# SOLO_RPW_140707_integratedFmChassis

Schedule from MS Project, 2012-05-07 to 2016-09-22, status date 2014-12-02, 7.7 hours a day, A marks actual dates.

## Calendars

- CNES Standard: Mon-Fri 09:00-16:42; Sat-Sun off. Exceptions (off unless hours are given): 2012-05-08, 2012-05-17, 2012-05-28, 2012-08-15, 2012-11-01, 2012-12-25, 2013-01-01, 2013-04-01, 2013-05-01, 2013-05-08 to 2013-05-09, 2013-05-20, 2013-08-15, 2013-11-01, 2013-11-11, 2013-12-25, 2014-01-01, 2014-04-21, 2014-05-01, 2014-05-08, 2014-05-29, 2014-06-09, 2014-07-14, 2014-08-15, 2014-11-11, 2014-12-25, 2015-01-01, 2015-04-06, 2015-05-01, 2015-05-08, 2015-05-14, 2015-05-25, 2015-07-14, 2015-11-11, 2015-12-25, 2016-01-01, 2016-03-28, 2016-05-05, 2016-05-16, 2016-07-14, 2016-08-15.
- Cnes_LVPS_PDU: Mon-Fri 09:00-16:42; Sat-Sun off. Exceptions (off unless hours are given): 2014-07-14 (14 juillet, recurring).
- Cnes_TDS: Mon-Fri 09:00-16:42; Sat-Sun off. Exceptions (off unless hours are given): 2014-06-09 (9 juin), 2014-07-14 (14 juillet, recurring), 2014-08-11 to 2014-08-18 (Eté), 2014-11-11 (11 Novembre), 2014-12-22 to 2015-01-03 (Noël).
- Cnes_DPU: Mon-Fri 09:00-16:42; Sat-Sun off. Exceptions (off unless hours are given): 2012-12-31 (290313), 2012-12-31 to 2021-12-31 (finAnnée_1, recurring), 2013-01-01 to 2022-01-01 (finAnnée_2, recurring), 2013-03-31 (310313), 2013-04-01 (010413), 2013-05-01 to 2022-05-01 (01mai, recurring), 2013-05-09 (090513), 2013-05-19 to 2013-05-20 (190513), 2013-05-30 (300513), 2013-08-15 to 2022-08-15 (15Aout, recurring), 2013-10-26 (261013), 2013-11-01 to 2022-11-01 (01Nov, recurring), 2013-12-08 to 2022-12-08 (08Dec, recurring), 2013-12-24 to 2022-12-24 (24Dec, recurring), 2013-12-25 to 2022-12-25 (25Dec, recurring), 2013-12-26 to 2022-12-26 (26Dec, recurring), 2014-04-06 (060415), 2014-04-18 (180414), 2014-04-20 (200414), 2014-04-21 (210414), 2014-05-29 (290514), 2014-06-08 to 2014-06-09 (080614), 2014-06-19 (190614), 2014-10-26 (261014), 2015-04-03 to 2015-04-06 (030415), 2015-05-14 (140515), 2015-05-24 to 2015-05-25 (240515), 2015-06-04 (040615), 2015-10-26 (261015).
- Cnes_BIAS: Mon-Fri 09:00-16:42; Sat-Sun off. Exceptions (off unless hours are given): 2014-07-14 to 2023-07-14 09:00-16:42 (14juillet, recurring), 2014-08-04 to 2014-08-14 (Ete14_1), 2014-08-18 to 2014-08-19 (Ete14_2), 2014-08-21 (Ete14_3), 2014-11-11 (11nov), 2014-12-22 to 2015-01-02 (Noel2015).
- Cnes_LFR: Mon-Fri 09:00-16:42; Sat-Sun off. Exceptions (off unless hours are given): 2012-08-06 to 2012-08-24 (Ete2012), 2012-12-24 to 2013-01-03 (Noel2012), 2013-05-01 (01mai, recurring), 2013-05-08 (080513), 2013-05-20 (200513), 2013-08-05 to 2013-08-23 (Ete2013), 2013-11-01 to 2022-11-01 (01Nov, recurring), 2013-11-11 (111113), 2013-12-23 to 2014-01-03 (Noel2013), 2014-04-21 (210414), 2014-05-01 (010514), 2014-05-08 (080514), 2014-06-09 (090614), 2014-07-14 (140714), 2014-08-04 to 2014-08-22 (Ete2014), 2014-11-11 (111114), 2014-12-22 to 2015-01-02 (Noel2014), 2015-08-03 to 2015-08-14 (Ete2015).
- Cnes_DAS_IDB: Mon-Fri 09:00-16:42; Sat-Sun off. Exceptions (off unless hours are given): 2013-02-25 to 2013-03-01 (250213), 2013-05-01 to 2013-05-03 (010513), 2013-05-06 to 2013-05-10 (060513), 2013-07-29 to 2013-08-02 (290713), 2013-08-05 to 2013-08-09 (050813), 2013-08-12 to 2013-08-16 (120813), 2013-08-19 to 2013-08-23 (190813).
- Cnes_TNR_HFR: Mon-Fri 09:00-16:42; Sat-Sun off. Exceptions (off unless hours are given): 2012-08-06 to 2012-08-24, 2012-12-24 to 2013-01-04, 2013-05-01, 2013-06-08, 2013-06-20, 2013-08-05 to 2013-08-23, 2013-11-01, 2013-11-11, 2013-12-23 to 2014-01-03, 2014-04-21, 2014-05-01, 2014-05-08, 2014-06-09, 2014-07-14, 2014-08-04 to 2014-08-22, 2014-11-11, 2014-12-22 to 2015-01-02, 2015-05-01, 2015-05-08, 2015-08-03 to 2015-08-21.
- Cnes_MEB_AIT: Mon-Fri 09:00-16:42; Sat-Sun off. Exceptions (off unless hours are given): 2014-12-22 to 2015-01-02, 2015-12-24 to 2016-01-01.

## Resources

| Resource | Group |
| --- | --- |
| ChanHin Christopher (MI-GSO) | DCT/DA /CP |
| Villora Elisabeth (MI-GSO) | DCT/DA /CP |
| Blandin Christophe (MI-GSO) | DCT/DA /CP |

## Schedule

| ID | WBS | Task | Type | Duration | Start | Finish | Predecessors | Complete | Remaining | Baseline start | Baseline finish | Baseline duration | Total slack | Constraint | ECHEANCE | FIN+NOM | Duplic | OldLg | Texte17 | Ancien Num |
| --- | --- | --- | --- | --- | --- | --- | --- | --- | --- | --- | --- | --- | --- | --- | --- | --- | --- | --- | --- | --- |
| 1 | 1 | **RPW Main Millestones** |  | 469d | 2014-11-14 | 2016-09-22 |  |  |  |  |  |  | 0d |  | NC RPW Main Millestones | 22/09/16 RPW Main Millestones |  |  |  |  |
| 2 | 1.1 | MEB EM DRB | milestone | 1d | 2014-11-14 | 2014-11-14 |  |  |  |  |  |  | 0d | start no earlier than 2014-11-14 | NC MEB EM DRB | 14/11/14 MEB EM DRB |  |  |  |  |
| 3 | 1.2 | MPCB | milestone | 1d | 2014-12-16 | 2014-12-16 |  |  |  |  |  |  | 0d | start no earlier than 2014-12-16 | NC MPCB | 16/12/14 MPCB |  |  |  |  |
| 4 | 1.3 | MEB EM DRB | milestone | 1d | 2014-11-14 | 2014-11-14 |  |  |  |  |  |  | 0d | start no earlier than 2014-11-14 | NC MEB EM DRB | 14/11/14 MEB EM DRB |  |  |  |  |
| 5 | 1.4 | SCM PFM and MEB PFM delivery to ESA (DRB) | milestone | 0d | 2016-06-28 | 2016-06-28 | 1082 |  |  |  |  |  | 0d |  | NC SCM PFM and MEB PFM delivery to ESA (DRB) | 28/06/16 SCM PFM and MEB PFM delivery to ESA (DRB) |  |  |  |  |
| 6 | 1.5 | ANT FM delivery to ESA (DRB) | milestone | 0d | 2016-09-22 | 2016-09-22 | 1086 |  |  |  |  |  | 0d |  | NC ANT FM delivery to ESA (DRB) | 22/09/16 ANT FM delivery to ESA (DRB) |  |  |  |  |
| 7 | 1.6 | ANT QM available for ESA/ ADS tests | milestone | 0d | 2015-08-05 | 2015-08-05 | 60SS |  |  |  |  |  | 0d |  | NC ANT QM available for ESA/ ADS tests | 05/08/15 ANT QM available for ESA/ ADS tests |  |  |  |  |
| 8 | 1.7 | **RPW CDR** |  | 393.5d | 2014-12-04 | 2016-06-27 |  |  |  |  |  |  | 0d |  | NC RPW CDR | 27/06/16 RPW CDR |  |  |  |  |
| 9 | 1.7.1 | Data package delivery | milestone | 0d | 2014-12-16 | 2014-12-16 |  |  |  |  |  |  | 0d | start no earlier than 2014-12-16 | NC Data package delivery | 16/12/14 Data package delivery |  |  |  |  |
| 10 | 1.7.2 | Kick Off meeting | milestone | 0d | 2015-01-13 | 2015-01-13 |  |  |  |  |  |  | 0d | start no earlier than 2015-01-13 | NC Kick Off meeting | 13/01/15 Kick Off meeting |  |  |  |  |
| 11 | 1.7.3 | RIDs availability for RPW team | milestone | 0d | 2015-01-22 | 2015-01-22 |  |  |  |  |  |  | 0d | start no earlier than 2015-01-22 | NC RIDs availability for RPW team | 22/01/15 RIDs availability for RPW team |  |  |  |  |
| 12 | 1.7.4 | RIDs Responses | milestone | 0d | 2015-01-30 | 2015-01-30 |  |  |  |  |  |  | 0d | start no earlier than 2015-01-30 | NC RIDs Responses | 30/01/15 RIDs Responses |  |  |  |  |
| 13 | 1.7.5 | Collocation meeting |  | 2d | 2015-02-05 | 2015-02-06 |  |  |  |  |  |  | 0d | start no earlier than 2015-02-05 | NC Collocation meeting | 06/02/15 Collocation meeting |  |  |  |  |
| 14 | 1.7.6 | Final CDR report (TBC) | milestone | 0d | 2015-03-06 | 2015-03-06 |  |  |  |  |  |  | 0d | start no earlier than 2015-03-06 | NC Final CDR report (TBC) | 06/03/15 Final CDR report (TBC) |  |  |  |  |
| 15 | 1.7.7 | Director board meeting (TBC) | milestone | 0d | 2015-03-12 | 2015-03-12 |  |  |  |  |  |  | 0d | start no earlier than 2015-03-12 | NC Director board meeting (TBC) | 12/03/15 Director board meeting (TBC) |  |  |  |  |
| 16 | 1.7.8 | **RPW qualification review** |  | 201.5d | 2015-09-10 | 2016-06-27 |  |  |  |  |  |  | 0d |  | NC RPW qualification review | 27/06/16 RPW qualification review |  |  |  |  |
| 17 | 1.7.8.1 | ANT QR |  | 5d | 2015-09-10 | 2015-09-16 | 65SS |  |  |  |  |  | 0d |  | NC ANT QR | 16/09/15 ANT QR | 6107 |  |  |  |
| 18 | 1.7.8.2 | MEB & SCM QR |  | 17d | 2016-06-02 | 2016-06-27 | 1079 |  |  |  |  |  | 0d |  | NC MEB & SCM QR | 27/06/16 MEB & SCM QR |  |  |  |  |
| 19 | 1.7.9 | SW reviews |  | 1d | 2014-12-04 | 2014-12-04 |  |  |  |  |  |  | 0d | start no earlier than 2014-12-04 | NC SW reviews | 04/12/14 SW reviews |  |  |  |  |
| 20 | 2 | **ANTENNA SYSTEM** |  | 954d | 2012-11-08 A | 2016-08-24 |  | 39% | 583.03d | 2011-01-03 | 2014-05-16 | 851d | 0d |  |  | 24/08/16 ANTENNA SYSTEM |  | 52 | 52 | 52 |
| 21 | 2.1 | **Antenna subsystem (Stellar)** |  | 563d | 2014-06-02 A | 2016-08-24 |  | 14% | 485.56d | 2012-10-01 | 2014-05-16 | 409d | 0d |  |  | 24/08/16 Antenna subsystem (Stellar) |  | 53 | 53 | 53 |
| 22 | 2.1.1 | **QM Models** |  | 316d | 2014-06-02 A | 2015-09-02 |  | 20% | 253.92d |  |  |  | 0d |  |  | 02/09/15 QM Models |  |  | 54 |  |
| 23 | 2.1.1.1 | **QM Design** |  | 107d | 2014-06-02 A | 2014-10-31 |  | 52% | 51.24d |  |  |  | 0d |  |  | 31/10/14 QM Design |  |  | 55 |  |
| 24 | 2.1.1.1.1 | KO Meeting | milestone | 0d | 2014-06-02 | 2014-06-02 |  |  |  |  |  |  | 0d | start no earlier than 2014-06-02 | NC KO Meeting | 02/06/14 KO Meeting |  |  | 56 |  |
| 25 | 2.1.1.1.2 | Design, interface & Requirements Review |  | 39d | 2014-06-02 | 2014-07-28 | 24 |  |  |  |  |  | 0d |  | NC Design, interface & Requirements Review | 28/07/14 Design, interface & Requirements Review |  |  | 57 |  |
| 26 | 2.1.1.1.3 | Design Key Point |  | 3d | 2014-07-29 | 2014-07-31 | 25 |  |  |  |  |  | 0d |  | NC Design Key Point | 31/07/14 Design Key Point |  |  | 63 |  |
| 27 | 2.1.1.1.4 | QM Design + Detailled |  | 60d | 2014-08-01 | 2014-10-24 | 26 |  |  |  |  |  | 0d |  | NC QM Design + Detailled | 24/10/14 QM Design + Detailled |  |  | 59 |  |
| 28 | 2.1.1.1.5 | QM Design Review (CDR) |  | 4d | 2014-10-13 A | 2014-10-16 A | 27FS-10d | 100% |  |  |  |  |  |  | NC QM Design Review (CDR) | 16/10/14 QM Design Review (CDR) |  |  | 60 |  |
| 29 | 2.1.1.1.6 | RFQs Long Leads |  | 107d | 2014-06-02 A | 2014-10-31 A | 24 | 100% |  |  |  |  |  |  | NC RFQs Long Leads | 31/10/14 RFQs Long Leads |  |  | 58 |  |

| ID | WBS | Task | Type | Duration | Start | Finish | Predecessors | Total slack | Free slack | Constraint |
| --- | --- | --- | --- | --- | --- | --- | --- | --- | --- | --- |
| 30 | 2.1.1.2 | **QM Development Planning** |  | 234d | 2014-09-29 | 2015-09-02 |  | 0d |  |  |
| 31 | 2.1.1.2.1 | Delay / Slack |  | 18d | 2014-10-17 | 2014-11-12 | 28 | 0d |  |  |
| 32 | 2.1.1.2.2 | MRR Documentation |  | 17d | 2014-11-13 | 2014-12-05 | 31 | 0d |  |  |
| 33 | 2.1.1.2.3 | MRR Document Review |  | 5d | 2014-12-08 | 2014-12-12 | 32 | 0d |  |  |
| 34 | 2.1.1.2.4 | Thermal solar vaccum tests on criticals elements (SAO)incl.documentation |  | 15d | 2015-01-05 | 2015-01-23 |  | 0d |  | start no earlier than 2015-01-05 |
| 35 | 2.1.1.2.5 | Sun T Vac on ANT criticals elements | milestone | 0d | 2015-01-23 | 2015-01-23 | 34FF | 0d |  |  |
| 36 | 2.1.1.2.6 | ESA inputs consolidation( RFDs, Thrusters) |  | 10d | 2015-01-13 | 2015-01-26 |  | 0d |  | start no earlier than 2015-01-13 |
| 37 | 2.1.1.2.7 | ANT I/F ESA inputs | milestone | 0d | 2015-01-26 | 2015-01-26 | 36FF | 0d |  |  |
| 38 | 2.1.1.2.8 | Long Lead Item Arrival |  | 87d | 2014-09-29 | 2015-01-30 |  | 0d |  | start no earlier than 2014-09-29 |
| 39 | 2.1.1.2.9 | **ANT QM fabrication & qualification** |  | 184d | 2014-12-09 | 2015-09-02 |  | 0d |  |  |
| 40 | 2.1.1.2.9.1 | ANT QM MRR | milestone | 2d | 2015-01-27 | 2015-01-28 | 34, 36 | 0d |  |  |
| 41 | 2.1.1.2.9.2 | QM PA BOX fabrication |  | 28d | 2014-12-09 | 2015-01-19 |  | 1d | 0d | start no earlier than 2014-12-09 |
| 42 | 2.1.1.2.9.3 | QM Parts Fabrication |  | 28d | 2015-01-29 | 2015-03-09 | 40 | 0d |  |  |
| 43 | 2.1.1.2.9.4 | PA Box Delivery 1 to 4 from Stellar |  | 5d | 2015-01-20 | 2015-01-26 | 41 | 1d |  |  |
| 44 | 2.1.1.2.9.5 | QM PA From CNES | milestone | 0d | 2015-03-25 | 2015-03-25 | 45FF-8d, 198 | 0d |  |  |
| 45 | 2.1.1.2.9.6 | QM Assembly |  | 20d | 2015-03-10 | 2015-04-07 | 42 | 0d |  |  |
| 46 | 2.1.1.2.9.7 | QM Bench Tests |  | 10d | 2015-04-08 | 2015-04-21 | 45 | 0d |  |  |
| 47 | 2.1.1.2.9.8 | Reserve |  | 5d | 2015-04-22 | 2015-04-28 | 46 | 0d |  |  |
| 48 | 2.1.1.2.9.9 | TRR Documentation |  | 5d | 2015-04-29 | 2015-05-06 | 47 | 0d |  |  |
| 49 | 2.1.1.2.9.10 | Document Review |  | 5d | 2015-05-07 | 2015-05-15 | 48 | 0d |  |  |
| 50 | 2.1.1.2.9.11 | QM TRR |  | 5d | 2015-05-18 | 2015-05-22 | 49 | 0d |  |  |
| 51 | 2.1.1.2.9.12 | Reserve |  | 5d | 2015-05-26 | 2015-06-01 | 50 | 0d |  |  |
| 52 | 2.1.1.2.9.13 | QM Pre-Qual Tests |  | 8d | 2015-06-02 | 2015-06-11 | 51 | 0d |  |  |
| 53 | 2.1.1.2.9.14 | QM Qual Tests |  | 15d | 2015-06-12 | 2015-07-02 | 52 | 0d |  |  |
| 54 | 2.1.1.2.9.15 | QM Post-Qual Tests |  | 4d | 2015-07-03 | 2015-07-08 | 53 | 0d |  |  |
| 55 | 2.1.1.2.9.16 | Reserve |  | 5d | 2015-07-08 | 2015-07-15 | 54FS-1d | 0d |  |  |
| 56 | 2.1.1.2.9.17 | Sun thermal vaccum test (ITS) -> TBC |  | 20d | 2015-07-16 | 2015-08-12 | 55 | 0d |  |  |
| 57 | 2.1.1.2.9.18 | Tests end to end EMC/RF (Figarol) - Including transportation |  | 15d | 2015-08-13 | 2015-09-02 | 56 | 0d |  |  |
| 58 | 2.1.1.2.9.19 | QR Documentation |  | 5d | 2015-07-16 | 2015-07-22 | 55 | 0d |  |  |
| 59 | 2.1.1.2.9.20 | Document Review |  | 10d | 2015-07-23 | 2015-08-05 | 58 | 0d |  |  |
| 60 | 2.1.1.2.9.21 | ANT QM available for ESA/ ADS tests | milestone | 0d | 2015-08-05 | 2015-08-05 | 59 | 0d |  |  |

Notes:
- 30: ECHEANCE: NC QM Development Planning / FIN+NOM: 02/09/15 QM Development Planning
- 31: ECHEANCE: NC Delay / Slack / FIN+NOM: 12/11/14 Delay / Slack
- 32: ECHEANCE: NC MRR Documentation / FIN+NOM: 05/12/14 MRR Documentation
- 33: ECHEANCE: NC MRR Document Review / FIN+NOM: 12/12/14 MRR Document Review
- 34: ECHEANCE: NC Thermal solar vaccum tests on criticals elements (SAO)incl.documentation / FIN+NOM: 23/01/15 Thermal solar vaccum tests on criticals elements (SAO)incl.documentation
- 35: ECHEANCE: NC Sun T Vac on ANT criticals elements / FIN+NOM: 23/01/15 Sun T Vac on ANT criticals elements
- 36: ECHEANCE: NC ESA inputs consolidation( RFDs, Thrusters) / FIN+NOM: 26/01/15 ESA inputs consolidation( RFDs, Thrusters)
- 37: ECHEANCE: NC ANT I/F ESA inputs / FIN+NOM: 26/01/15 ANT I/F ESA inputs
- 38: ECHEANCE: NC Long Lead Item Arrival / FIN+NOM: 30/01/15 Long Lead Item Arrival
- 39: ECHEANCE: NC ANT QM fabrication & qualification / FIN+NOM: 02/09/15 ANT QM fabrication & qualification
- 40: ECHEANCE: NC ANT QM MRR / FIN+NOM: 28/01/15 ANT QM MRR
- 41: ECHEANCE: NC QM PA BOX fabrication / FIN+NOM: 19/01/15 QM PA BOX fabrication
- 42: ECHEANCE: NC QM Parts Fabrication / FIN+NOM: 09/03/15 QM Parts Fabrication
- 43: ECHEANCE: NC PA Box Delivery 1 to 4 from Stellar / FIN+NOM: 26/01/15 PA Box Delivery 1 to 4 from Stellar
- 44: ECHEANCE: NC QM PA From CNES / FIN+NOM: 25/03/15 QM PA From CNES
- 45: ECHEANCE: NC QM Assembly / FIN+NOM: 07/04/15 QM Assembly
- 46: ECHEANCE: NC QM Bench Tests / FIN+NOM: 21/04/15 QM Bench Tests
- 47: ECHEANCE: NC Reserve / FIN+NOM: 28/04/15 Reserve
- 48: ECHEANCE: NC TRR Documentation / FIN+NOM: 06/05/15 TRR Documentation
- 49: ECHEANCE: NC Document Review / FIN+NOM: 15/05/15 Document Review
- 50: ECHEANCE: NC QM TRR / FIN+NOM: 22/05/15 QM TRR
- 51: ECHEANCE: NC Reserve / FIN+NOM: 01/06/15 Reserve
- 52: ECHEANCE: NC QM Pre-Qual Tests / FIN+NOM: 11/06/15 QM Pre-Qual Tests
- 53: ECHEANCE: NC QM Qual Tests / FIN+NOM: 02/07/15 QM Qual Tests
- 54: ECHEANCE: NC QM Post-Qual Tests / FIN+NOM: 08/07/15 QM Post-Qual Tests
- 55: ECHEANCE: NC Reserve / FIN+NOM: 15/07/15 Reserve
- 56: ECHEANCE: NC Sun thermal vaccum test (ITS) -> TBC / FIN+NOM: 12/08/15 Sun thermal vaccum test (ITS) -> TBC
- 57: ECHEANCE: NC Tests end to end EMC/RF (Figarol) - Including transportation / FIN+NOM: 02/09/15 Tests end to end EMC/RF (Figarol) - Including transportation
- 58: ECHEANCE: NC QR Documentation / FIN+NOM: 22/07/15 QR Documentation
- 59: ECHEANCE: NC Document Review / FIN+NOM: 05/08/15 Document Review
- 60: ECHEANCE: NC ANT QM available for ESA/ ADS tests / FIN+NOM: 05/08/15 ANT QM available for ESA/ ADS tests

| ID | WBS | Task | Type | Duration | Start | Finish | Predecessors | Total slack | Free slack | Texte17 |
| --- | --- | --- | --- | --- | --- | --- | --- | --- | --- | --- |
| 61 | 2.1.2 | **FM Built** |  | 262d | 2015-08-13 | 2016-08-24 |  | 0d |  | 67 |
| 62 | 2.1.2.1 | **ANTENNA FM Development Planning** |  | 262d | 2015-08-13 | 2016-08-24 |  | 0d |  |  |
| 63 | 2.1.2.1.1 | **ANT FM Fabrication** |  | 81d | 2015-08-13 | 2015-12-04 |  | 0d |  |  |
| 64 | 2.1.2.1.1.1 | Reserve |  | 20d | 2015-08-13 | 2015-09-09 | 59, 56 | 0d |  |  |
| 65 | 2.1.2.1.1.2 | Qualification review |  | 5d | 2015-09-10 | 2015-09-16 | 64 | 0d |  |  |
| 66 | 2.1.2.1.1.3 | FM-MRR |  | 1d | 2015-09-24 | 2015-09-24 | 65FS+5d | 18d | 0d |  |
| 67 | 2.1.2.1.1.4 | RFAs/FM Design changes |  | 10d | 2015-09-25 | 2015-10-08 | 66 | 18d | 0d |  |
| 68 | 2.1.2.1.1.5 | FM Parts Fabrication |  | 40d | 2015-10-09 | 2015-12-04 | 67 | 18d | 0d |  |
| 69 | 2.1.2.1.1.6 | PA Box Delivery 2 (with transportation) / 8 BOX FM (4 for PCB FM & 4 for PCB EQM) | milestone | 0d | 2015-09-30 | 2015-09-30 | 65FS+10d | 84d | 66d |  |
| 70 | 2.1.2.1.1.7 | 4 FM BOX PA (PCB EQM) From CNES to Stelar | milestone | 0d | 2015-10-19 | 2015-10-19 | 212FS+10d | 0d |  |  |
| 71 | 2.1.2.1.1.8 | PAs EQM for AIT ANT Phase1 | milestone | 0d | 2015-10-19 | 2015-10-19 | 70SS | 51.5d | 33.5d |  |
| 72 | 2.1.2.1.2 | **ANT FM AIT phase 1** |  | 132.5d | 2015-12-07 | 2016-06-15 |  | 0.5d |  |  |
| 73 | 2.1.2.1.2.1 | FM Assembly |  | 20d | 2015-12-07 | 2016-01-05 | 68, 71 | 18d | 0d |  |
| 74 | 2.1.2.1.2.2 | FM Bench Tests |  | 15d | 2016-01-06 | 2016-01-26 | 69, 73 | 18d | 0d |  |
| 75 | 2.1.2.1.2.3 | TRR Documentation |  | 5d | 2016-01-27 | 2016-02-02 | 74 | 18d | 0d |  |
| 76 | 2.1.2.1.2.4 | Document Review |  | 4d | 2016-02-03 | 2016-02-08 | 75 | 18d | 0d |  |
| 77 | 2.1.2.1.2.5 | FM TRR |  | 5d | 2016-02-09 | 2016-02-15 | 76 | 18d | 0d |  |
| 78 | 2.1.2.1.2.6 | RFAs |  | 5d | 2016-02-16 | 2016-02-22 | 77 | 18d | 0d |  |
| 79 | 2.1.2.1.2.7 | **FM Pre-acceptance tests** |  | 19d | 2016-02-23 | 2016-03-18 |  | 18d |  |  |
| 80 | 2.1.2.1.2.7.1 | TR17 Inspection |  | 2d | 2016-02-23 | 2016-02-24 | 78 | 18d | 0d |  |
| 81 | 2.1.2.1.2.7.2 | TR3/TR8/TR14 |  | 2d | 2016-02-25 | 2016-02-26 | 80 | 18d | 0d |  |
| 82 | 2.1.2.1.2.7.3 | ANT1 Pre-Environment |  | 4d | 2016-02-29 | 2016-03-03 | 81 | 18d | 0d |  |
| 83 | 2.1.2.1.2.7.4 | ANT2 Pre-Environment |  | 4d | 2016-03-04 | 2016-03-09 | 82 | 18d | 0d |  |
| 84 | 2.1.2.1.2.7.5 | ANT3 Pre-Environment |  | 4d | 2016-03-10 | 2016-03-15 | 83 | 18d | 0d |  |
| 85 | 2.1.2.1.2.7.6 | Spare Pre-Environment |  | 3d | 2016-03-16 | 2016-03-18 | 84 | 18d | 0d |  |

Notes:
- 61: FIN+NOM: 24/08/16 FM Built
- 62: FIN+NOM: 24/08/16 ANTENNA FM Development Planning
- 63: ECHEANCE: NC ANT FM Fabrication / FIN+NOM: 04/12/15 ANT FM Fabrication
- 64: ECHEANCE: NC Reserve / FIN+NOM: 09/09/15 Reserve
- 65: ECHEANCE: NC Qualification review / FIN+NOM: 16/09/15 Qualification review
- 66: ECHEANCE: NC FM-MRR / FIN+NOM: 24/09/15 FM-MRR
- 67: ECHEANCE: NC RFAs/FM Design changes / FIN+NOM: 08/10/15 RFAs/FM Design changes
- 68: ECHEANCE: NC FM Parts Fabrication / FIN+NOM: 04/12/15 FM Parts Fabrication
- 69: ECHEANCE: NC PA Box Delivery 2 (with transportation) / 8 BOX FM (4 for PCB FM & 4 for PCB EQM) / FIN+NOM: 30/09/15 PA Box Delivery 2 (with transportation) / 8 BOX FM (4 for PCB FM & 4 for PCB EQM)
- 70: ECHEANCE: NC 4 FM BOX PA (PCB EQM) From CNES to Stelar / FIN+NOM: 19/10/15 4 FM BOX PA (PCB EQM) From CNES to Stelar
- 71: ECHEANCE: NC PAs EQM for AIT ANT Phase1 / FIN+NOM: 19/10/15 PAs EQM for AIT ANT Phase1
- 72: ECHEANCE: NC ANT FM AIT phase 1 / FIN+NOM: 15/06/16 ANT FM AIT phase 1
- 73: ECHEANCE: NC FM Assembly / FIN+NOM: 05/01/16 FM Assembly
- 74: ECHEANCE: NC FM Bench Tests / FIN+NOM: 26/01/16 FM Bench Tests
- 75: ECHEANCE: NC TRR Documentation / FIN+NOM: 02/02/16 TRR Documentation
- 76: ECHEANCE: NC Document Review / FIN+NOM: 08/02/16 Document Review
- 77: ECHEANCE: NC FM TRR / FIN+NOM: 15/02/16 FM TRR
- 78: ECHEANCE: NC RFAs / FIN+NOM: 22/02/16 RFAs
- 79: ECHEANCE: NC FM Pre-acceptance tests / FIN+NOM: 18/03/16 FM Pre-acceptance tests
- 80: ECHEANCE: NC TR17 Inspection / FIN+NOM: 24/02/16 TR17 Inspection
- 81: ECHEANCE: NC TR3/TR8/TR14 / FIN+NOM: 26/02/16 TR3/TR8/TR14
- 82: ECHEANCE: NC ANT1 Pre-Environment / FIN+NOM: 03/03/16 ANT1 Pre-Environment
- 83: ECHEANCE: NC ANT2 Pre-Environment / FIN+NOM: 09/03/16 ANT2 Pre-Environment
- 84: ECHEANCE: NC ANT3 Pre-Environment / FIN+NOM: 15/03/16 ANT3 Pre-Environment
- 85: ECHEANCE: NC Spare Pre-Environment / FIN+NOM: 18/03/16 Spare Pre-Environment

| ID | WBS | Task | Type | Duration | Start | Finish | Predecessors | Complete | Remaining | Baseline start | Baseline finish | Baseline duration | Total slack | Free slack | Constraint | ECHEANCE | FIN+NOM | OldLg | Texte17 | Ancien Num |
| --- | --- | --- | --- | --- | --- | --- | --- | --- | --- | --- | --- | --- | --- | --- | --- | --- | --- | --- | --- | --- |
| 86 | 2.1.2.1.2.8 | **FM Environments** |  | 16d | 2016-03-21 | 2016-04-12 |  |  |  |  |  |  | 18d |  |  | NC FM Environments | 12/04/16 FM Environments |  |  |  |
| 87 | 2.1.2.1.2.8.1 | TR28 Sine & Random |  | 3d | 2016-03-21 | 2016-03-23 | 85 |  |  |  |  |  | 18d | 0d |  | NC TR28 Sine & Random | 23/03/16 TR28 Sine & Random |  |  |  |
| 88 | 2.1.2.1.2.8.2 | TR28 Acoustic |  | 5d | 2016-03-24 | 2016-03-31 | 87 |  |  |  |  |  | 18d | 0d |  | NC TR28 Acoustic | 31/03/16 TR28 Acoustic |  |  |  |
| 89 | 2.1.2.1.2.8.3 | TR25 Tvac |  | 8d | 2016-04-01 | 2016-04-12 | 88 |  |  |  |  |  | 18d | 0d |  | NC TR25 Tvac | 12/04/16 TR25 Tvac |  |  |  |
| 90 | 2.1.2.1.2.9 | **FM Post-acceptance tests** |  | 16d | 2016-04-13 | 2016-05-04 |  |  |  |  |  |  | 18d |  |  | NC FM Pre-acceptance tests | 04/05/16 FM Post-acceptance tests |  |  |  |
| 91 | 2.1.2.1.2.9.1 | ANT1 Post-Environment |  | 4d | 2016-04-13 | 2016-04-18 | 89 |  |  |  |  |  | 18d | 0d |  | NC ANT1 Post-Environment | 18/04/16 ANT1 Post-Environment |  |  |  |
| 92 | 2.1.2.1.2.9.2 | ANT2 Post-Environment |  | 4d | 2016-04-19 | 2016-04-22 | 91 |  |  |  |  |  | 18d | 0d |  | NC ANT2 Post-Environment | 22/04/16 ANT2 Post-Environment |  |  |  |
| 93 | 2.1.2.1.2.9.3 | ANT3 Post-Environment |  | 4d | 2016-04-25 | 2016-04-28 | 92 |  |  |  |  |  | 18d | 0d |  | NC ANT3 Post-Environment | 28/04/16 ANT3 Post-Environment |  |  |  |
| 94 | 2.1.2.1.2.9.4 | Spare Post-Environment |  | 4d | 2016-04-29 | 2016-05-04 | 93 |  |  |  |  |  | 18d | 0d |  | NC Spare Post-Environment | 04/05/16 Spare Post-Environment |  |  |  |
| 95 | 2.1.2.1.2.10 | Reserve |  | 10d | 2016-05-06 | 2016-05-20 | 94 |  |  |  |  |  | 18d | 17.5d |  | NC Reserve | 20/05/16 Reserve |  |  |  |
| 96 | 2.1.2.1.2.11 | 3 FM PA + spare From CNES |  | 4d | 2016-06-09 | 2016-06-15 | 218, 1075FS+20d |  |  |  |  |  | 0.5d | 0d |  | NC 3 FM PA + spare From CNES | 15/06/16 3 FM PA + spare From CNES |  |  |  |
| 97 | 2.1.2.1.2.12 | PAs FM for AIT ANT Phase2 | milestone | 0d | 2016-06-15 | 2016-06-15 | 96FF |  |  |  |  |  | 0.5d | 0d |  | NC PAs FM for AIT ANT Phase2 | 15/06/16 PAs FM for AIT ANT Phase2 |  |  |  |
| 98 | 2.1.2.1.3 | **ANT FM AIT phase 2** |  | 48.5d | 2016-06-15 | 2016-08-24 |  |  |  |  |  |  | 0d |  |  | NC ANTENNA FM Phase 2 | 24/08/16 ANT FM AIT phase 2 |  |  |  |
| 99 | 2.1.2.1.3.1 | FM PA I & T |  | 15d | 2016-06-15 | 2016-07-06 | 97, 95 |  |  |  |  |  | 0.5d | 0d |  | NC FM PA I & T | 06/07/16 FM PA I & T |  |  |  |
| 100 | 2.1.2.1.3.2 | FM Bake-Out |  | 4d | 2016-07-06 | 2016-07-12 | 99 |  |  |  |  |  | 0.5d | 0d |  | NC FM Bake-Out | 12/07/16 FM Bake-Out |  |  |  |
| 101 | 2.1.2.1.3.3 | EIDP & Doc Prep |  | 4d | 2016-07-12 | 2016-07-19 | 100 |  |  |  |  |  | 0.5d | 0d |  | NC EIDP & Doc Prep | 19/07/16 EIDP & Doc Prep |  |  |  |
| 102 | 2.1.2.1.3.4 | **Review & Delivery** |  | 25.5d | 2016-07-19 | 2016-08-24 |  |  |  |  |  |  | 0d |  |  | NC Review & Delivery | 24/08/16 Review & Delivery |  |  |  |
| 103 | 2.1.2.1.3.4.1 | Antenna FM DRB |  | 5d | 2016-07-19 | 2016-07-26 | 101 |  |  |  |  |  | 0.5d | 0d |  | NC Antenna FM DRB | 26/07/16 Antenna FM DRB |  |  |  |
| 104 | 2.1.2.1.3.4.2 | Satisfy RFAs |  | 9d | 2016-07-26 | 2016-08-08 | 103 |  |  |  |  |  | 0.5d | 0d |  | NC Satisfy RFAs | 08/08/16 Satisfy RFAs |  |  |  |
| 105 | 2.1.2.1.3.4.3 | FM Model Prep |  | 5d | 2016-08-08 | 2016-08-16 | 104 |  |  |  |  |  | 0.5d |  |  | NC FM Model Prep | 16/08/16 FM Model Prep |  |  |  |
| 106 | 2.1.2.1.3.4.4 | Ship to Cnes |  | 5d | 2016-08-18 | 2016-08-24 | 105FS+1d |  |  |  |  |  | 0d |  | finish no earlier than 2016-08-24 | NC Ship to Cnes | 24/08/16 Ship to Cnes |  |  |  |
| 107 | 2.2 | **Preamplifier PCB (LESIA+CNES-IRF)** |  | 771d | 2012-11-08 A | 2015-12-02 |  | 64% | 275.95d | 2011-01-03 | 2014-05-16 | 851d | 0d |  |  |  | 02/12/15 Preamplifier PCB (LESIA+CNES-IRF) | 99 | 72 | 108 |
| 108 | 2.2.1 | **PA PCB Subset** |  | 215d | 2012-11-08 A | 2013-09-16 A |  | 100% |  | 2012-11-09 | 2013-05-16 | 129d |  |  |  |  | 16/09/13 PA PCB Subset | 100 | 73 | 109 |
| 109 | 2.2.1.1 | Delivery of the analyse note |  | 1d | 2012-11-09 A | 2012-11-09 A |  | 100% |  | 2012-11-09 | 2012-11-09 | 1d |  |  | start no earlier than 2012-11-09 | NC Delivery of the analyse note | 09/11/12 Delivery of the analyse note | 101 | 74 | 110 |
| 110 | 2.2.1.2 | Schematic updates |  | 28d | 2012-12-03 A | 2013-01-11 A |  | 100% |  | 2012-12-03 | 2013-01-11 | 28d |  |  | start no earlier than 2012-12-03 | NC Schematic updates | 11/01/13 Schematic updates | 102 | 75 | 111 |
| 111 | 2.2.1.3 | Design of the PCB layout |  | 25d | 2013-01-14 A | 2013-02-15 A | 110 | 100% |  | 2013-01-14 | 2013-02-22 | 30d |  |  |  | NC Design of the PCB layout | 15/02/13 Design of the PCB layout | 103 | 76 | 112 |
| 112 | 2.2.1.4 | PCB manufacturing |  | 30d | 2013-02-18 A | 2013-03-29 A | 111 | 100% |  | 2013-02-25 | 2013-04-08 | 30d |  |  |  | NC PCB manufacturing | 29/03/13 PCB manufacturing | 104 | 77 | 113 |
| 113 | 2.2.1.5 | Parts assembly |  | 20d | 2013-04-02 A | 2013-04-29 A | 112 | 100% |  | 2013-04-09 | 2013-04-19 | 9d |  |  |  | NC Parts assembly | 29/04/13 Parts assembly | 105 | 78 | 114 |
| 114 | 2.2.1.6 | Parts procurement |  | 100d | 2012-11-08 A | 2013-03-29 A | 113SF | 100% |  | 2012-11-15 | 2013-04-09 | 100d |  |  |  | NC Parts procurement | 29/03/13 Parts procurement | 106 | 79 | 115 |
| 115 | 2.2.1.7 | H/W delivery to LESIA | milestone | 0d | 2013-04-29 A | 2013-04-29 A | 113, 114 | 100% |  | 2013-04-09 | 2013-04-09 | 1d |  |  |  | NC H/W delivery to LESIA | 29/04/13 H/W delivery to LESIA | 107 | 80 | 116 |
| 116 | 2.2.1.8 | Functional and performance tests |  | 8d | 2013-04-30 A | 2013-05-14 A | 115 | 100% |  | 2013-04-10 | 2013-04-29 | 14d |  |  |  | NC Functional and performance tests | 14/05/13 Functional and performance tests | 108 | 81 | 117 |
| 117 | 2.2.1.9 | Thermal tests |  | 5d | 2013-05-15 A | 2013-05-22 A | 116 | 100% |  | 2013-04-30 | 2013-05-16 | 10d |  |  |  | NC Thermal tests | 22/05/13 Thermal tests | 109 | 82 | 118 |
| 118 | 2.2.1.10 | PA PCB Subset acceptance (LESIA) |  | 2d | 2013-05-23 A | 2013-05-24 A | 117 | 100% |  | 2013-05-16 | 2013-05-16 | 0d |  |  |  | NC PA PCB Subset acceptance (LESIA) | 24/05/13 PA PCB Subset acceptance (LESIA) | 110 | 83 | 119 |
| 119 | 2.2.1.11 | PA PCB Subset CNES validation |  | 80d | 2013-05-27 A | 2013-09-16 A | 118 | 100% |  |  |  |  |  |  |  | NC PA PCB Subset CNES validation | 16/09/13 PA PCB Subset CNES validation |  | 84 |  |

| ID | WBS | Task | Type | Duration | Start | Finish | Predecessors | Complete | Remaining | Baseline start | Baseline finish | Baseline duration | Total slack | Constraint | OldLg | Texte17 | Ancien Num |
| --- | --- | --- | --- | --- | --- | --- | --- | --- | --- | --- | --- | --- | --- | --- | --- | --- | --- |
| 120 | 2.2.2 | **PA PCB EM for tests (x6)** |  | 135d | 2013-09-17 A | 2014-03-28 A |  | 100% |  | 2011-01-03 | 2013-04-26 | 588d |  |  | 111 | 85 | 120 |
| 121 | 2.2.2.1 | PA PCB EM manufacturing and tests |  | 135d | 2013-09-17 A | 2014-03-28 A | 119 | 100% |  |  |  |  |  |  |  | 86 |  |
| 122 | 2.2.2.2 | PA PCB EM ready for MEB and RPW tests (x4 for CNES) | milestone | 0d | 2014-03-28 A | 2014-03-28 A | 121 | 100% |  | 2013-04-26 | 2013-04-26 | 0d |  |  | 123 | 87 | 132 |
| 123 | 2.2.3 | **PA PCB EQM HF (x4)** |  | 182d | 2014-05-02 A | 2015-01-22 |  | 77% | 42.47d | 2013-09-30 | 2014-02-04 | 88d | 3d |  | 124 | 88 | 133 |
| 124 | 2.2.3.1 | Schematic updates |  | 29d | 2014-05-02 A | 2014-06-16 A |  | 100% |  | 2013-09-30 | 2013-10-18 | 15d |  | start no earlier than 2014-05-02 | 125 | 89 | 134 |
| 125 | 2.2.3.2 | Design of the PCB layout |  | 10d | 2014-06-17 A | 2014-06-30 A | 124 | 100% |  | 2013-10-21 | 2013-10-31 | 9d |  |  | 126 | 90 | 135 |
| 126 | 2.2.3.3 | PCB manufacturing |  | 43d | 2014-07-01 A | 2014-09-01 A | 125 | 100% |  | 2013-11-04 | 2013-12-13 | 29d |  |  | 127 | 91 | 136 |
| 127 | 2.2.3.4 | Parts assembly |  | 25d | 2014-09-02 A | 2014-10-06 A | 126 | 100% |  | 2013-12-16 | 2014-01-14 | 20d |  |  | 128 | 92 | 137 |
| 128 | 2.2.3.5 | H/W delivery to LESIA | milestone | 0d | 2014-10-06 A | 2014-10-06 A | 127 | 100% |  | 2014-01-14 | 2014-01-14 | 0d |  |  | 129 | 93 | 138 |
| 129 | 2.2.3.6 | Design uddate |  | 33d | 2014-10-07 A | 2014-11-21 | 128 | 94% | 2d |  |  |  | 0d |  |  |  |  |
| 130 | 2.2.3.7 | MRR |  | 1d | 2014-11-24 | 2014-11-24 | 129 |  |  |  |  |  | 0d |  |  |  |  |
| 131 | 2.2.3.8 | Modification implementation (RESA) |  | 8d | 2014-11-24 | 2014-12-03 | 129 |  |  |  |  |  | 0d |  |  |  |  |
| 132 | 2.2.3.9 | Modification validation (Lésia) |  | 3d | 2014-12-04 | 2014-12-08 | 131 |  |  |  |  |  | 0d |  |  |  |  |
| 133 | 2.2.3.10 | Coating (RESA) |  | 5d | 2014-12-09 | 2014-12-15 | 132 |  |  |  |  |  | 0d |  |  |  |  |
| 134 | 2.2.3.11 | TRR |  | 1d | 2014-12-16 | 2014-12-16 | 133 |  |  |  |  |  | 0d |  |  |  |  |
| 135 | 2.2.3.12 | Functional and performance tests including documentation |  | 21d | 2014-12-16 | 2015-01-15 | 133 |  |  | 2014-01-15 | 2014-02-04 | 15d | 0d |  | 130 | 94 | 139 |
| 136 | 2.2.3.13 | TRB & DRB |  | 1d | 2015-01-16 | 2015-01-16 | 135 |  |  |  |  |  | 0d |  |  |  |  |
| 137 | 2.2.3.14 | PA PCB QM HF ready for AIT (x4 for CNES) | milestone | 0d | 2015-01-22 | 2015-01-22 | 135FS+5d |  |  | 2014-02-04 | 2014-02-04 | 0d | 3d |  | 132 | 96 | 141 |
| 138 | 2.2.4 | **PA PCB EQM LF (x4)** |  | 185d | 2014-05-02 A | 2015-01-27 |  | 38% | 114.41d | 2013-09-30 | 2014-02-04 | 88d | 0d |  | 124 | 88 | 133 |
| 139 | 2.2.4.1 | Schematic updates |  | 29d | 2014-05-02 A | 2014-06-16 A |  | 100% |  | 2013-09-30 | 2013-10-18 | 15d |  | start no earlier than 2014-05-02 | 125 | 89 | 134 |
| 140 | 2.2.4.2 | Final design of the PCB layout | milestone | 0d | 2014-11-20 A | 2014-11-20 A | 139 | 100% |  | 2013-10-21 | 2013-10-31 | 9d |  |  | 126 | 90 | 135 |
| 141 | 2.2.4.3 | PCB manufacturing (*7) |  | 20d | 2014-11-20 | 2014-12-17 | 140 |  |  | 2013-11-04 | 2013-12-13 | 29d | 0d | start no earlier than 2014-09-08 | 127 | 91 | 136 |
| 142 | 2.2.4.4 | PCB * 3 delivery IRF | milestone | 0d | 2014-12-17 | 2014-12-17 | 141 |  |  |  |  |  | 0d |  |  |  |  |
| 143 | 2.2.4.5 | Parts assembly and coating |  | 20d | 2014-12-18 | 2015-01-16 | 142 |  |  | 2013-12-16 | 2014-01-14 | 20d | 0d |  | 128 | 92 | 137 |
| 144 | 2.2.4.6 | H/W delivery to CNES | milestone | 0d | 2015-01-16 | 2015-01-16 | 143 |  |  | 2014-01-14 | 2014-01-14 | 0d | 0d |  | 129 | 93 | 138 |
| 145 | 2.2.4.7 | TRR |  | 1d | 2015-01-19 | 2015-01-19 | 144 |  |  |  |  |  | 0d |  |  |  |  |
| 146 | 2.2.4.8 | Functional and performance tests (LF1 Stellar) including documentation |  | 2d | 2015-01-20 | 2015-01-21 | 145 |  |  | 2014-01-15 | 2014-02-04 | 15d | 0d |  | 130 | 94 | 139 |
| 147 | 2.2.4.9 | Functional and performance tests (LF2 3, 4) ncluding documentation |  | 4d | 2015-01-22 | 2015-01-27 | 146 |  |  | 2014-01-15 | 2014-02-04 | 15d | 0d |  | 130 | 94 | 139 |
| 148 | 2.2.4.10 | PA PCB QM LF ready for AIT (x4 for CNES) | milestone | 0d | 2015-01-27 | 2015-01-27 | 147 |  |  | 2014-02-04 | 2014-02-04 | 0d | 0d |  | 132 | 96 | 141 |

Notes:
- 120: FIN+NOM: 28/03/14 PA PCB EM for tests (x6)
- 121: ECHEANCE: NC PA PCB EM manufacturing and tests / FIN+NOM: 28/03/14 PA PCB EM manufacturing and tests
- 122: ECHEANCE: NC PA PCB EM ready for MEB and RPW tests (x4 for CNES) / FIN+NOM: 28/03/14 PA PCB EM ready for MEB and RPW tests (x4 for CNES)
- 123: Reboucler avec LESIA / FIN+NOM: 22/01/15 PA PCB EQM HF (x4)
- 124: ECHEANCE: NC Schematic updates / FIN+NOM: 16/06/14 Schematic updates
- 125: ECHEANCE: NC Design of the PCB layout / FIN+NOM: 30/06/14 Design of the PCB layout
- 126: ECHEANCE: NC PCB manufacturing / FIN+NOM: 01/09/14 PCB manufacturing
- 127: ECHEANCE: NC Parts assembly / FIN+NOM: 06/10/14 Parts assembly
- 128: ECHEANCE: NC H/W delivery to LESIA / FIN+NOM: 06/10/14 H/W delivery to LESIA
- 129: ECHEANCE: NC Design uddate / FIN+NOM: 21/11/14 Design uddate
- 130: ECHEANCE: NC MRR / FIN+NOM: 24/11/14 MRR
- 131: ECHEANCE: NC Modification implementation (RESA) / FIN+NOM: 03/12/14 Modification implementation (RESA)
- 132: ECHEANCE: NC Modification validation (Lésia) / FIN+NOM: 08/12/14 Modification validation (Lésia)
- 133: ECHEANCE: NC Coating (RESA) / FIN+NOM: 15/12/14 Coating (RESA)
- 134: ECHEANCE: NC TRR / FIN+NOM: 16/12/14 TRR
- 135: ECHEANCE: NC Functional and performance tests including documentation / FIN+NOM: 15/01/15 Functional and performance tests including documentation
- 136: ECHEANCE: NC TRB & DRB / FIN+NOM: 16/01/15 TRB & DRB
- 137: ECHEANCE: NC PA PCB QM HF ready for AIT (x4 for CNES) / FIN+NOM: 22/01/15 PA PCB QM HF ready for AIT (x4 for CNES)
- 138: Reboucler avec LESIA / FIN+NOM: 27/01/15 PA PCB EQM LF (x4)
- 139: ECHEANCE: NC Schematic updates / FIN+NOM: 16/06/14 Schematic updates
- 140: ECHEANCE: NC Final design of the PCB layout / FIN+NOM: 20/11/14 Final design of the PCB layout
- 141: ECHEANCE: NC PCB manufacturing (*7) / FIN+NOM: 17/12/14 PCB manufacturing (*7)
- 142: ECHEANCE: NC PCB * 3 delivery IRF / FIN+NOM: 17/12/14 PCB * 3 delivery IRF
- 143: ECHEANCE: NC Parts assembly and coating / FIN+NOM: 16/01/15 Parts assembly and coating
- 144: ECHEANCE: NC H/W delivery to CNES / FIN+NOM: 16/01/15 H/W delivery to CNES
- 145: ECHEANCE: NC TRR / FIN+NOM: 19/01/15 TRR
- 146: ECHEANCE: NC Functional and performance tests (LF1 Stellar) including documentation / FIN+NOM: 21/01/15 Functional and performance tests (LF1 Stellar) including documentation
- 147: ECHEANCE: NC Functional and performance tests (LF2 3, 4) ncluding documentation / FIN+NOM: 27/01/15 Functional and performance tests (LF2 3, 4) ncluding documentation
- 148: ECHEANCE: NC PA PCB QM LF ready for AIT (x4 for CNES) / FIN+NOM: 27/01/15 PA PCB QM LF ready for AIT (x4 for CNES)

| ID | WBS | Task | Type | Duration | Start | Finish | Predecessors | Baseline start | Baseline finish | Baseline duration | Total slack | OldLg | Texte17 | Ancien Num | FIN+NOM | ECHEANCE |
| --- | --- | --- | --- | --- | --- | --- | --- | --- | --- | --- | --- | --- | --- | --- | --- | --- |
| 149 | 2.2.5 | **PA PCB FM-EQM (x4) for Stellar** |  | 125.5d | 2015-06-08 | 2015-12-02 |  | 2014-02-03 | 2014-05-16 | 72d | 0d | 133 | 97 | 142 | 02/12/15 PA PCB FM-EQM (x4) for Stellar |  |
| 150 | 2.2.5.1 | MRR preparation |  | 2d | 2015-06-08 | 2015-06-10 | 202 |  |  |  | 0d |  |  |  | 10/06/15 MRR preparation | NC MRR preparation |
| 151 | 2.2.5.2 | MRR |  | 1d | 2015-06-10 | 2015-06-11 | 150 |  |  |  | 0d |  |  |  | 11/06/15 MRR | NC MRR |
| 152 | 2.2.5.3 | PCB manufacturing |  | 30d | 2015-06-11 | 2015-07-24 | 151 |  |  |  | 0d |  | 98 |  | 24/07/15 PCB manufacturing | NC PCB manufacturing |
| 153 | 2.2.5.4 | Parts assembly |  | 15d | 2015-07-24 | 2015-08-14 | 152 |  |  |  | 0d |  |  |  | 14/08/15 Parts assembly | NC Parts assembly |
| 154 | 2.2.5.5 | TRR preparation |  | 2d | 2015-07-24 | 2015-07-28 | 152 |  |  |  | 0d |  |  |  | 28/07/15 TRR preparation | NC TRR preparation |
| 155 | 2.2.5.6 | TRR |  | 1d | 2015-07-28 | 2015-07-29 | 154 |  |  |  | 0d |  |  |  | 29/07/15 TRR | NC TRR |
| 156 | 2.2.5.7 | Validation tests |  | 2d | 2015-08-14 | 2015-08-18 | 153 |  |  |  | 0d |  |  |  | 18/08/15 Validation tests | NC Validation tests |
| 157 | 2.2.5.8 | MIP before coating |  | 1d | 2015-08-18 | 2015-08-19 | 156 |  |  |  | 0d |  |  |  | 19/08/15 MIP before coating | NC MIP before coating |
| 158 | 2.2.5.9 | Coating |  | 8d | 2015-08-19 | 2015-08-31 | 157 |  |  |  | 0d |  |  |  | 31/08/15 Coating | NC Coating |
| 159 | 2.2.5.10 | Functional and performance tests |  | 5d | 2015-08-31 | 2015-09-07 | 158 |  |  |  | 0d |  | 100 |  | 07/09/15 Functional and performance tests | NC Functional and performance tests |
| 160 | 2.2.5.11 | Thermal tests (outgazing) |  | 5d | 2015-09-07 | 2015-09-14 | 159 |  |  |  | 0d |  | 101 |  | 14/09/15 Thermal tests (outgazing) | NC Thermal tests (outgazing) |
| 161 | 2.2.5.12 | PA PCB FM-EQM ready for AIT (x4 for CNES) | milestone | 0d | 2015-09-14 | 2015-09-14 | 160 |  |  |  | 0d |  | 102 |  | 14/09/15 PA PCB FM-EQM ready for AIT (x4 for CNES) | NC PA PCB FM-EQM ready for AIT (x4 for CNES) |
| 162 | 2.2.5.13 | **PA PCB FM HF (x4)** |  | 84d | 2015-08-06 | 2015-12-02 |  | 2014-02-03 | 2014-05-16 | 72d | 0d | 133 | 103 | 142 | 02/12/15 PA PCB FM HF (x4) |  |
| 163 | 2.2.5.13.1 | Design updates |  | 10d | 2015-08-06 | 2015-08-19 | 202, 56FS-5d |  |  |  | 0d |  |  |  | 19/08/15 Design updates | NC Design updates |
| 164 | 2.2.5.13.2 | MRR preparation |  | 1d | 2015-08-20 | 2015-08-20 | 163 |  |  |  | 0d |  |  |  | 20/08/15 MRR preparation | NC MRR preparation |
| 165 | 2.2.5.13.3 | MRR |  | 1d | 2015-08-21 | 2015-08-21 | 164 |  |  |  | 0d |  |  |  | 21/08/15 MRR | NC MRR |
| 166 | 2.2.5.13.4 | PCB manufacturing (TBC) |  | 30d | 2015-08-24 | 2015-10-02 | 165 | 2014-02-03 | 2014-03-14 | 30d | 0d | 134 | 104 | 143 | 02/10/15 PCB manufacturing (TBC) | NC PCB manufacturing (TBC) |
| 167 | 2.2.5.13.5 | Parts assembly |  | 15d | 2015-10-05 | 2015-10-23 | 166 |  |  |  | 0d |  |  |  | 23/10/15 Parts assembly | NC Parts assembly |
| 168 | 2.2.5.13.6 | TRR preparation |  | 2d | 2015-10-05 | 2015-10-06 | 166 |  |  |  | 0d |  |  |  | 06/10/15 TRR preparation | NC TRR preparation |
| 169 | 2.2.5.13.7 | TRR |  | 1d | 2015-10-07 | 2015-10-07 | 168 |  |  |  | 0d |  |  |  | 07/10/15 TRR | NC TRR |
| 170 | 2.2.5.13.8 | Validation tests |  | 3d | 2015-10-26 | 2015-10-28 | 167 |  |  |  | 0d |  |  |  | 28/10/15 Validation tests | NC Validation tests |
| 171 | 2.2.5.13.9 | MIP before coating |  | 1d | 2015-10-29 | 2015-10-29 | 170 |  |  |  | 0d |  |  |  | 29/10/15 MIP before coating | NC MIP before coating |
| 172 | 2.2.5.13.10 | Coating |  | 8d | 2015-10-30 | 2015-11-10 | 171 |  |  |  | 0d |  |  |  | 10/11/15 Coating | NC Coating |
| 173 | 2.2.5.13.11 | Functional and performance tests |  | 10d | 2015-11-12 | 2015-11-25 | 172, 161 | 2014-04-28 | 2014-05-16 | 13d | 0d | 136 | 106 | 145 | 25/11/15 Functional and performance tests | NC Functional and performance tests |
| 174 | 2.2.5.13.12 | Thermal tests (outgazing) |  | 5d | 2015-11-26 | 2015-12-02 | 173 |  |  |  | 0d | 137 | 107 | 146 | 02/12/15 Thermal tests (outgazing) | NC Thermal tests (outgazing) |
| 175 | 2.2.5.13.13 | PA PCB FM ready for AIT (x3 for CNES) | milestone | 0d | 2015-12-02 | 2015-12-02 | 174 |  |  |  | 0d | 138 | 108 | 147 | 02/12/15 PA PCB FM ready for AIT (x3 for CNES) | NC PA PCB FM ready for AIT (x3 for CNES) |

| ID | WBS | Task | Type | Duration | Start | Finish | Predecessors | Baseline start | Baseline finish | Baseline duration | Total slack | Free slack | OldLg | Texte17 | Ancien Num |
| --- | --- | --- | --- | --- | --- | --- | --- | --- | --- | --- | --- | --- | --- | --- | --- |
| 176 | 2.2.6 | **PA PCB FM LF(x4)** |  | 84d | 2015-08-06 | 2015-12-02 |  | 2014-02-03 | 2014-05-16 | 72d | 0d |  | 133 | 103 | 142 |
| 177 | 2.2.6.1 | Design updates |  | 10d | 2015-08-06 | 2015-08-19 | 202, 56FS-5d |  |  |  | 0d |  |  |  |  |
| 178 | 2.2.6.2 | MRR preparation |  | 1d | 2015-08-20 | 2015-08-20 | 177 |  |  |  | 0d |  |  |  |  |
| 179 | 2.2.6.3 | MRR |  | 1d | 2015-08-21 | 2015-08-21 | 178 |  |  |  | 0d |  |  |  |  |
| 180 | 2.2.6.4 | PCB manufacturing (TBC) |  | 30d | 2015-08-24 | 2015-10-02 | 179 | 2014-02-03 | 2014-03-14 | 30d | 0d |  | 134 | 104 | 143 |
| 181 | 2.2.6.5 | Parts assembly |  | 15d | 2015-10-05 | 2015-10-23 | 180 |  |  |  | 0d |  |  |  |  |
| 182 | 2.2.6.6 | TRR preparation |  | 2d | 2015-10-05 | 2015-10-06 | 180 |  |  |  | 0d |  |  |  |  |
| 183 | 2.2.6.7 | TRR |  | 1d | 2015-10-07 | 2015-10-07 | 182 |  |  |  | 0d |  |  |  |  |
| 184 | 2.2.6.8 | Validation tests |  | 3d | 2015-10-26 | 2015-10-28 | 181 |  |  |  | 0d |  |  |  |  |
| 185 | 2.2.6.9 | MIP before coating |  | 1d | 2015-10-29 | 2015-10-29 | 184 |  |  |  | 0d |  |  |  |  |
| 186 | 2.2.6.10 | Coating |  | 8d | 2015-10-30 | 2015-11-10 | 185 |  |  |  | 0d |  |  |  |  |
| 187 | 2.2.6.11 | Functional and performance tests |  | 10d | 2015-11-12 | 2015-11-25 | 161, 186 | 2014-04-28 | 2014-05-16 | 13d | 0d |  | 136 | 106 | 145 |
| 188 | 2.2.6.12 | Thermal tests (outgazing) |  | 5d | 2015-11-26 | 2015-12-02 | 187 |  |  |  | 0d |  | 137 | 107 | 146 |
| 189 | 2.2.6.13 | PA PCB FM ready for AIT (x3 for CNES) | milestone | 0d | 2015-12-02 | 2015-12-02 | 188 |  |  |  | 0d |  | 138 | 108 | 147 |
| 190 | 2.3 | **PA AIT (PCB+BOX)** |  | 239d | 2015-01-28 | 2016-01-08 |  |  |  |  | 0d |  |  | 109 |  |
| 191 | 2.3.1 | **PA AIT QM (x4)** |  | 88.5d | 2015-01-28 | 2015-06-08 |  |  |  |  | 0d |  |  | 110 |  |
| 192 | 2.3.1.1 | PA PCB LF & HF, box, harnesses acceptances (incl. Capacitance measurement) |  | 1d | 2015-01-28 | 2015-01-28 | 137, 148, 43 |  |  |  | 0d |  |  | 111 |  |
| 193 | 2.3.1.2 | Mechanical assembly PA1 |  | 3d | 2015-01-29 | 2015-02-02 | 192 |  |  |  | 24d | 0d |  | 112 |  |
| 194 | 2.3.1.3 | TRR PA1 BOX |  | 1d | 2015-02-03 | 2015-02-03 | 193 |  |  |  | 24d | 0d |  | 113 |  |
| 195 | 2.3.1.4 | Functional tests PA1 |  | 4d | 2015-02-04 | 2015-02-09 | 194 |  |  |  | 24d | 0d |  | 114 |  |
| 196 | 2.3.1.5 | TRB/DRB preparation |  | 2d | 2015-02-10 | 2015-02-11 | 195 |  |  |  | 24d | 0d |  |  |  |
| 197 | 2.3.1.6 | TRB/DRB PA1 |  | 1d | 2015-02-12 | 2015-02-12 | 196 |  |  |  | 24d | 0d |  | 115 |  |
| 198 | 2.3.1.7 | Transportation to Stellar PA1 |  | 5d | 2015-02-13 | 2015-02-19 | 197 |  |  |  | 24d |  |  | 117 |  |
| 199 | 2.3.1.8 | Mechanical assembly PA2-PA3-PA4 |  | 3d | 2015-01-29 | 2015-02-02 | 192 |  |  |  | 0d |  |  |  |  |
| 200 | 2.3.1.9 | TRR PA2-PA3-PA4 BOX |  | 1d | 2015-02-03 | 2015-02-03 | 199 |  |  |  | 0d |  |  |  |  |
| 201 | 2.3.1.10 | Functional tests + EMC + Docs PA2-PA3-PA4 |  | 10d | 2015-02-04 | 2015-02-17 | 200 |  |  |  | 0d |  |  |  |  |
| 202 | 2.3.1.11 | Complementary Performance and Thermal Tests on QM PA2-PA3-PA4 (including documentation) |  | 12d | 2015-05-20 | 2015-06-08 | 914 |  |  |  | 0d |  |  | 116 |  |
| 203 | 2.3.1.12 | TRB/DRB preparation |  | 2d | 2015-02-18 | 2015-02-19 | 201 |  |  |  | 0d |  |  |  |  |
| 204 | 2.3.1.13 | TRB/DRB PA2-PA3-PA4 |  | 1d | 2015-02-20 | 2015-02-20 | 203 |  |  |  | 0d |  |  |  |  |
| 205 | 2.3.1.14 | PA delevery to RPW / MEB EM2 AIT PA2 & PA3 & PA4 |  | 1d | 2015-02-23 | 2015-02-23 | 204 |  |  |  | 0d |  |  | 118 |  |

Notes:
- 176: FIN+NOM: 02/12/15 PA PCB FM LF(x4)
- 177: ECHEANCE: NC Design updates / FIN+NOM: 19/08/15 Design updates
- 178: ECHEANCE: NC MRR preparation / FIN+NOM: 20/08/15 MRR preparation
- 179: ECHEANCE: NC MRR / FIN+NOM: 21/08/15 MRR
- 180: ECHEANCE: NC PCB manufacturing (TBC) / FIN+NOM: 02/10/15 PCB manufacturing (TBC)
- 181: ECHEANCE: NC Parts assembly / FIN+NOM: 23/10/15 Parts assembly
- 182: ECHEANCE: NC TRR preparation / FIN+NOM: 06/10/15 TRR preparation
- 183: ECHEANCE: NC TRR / FIN+NOM: 07/10/15 TRR
- 184: ECHEANCE: NC Validation tests / FIN+NOM: 28/10/15 Validation tests
- 185: ECHEANCE: NC MIP before coating / FIN+NOM: 29/10/15 MIP before coating
- 186: ECHEANCE: NC Coating / FIN+NOM: 10/11/15 Coating
- 187: ECHEANCE: NC Functional and performance tests / FIN+NOM: 25/11/15 Functional and performance tests
- 188: ECHEANCE: NC Thermal tests (outgazing) / FIN+NOM: 02/12/15 Thermal tests (outgazing)
- 189: ECHEANCE: NC PA PCB FM ready for AIT (x3 for CNES) / FIN+NOM: 02/12/15 PA PCB FM ready for AIT (x3 for CNES)
- 190: FIN+NOM: 08/01/16 PA AIT (PCB+BOX)
- 191: FIN+NOM: 08/06/15 PA AIT QM (x4)
- 192: ECHEANCE: NC PA PCB LF & HF, box, harnesses acceptances (incl. Capacitance measurement) / FIN+NOM: 28/01/15 PA PCB LF & HF, box, harnesses acceptances (incl. Capacitance measurement)
- 193: ECHEANCE: NC Mechanical assembly PA1 / FIN+NOM: 02/02/15 Mechanical assembly PA1
- 194: ECHEANCE: NC TRR PA1 BOX / FIN+NOM: 03/02/15 TRR PA1 BOX
- 195: ECHEANCE: NC Functional tests PA1 / FIN+NOM: 09/02/15 Functional tests PA1
- 196: ECHEANCE: NC TRB/DRB preparation / FIN+NOM: 11/02/15 TRB/DRB preparation
- 197: ECHEANCE: NC TRB/DRB PA1 / FIN+NOM: 12/02/15 TRB/DRB PA1
- 198: ECHEANCE: NC Transportation to Stellar PA1 / FIN+NOM: 19/02/15 Transportation to Stellar PA1
- 199: ECHEANCE: NC Mechanical assembly PA2-PA3-PA4 / FIN+NOM: 02/02/15 Mechanical assembly PA2-PA3-PA4
- 200: ECHEANCE: NC TRR PA2-PA3-PA4 BOX / FIN+NOM: 03/02/15 TRR PA2-PA3-PA4 BOX
- 201: ECHEANCE: NC Functional tests + EMC + Docs PA2-PA3-PA4 / FIN+NOM: 17/02/15 Functional tests + EMC + Docs PA2-PA3-PA4
- 202: ECHEANCE: NC Complementary Performance and Thermal Tests on QM PA2-PA3-PA4 (including documentation) / FIN+NOM: 08/06/15 Complementary Performance and Thermal Tests on QM PA2-PA3-PA4 (including documentation)
- 203: ECHEANCE: NC TRB/DRB preparation / FIN+NOM: 19/02/15 TRB/DRB preparation
- 204: ECHEANCE: NC TRB/DRB PA2-PA3-PA4 / FIN+NOM: 20/02/15 TRB/DRB PA2-PA3-PA4
- 205: ECHEANCE: NC PA delevery to RPW / MEB EM2 AIT PA2 & PA3 & PA4 / FIN+NOM: 23/02/15 PA delevery to RPW / MEB EM2 AIT PA2 & PA3 & PA4

| ID | WBS | Task | Type | Duration | Start | Finish | Predecessors | Complete | Remaining | Baseline start | Baseline finish | Baseline duration | Total slack | Constraint | Texte17 | OldLg | Ancien Num |
| --- | --- | --- | --- | --- | --- | --- | --- | --- | --- | --- | --- | --- | --- | --- | --- | --- | --- |
| 206 | 2.3.2 | **PA AIT FM-EQM (x4)** |  | 15d | 2015-09-14 | 2015-10-05 |  |  |  |  |  |  | 0d |  | 119 |  |  |
| 207 | 2.3.2.1 | PA PCB, box, harnesses acceptances (incl. Capacitance measurement): |  | 4d | 2015-09-14 | 2015-09-18 | 161 |  |  |  |  |  | 0d |  | 120 |  |  |
| 208 | 2.3.2.2 | Mechanical assembly |  | 3d | 2015-09-18 | 2015-09-23 | 207 |  |  |  |  |  | 0d |  | 121 |  |  |
| 209 | 2.3.2.3 | TRR |  | 1d | 2015-09-23 | 2015-09-24 | 208 |  |  |  |  |  | 0d |  | 122 |  |  |
| 210 | 2.3.2.4 | Functional tests |  | 1d | 2015-09-24 | 2015-09-25 | 209 |  |  |  |  |  | 0d |  | 123 |  |  |
| 211 | 2.3.2.5 | TRB/DRB: |  | 1d | 2015-09-25 | 2015-09-28 | 210 |  |  |  |  |  | 0d |  | 124 |  |  |
| 212 | 2.3.2.6 | Transportation to Stellar |  | 5d | 2015-09-28 | 2015-10-05 | 211 |  |  |  |  |  | 0d |  | 125 |  |  |
| 213 | 2.3.3 | **PA AIT FM (x4)** |  | 25d | 2015-12-03 | 2016-01-08 |  |  |  |  |  |  | 0d |  | 126 |  |  |
| 214 | 2.3.3.1 | PA PCB, box, harnesses acceptances (incl. Capacitance measurement): |  | 4d | 2015-12-03 | 2015-12-08 | 189, 175 |  |  |  |  |  | 0d |  | 127 |  |  |
| 215 | 2.3.3.2 | Mechanical assembly |  | 5d | 2015-12-09 | 2015-12-15 | 214 |  |  |  |  |  | 0d |  | 128 |  |  |
| 216 | 2.3.3.3 | TRR |  | 1d | 2015-12-16 | 2015-12-16 | 215 |  |  |  |  |  | 0d |  | 129 |  |  |
| 217 | 2.3.3.4 | Functional tests |  | 4d | 2015-12-17 | 2015-12-22 | 216 |  |  |  |  |  | 0d |  | 130 |  |  |
| 218 | 2.3.3.5 | PA AIT FM environment acceptance tests (thermal, mécanichal) |  | 10d | 2015-12-23 | 2016-01-07 | 217 |  |  |  |  |  | 0d |  |  |  |  |
| 219 | 2.3.3.6 | TRB/DRB PA AIT FM (x4) | milestone | 1d | 2016-01-08 | 2016-01-08 | 218 |  |  |  |  |  | 0d |  | 131 |  |  |
| 220 | 2.3.3.7 | PAs FM | milestone | 1d | 2016-01-08 | 2016-01-08 | 218 |  |  |  |  |  | 0d |  | 131 |  |  |
| 221 | 3 | **MEB** |  | 1010.5d? | 2012-05-07 A | 2016-05-12 |  | 34% | 669.48d? | 2012-05-11 | 2014-07-29 | 556d | 0d |  | 230 | 211 | 226 |
| 222 | 3.1 | **Chassis** |  | 743d | 2012-05-07 A | 2015-04-20 |  | 87% | 95.02d |  |  |  | 0d |  | 233 | 212 | 227 |
| 223 | 3.1.1 | **EM Chassis** |  | 352d | 2012-05-07 A | 2013-09-27 A |  | 100% |  |  |  |  |  |  | 234 | 213 | 228 |
| 224 | 3.1.1.1 | Mechanical design |  | 111d | 2012-05-07 A | 2012-10-12 A |  | 100% |  |  |  |  |  | start no earlier than 2012-05-07 | 235 | 214 | 229 |
| 225 | 3.1.1.2 | EM manufacturing |  | 142d | 2013-01-03 A | 2013-07-26 A | 224 | 100% |  |  |  |  |  | start no earlier than 2013-01-03 | 236 | 215 | 230 |
| 226 | 3.1.1.3 | Structural analyses and FEM delivery |  | 160d | 2012-05-07 A | 2012-12-21 A |  | 100% |  |  |  |  |  | start no earlier than 2012-05-07 | 237 | 216 | 231 |
| 227 | 3.1.1.4 | Detailed structural model |  | 19d | 2013-07-22 A | 2013-08-16 A | 238 | 100% |  |  |  |  |  |  | 238 | 217 | 232 |
| 228 | 3.1.1.5 | Simulations and itéraions |  | 20d | 2013-08-19 A | 2013-09-13 A | 227 | 100% |  |  |  |  |  |  | 239 | 218 | 233 |
| 229 | 3.1.1.6 | Structural analyses report |  | 9d | 2013-09-16 A | 2013-09-26 A | 228 | 100% |  |  |  |  |  |  | 240 | 219 | 234 |
| 230 | 3.1.1.7 | Delivery of the final FEM | milestone | 1d | 2013-09-27 A | 2013-09-27 A | 229 | 100% |  |  |  |  |  |  | 241 | 220 | 235 |

Notes:
- 206: FIN+NOM: 05/10/15 PA AIT FM-EQM (x4)
- 207: ECHEANCE: NC PA PCB, box, harnesses acceptances (incl. Capacitance measurement): / FIN+NOM: 18/09/15 PA PCB, box, harnesses acceptances (incl. Capacitance measurement):
- 208: ECHEANCE: NC Mechanical assembly / FIN+NOM: 23/09/15 Mechanical assembly
- 209: ECHEANCE: NC TRR / FIN+NOM: 24/09/15 TRR
- 210: ECHEANCE: NC Functional tests / FIN+NOM: 25/09/15 Functional tests
- 211: ECHEANCE: NC TRB/DRB: / FIN+NOM: 28/09/15 TRB/DRB:
- 212: ECHEANCE: NC Transportation to Stellar / FIN+NOM: 05/10/15 Transportation to Stellar
- 213: FIN+NOM: 08/01/16 PA AIT FM (x4)
- 214: ECHEANCE: NC PA PCB, box, harnesses acceptances (incl. Capacitance measurement): / FIN+NOM: 08/12/15 PA PCB, box, harnesses acceptances (incl. Capacitance measurement):
- 215: ECHEANCE: NC Mechanical assembly / FIN+NOM: 15/12/15 Mechanical assembly
- 216: ECHEANCE: NC TRR / FIN+NOM: 16/12/15 TRR
- 217: ECHEANCE: NC Functional tests / FIN+NOM: 22/12/15 Functional tests
- 218: ECHEANCE: NC PA AIT FM environment acceptance tests (thermal, mécanichal) / FIN+NOM: 07/01/16 PA AIT FM environment acceptance tests (thermal, mécanichal)
- 219: ECHEANCE: NC TRB/DRB PA AIT FM (x4) / FIN+NOM: 08/01/16 TRB/DRB PA AIT FM (x4)
- 220: ECHEANCE: NC PAs FM / FIN+NOM: 08/01/16 PAs FM
- 221: FIN+NOM: 12/05/16 MEB
- 222: FIN+NOM: 20/04/15 Chassis
- 223: FIN+NOM: 27/09/13 EM Chassis
- 224: ECHEANCE: NC Mechanical design / FIN+NOM: 12/10/12 Mechanical design
- 225: ECHEANCE: NC EM manufacturing / FIN+NOM: 26/07/13 EM manufacturing
- 226: ECHEANCE: NC Structural analyses and FEM delivery / FIN+NOM: 21/12/12 Structural analyses and FEM delivery
- 227: ECHEANCE: NC Detailed structural model / FIN+NOM: 16/08/13 Detailed structural model
- 228: ECHEANCE: NC Simulations and itéraions / FIN+NOM: 13/09/13 Simulations and itéraions
- 229: ECHEANCE: NC Structural analyses report / FIN+NOM: 26/09/13 Structural analyses report
- 230: ECHEANCE: NC Delivery of the final FEM / FIN+NOM: 27/09/13 Delivery of the final FEM

| ID | WBS | Task | Duration | Start | Finish | Predecessors | Complete | Remaining | Total slack | Constraint | OldLg | Texte17 | Ancien Num | ECHEANCE |
| --- | --- | --- | --- | --- | --- | --- | --- | --- | --- | --- | --- | --- | --- | --- |
| 231 | 3.1.1.8 | **Chassis thermal analysis** | 135d | 2013-01-07 A | 2013-07-19 A |  | 100% |  |  |  | 221 | 242 | 236 |  |
| 232 | 3.1.1.8.1 | Design of the thermal model | 30d | 2013-01-07 A | 2013-02-15 A |  | 100% |  |  | start no earlier than 2013-01-07 | 222 | 243 | 237 | NC Design of the thermal model |
| 233 | 3.1.1.8.2 | Completion of the model with the power repartition | 30d | 2013-02-18 A | 2013-03-29 A | 232 | 100% |  |  |  | 223 | 244 | 238 | NC Completion of the model with the power repartition |
| 234 | 3.1.1.8.3 | Simulations and iterations | 26d | 2013-04-02 A | 2013-05-10 A | 233 | 100% |  |  |  | 224 | 245 | 239 | NC Simulations and iterations |
| 235 | 3.1.1.8.4 | Thermal analyses report | 18d | 2013-05-13 A | 2013-06-06 A | 234 | 100% |  |  |  | 225 | 246 | 240 | NC Thermal analyses report |
| 236 | 3.1.1.8.5 | Delivery of the TMM | 1d | 2013-06-07 A | 2013-06-07 A | 235 | 100% |  |  |  | 226 | 247 | 241 | NC Delivery of the TMM |
| 237 | 3.1.1.8.6 | Thermal analyses updates | 29d | 2013-06-10 A | 2013-07-18 A | 236 | 100% |  |  |  | 227 | 248 | 242 | NC Thermal analyses updates |
| 238 | 3.1.1.8.7 | Delivery of the final TMM | 1d | 2013-07-19 A | 2013-07-19 A | 237 | 100% |  |  |  | 228 | 249 | 243 | NC Delivery of the final TMM |
| 239 | 3.1.2 | **EQM Chassis** | 35d | 2014-05-30 A | 2014-07-21 A |  | 100% |  |  |  |  | 250 |  |  |
| 240 | 3.1.2.1 | Chassis and harnesses MRR | 1d | 2014-05-30 A | 2014-05-30 A |  | 100% |  |  | start no earlier than 2014-05-30 |  | 251 |  | NC Chassis and harnesses MRR |
| 241 | 3.1.2.2 | **EQM Chassis Fabrication** | 33d | 2014-06-02 A | 2014-07-18 A |  | 100% |  |  |  |  | 252 |  |  |
| 242 | 3.1.2.2.1 | Black anodization and marking | 33d | 2014-06-02 A | 2014-07-18 A | 240 | 100% |  |  |  |  | 253 |  | NC Black anodization and marking |
| 243 | 3.1.2.3 | EQM Chassis delivery | 1d | 2014-07-21 A | 2014-07-21 A | 242 | 100% |  |  |  |  | 254 |  | NC EQM Chassis delivery |
| 244 | 3.1.3 | **FM chassis** | 188d | 2014-07-24 A | 2015-04-20 |  | 44% | 104.44d | 0d |  | 233 | 260 | 248 |  |
| 245 | 3.1.3.1 | MRR | 1d | 2014-07-24 A | 2014-07-24 A |  | 100% |  |  | start no earlier than 2014-07-24 |  | 259 |  | NC MRR |
| 246 | 3.1.3.2 | **FM Chassis fabrication** | 188d | 2014-07-24 A | 2015-04-20 |  | 44% | 105d | 0d |  |  | 261 |  |  |
| 247 | 3.1.3.2.1 | Frame Nom. DPU belt | 14d | 2014-07-24 A | 2014-08-12 A | 245SS | 100% |  |  |  |  |  |  | NC Frame Nom. DPU belt |
| 248 | 3.1.3.2.2 | Stand-by | 22d | 2014-08-13 A | 2014-09-12 A | 247 | 100% |  |  |  |  |  |  | NC Stand-by |
| 249 | 3.1.3.2.3 | Frame TDS belt | 14d | 2014-09-15 A | 2014-10-02 A | 248 | 100% |  |  |  |  |  |  | NC Frame TDS belt |
| 250 | 3.1.3.2.4 | Frame TNR-HFR belt | 15d | 2014-10-03 A | 2014-10-23 A | 249 | 100% |  |  |  |  |  |  | NC Frame TNR-HFR belt |
| 251 | 3.1.3.2.5 | Frame BIAS belt Unit | 15d | 2014-10-24 A | 2014-11-14 A | 250 | 100% |  |  |  |  |  |  | NC Frame BIAS belt Unit |
| 252 | 3.1.3.2.6 | Frame LFR belt | 15d | 2014-11-17 A | 2014-12-05 | 251 | 20% | 12d | 0d |  |  |  |  | NC Frame LFR belt |
| 253 | 3.1.3.2.7 | Frame Red. DPU belt | 14d | 2014-12-08 | 2014-12-26 | 252 |  |  | 0d |  |  |  |  | NC Frame Red. DPU belt |
| 254 | 3.1.3.2.8 | Frame Nom. LVPS-PDU belt | 17d | 2014-12-29 | 2015-01-21 | 253 |  |  | 0d |  |  |  |  | NC Frame Nom. LVPS-PDU belt |
| 255 | 3.1.3.2.9 | Frame Red. LVPS-PDU belt | 17d | 2015-01-22 | 2015-02-13 | 254 |  |  | 0d |  |  |  |  | NC Frame Red. LVPS-PDU belt |
| 256 | 3.1.3.2.10 | Lateral covers | 15d | 2015-02-16 | 2015-03-06 | 255 |  |  | 0d |  |  |  |  | NC Lateral covers |
| 257 | 3.1.3.2.11 | Delivery of the raw chassis | 1d | 2015-03-09 | 2015-03-09 | 256 |  |  | 0d |  |  |  |  | NC Delivery of the raw chassis |
| 258 | 3.1.3.2.12 | Dimension controls and blank mounting | 4d | 2015-03-10 | 2015-03-13 | 257 |  |  | 0d |  |  |  |  | NC Dimension controls and blank mounting |
| 259 | 3.1.3.2.13 | Black anodization and marking | 24d | 2015-03-16 | 2015-04-17 | 258 |  |  | 0d |  |  |  |  | NC Black anodization and marking |
| 260 | 3.1.3.2.14 | FM chassis ready | 1d | 2015-04-20 | 2015-04-20 | 259 |  |  | 0d |  |  |  |  | NC FM chassis ready |

Notes:
- 231: FIN+NOM: 19/07/13 Chassis thermal analysis
- 232: FIN+NOM: 15/02/13 Design of the thermal model
- 233: FIN+NOM: 29/03/13 Completion of the model with the power repartition
- 234: FIN+NOM: 10/05/13 Simulations and iterations
- 235: FIN+NOM: 06/06/13 Thermal analyses report
- 236: FIN+NOM: 07/06/13 Delivery of the TMM
- 237: FIN+NOM: 18/07/13 Thermal analyses updates
- 238: FIN+NOM: 19/07/13 Delivery of the final TMM
- 239: FIN+NOM: 21/07/14 EQM Chassis
- 240: FIN+NOM: 30/05/14 Chassis and harnesses MRR
- 241: FIN+NOM: 18/07/14 EQM Chassis Fabrication
- 242: FIN+NOM: 18/07/14 Black anodization and marking
- 243: FIN+NOM: 21/07/14 EQM Chassis delivery
- 244: FIN+NOM: 20/04/15 FM chassis
- 245: FIN+NOM: 24/07/14 MRR
- 246: FIN+NOM: 20/04/15 FM Chassis fabrication
- 247: FIN+NOM: 12/08/14 Frame Nom. DPU belt
- 248: FIN+NOM: 12/09/14 Stand-by
- 249: FIN+NOM: 02/10/14 Frame TDS belt
- 250: FIN+NOM: 23/10/14 Frame TNR-HFR belt
- 251: FIN+NOM: 14/11/14 Frame BIAS belt Unit
- 252: FIN+NOM: 05/12/14 Frame LFR belt
- 253: FIN+NOM: 26/12/14 Frame Red. DPU belt
- 254: FIN+NOM: 21/01/15 Frame Nom. LVPS-PDU belt
- 255: FIN+NOM: 13/02/15 Frame Red. LVPS-PDU belt
- 256: FIN+NOM: 06/03/15 Lateral covers
- 257: FIN+NOM: 09/03/15 Delivery of the raw chassis
- 258: FIN+NOM: 13/03/15 Dimension controls and blank mounting
- 259: FIN+NOM: 17/04/15 Black anodization and marking
- 260: FIN+NOM: 20/04/15 FM chassis ready

| ID | WBS | Task | Duration | Start | Finish | Predecessors | Complete | Remaining | Total slack | Free slack | Constraint | Calendar |
| --- | --- | --- | --- | --- | --- | --- | --- | --- | --- | --- | --- | --- |
| 261 | 3.2 | **LVPS-PDU** | 471.5d | 2014-07-01 A | 2016-05-12 |  | 38% | 292.31d | 0d |  |  |  |
| 262 | 3.2.1 | **Parts procurement** | 221d | 2014-07-01 A | 2015-05-06 |  | 56% | 96.76d | 8.5d |  |  | Cnes_LVPS_PDU |
| 263 | 3.2.1.1 | EQM/EM4 Parts | 239ed | 2014-07-01 A | 2015-02-25 |  | 59% | 97ed | 37.4d |  | start no earlier than 2014-07-01 |  |
| 264 | 3.2.1.2 | **FM parts** | 221d | 2014-07-01 A | 2015-05-06 |  | 45% | 120.45d | 8.5d |  |  | Cnes_LVPS_PDU |
| 265 | 3.2.1.2.1 | FPGA part delivery | 1d | 2015-01-08 | 2015-01-08 |  |  |  | 0d |  | start no earlier than 2015-01-08 | Cnes_LVPS_PDU |
| 266 | 3.2.1.2.2 | LLI parts | 221d | 2014-07-01 A | 2015-05-06 |  | 46% | 120d | 8.5d | 0d | start no earlier than 2014-07-01 | Cnes_LVPS_PDU |
| 267 | 3.2.2 | **Hardware developments** | 463.5d | 2014-08-04 | 2016-05-12 |  |  |  | 0d |  |  | Cnes_LVPS_PDU |
| 268 | 3.2.2.1 | **LVPS-PDU EM3 HW design,dev & tests** | 97d | 2014-08-04 | 2014-12-18 |  |  |  | 0d |  |  |  |
| 269 | 3.2.2.1.1 | **Em3 Design&Development** | 23d | 2014-08-04 | 2014-09-03 |  |  |  | 0d |  |  | Cnes_LVPS_PDU |
| 270 | 3.2.2.1.1.1 | Complementary NCR investigation | 10d | 2014-08-04 | 2014-08-15 |  |  |  | 0d |  | start no earlier than 2014-08-04 | Cnes_LVPS_PDU |
| 271 | 3.2.2.1.1.2 | H/W definition and schematics (update) | 10d | 2014-08-04 | 2014-08-15 |  |  |  | 0d |  | start no earlier than 2014-08-04 | Cnes_LVPS_PDU |
| 272 | 3.2.2.1.1.3 | PCB layout | 11d | 2014-08-04 | 2014-08-18 |  |  |  | 0d |  | start no earlier than 2014-08-04 | Cnes_LVPS_PDU |
| 273 | 3.2.2.1.1.4 | MRR (light) | 0.5d | 2014-08-19 | 2014-08-19 | 272 |  |  | 0d |  | start no earlier than 2014-08-18 | Cnes_LVPS_PDU |
| 274 | 3.2.2.1.1.5 | PCB Manufacturing | 10d | 2014-08-19 | 2014-09-02 | 273 |  |  | 0d |  |  | Cnes_LVPS_PDU |
| 275 | 3.2.2.1.1.6 | FPGA ready for assembly (link with FPGA developpement) | 1d | 2014-09-03 | 2014-09-03 | 364 |  |  | 0d |  |  | Cnes_LVPS_PDU |
| 276 | 3.2.2.1.1.7 | EM3 EEE Procurement | 20d | 2014-08-04 | 2014-08-29 |  |  |  | 1.5d |  | start no earlier than 2014-08-04 | Cnes_LVPS_PDU |
| 277 | 3.2.2.1.2 | **Em3 Parts assembly** | 77.5d | 2014-09-02 | 2014-12-18 | 274, 276 |  |  | 0d |  |  | Cnes_LVPS_PDU |
| 278 | 3.2.2.1.2.1 | PSU Assembly - part 1 (CSRC) | 5d | 2014-09-03 | 2014-09-09 |  |  |  | 0d |  | start no earlier than 2014-09-03 | Cnes_LVPS_PDU |
| 279 | 3.2.2.1.2.2 | PSU Board delivery (CSRC to ASI) | 1d | 2014-09-10 | 2014-09-10 | 278 |  |  | 0d |  |  | Cnes_LVPS_PDU |
| 280 | 3.2.2.1.2.3 | PSU Reduced Electrical Test (Efficency and etc.) ASI | 5d | 2014-09-11 | 2014-09-17 | 279 |  |  | 0d |  |  | Cnes_LVPS_PDU |
| 281 | 3.2.2.1.2.4 | PSU Board delivery (to CSRC) | 1d | 2014-09-18 | 2014-09-18 | 280 |  |  | 0d |  |  | Cnes_LVPS_PDU |
| 282 | 3.2.2.1.2.5 | PSU Assembly - part 2 (CSRC) | 11d | 2014-09-19 | 2014-10-03 | 281, 380 |  |  | 0d |  |  | Cnes_LVPS_PDU |
| 283 | 3.2.2.1.2.6 | PDU Asembly - reprogamable FPGA ( CSRC) | 24d | 2014-09-02 | 2014-10-06 |  |  |  | 0d |  |  | Cnes_LVPS_PDU |
| 284 | 3.2.2.1.2.7 | Assembled boards delivery from CSRC to ASI (PDU+PSU) | 1d | 2014-10-06 | 2014-10-06 | 282 |  |  | 0d |  |  | Cnes_LVPS_PDU |
| 285 | 3.2.2.1.2.8 | TRR (light) | 1d | 2014-10-07 | 2014-10-07 | 284 |  |  | 0d |  |  | Cnes_LVPS_PDU |
| 286 | 3.2.2.1.2.9 | Board testing full functional and performance - reprogamable FPGA | 5d | 2014-10-07 | 2014-10-13 | 284 |  |  | 0d |  |  | Cnes_LVPS_PDU |
| 287 | 3.2.2.1.2.10 | PDU assembly of OTP FPGA (CSRC) | 2d | 2014-10-14 | 2014-10-15 | 286 |  |  | 0d |  |  | Cnes_LVPS_PDU |
| 288 | 3.2.2.1.2.11 | Board testing full functional and performance | 15d | 2014-10-16 | 2014-11-05 | 287 |  |  | 0d |  |  | Cnes_LVPS_PDU |
| 289 | 3.2.2.1.2.12 | Board EMC Tests + Test report | 10d | 2014-11-06 | 2014-11-19 | 288 |  |  | 0d |  |  | Cnes_LVPS_PDU |
| 290 | 3.2.2.1.2.13 | Board thermal tests + Test Report | 13d | 2014-11-20 | 2014-12-08 | 289 |  |  | 0d |  |  | Cnes_LVPS_PDU |
| 291 | 3.2.2.1.2.14 | Test Results Review | 5d | 2014-12-09 | 2014-12-15 | 290 |  |  | 0d |  |  | Cnes_LVPS_PDU |
| 292 | 3.2.2.1.2.15 | Test Reports Finalization | 5d | 2014-12-09 | 2014-12-15 | 290 |  |  | 0d |  |  | Cnes_LVPS_PDU |
| 293 | 3.2.2.1.2.16 | LVPS-PDU EM3 TRB and DRB (for acceptance) | 3d | 2014-12-16 | 2014-12-18 | 292 |  |  | 0d |  |  | Cnes_LVPS_PDU |

Notes:
- 261: ECHEANCE: NC LVPS-PDU / FIN+NOM: 12/05/16 LVPS-PDU
- 262: FIN+NOM: 06/05/15 Parts procurement
- 263: ECHEANCE: NC EQM/EM4 Parts / FIN+NOM: 25/02/15 EQM/EM4 Parts
- 264: FIN+NOM: 06/05/15 FM parts
- 265: ECHEANCE: NC FPGA part delivery / FIN+NOM: 08/01/15 FPGA part delivery
- 266: ECHEANCE: NC LLI parts / FIN+NOM: 06/05/15 LLI parts
- 267: ECHEANCE: NC Hardware developments / FIN+NOM: 12/05/16 Hardware developments
- 268: ECHEANCE: NC LVPS-PDU EM3 HW design and development / FIN+NOM: 18/12/14 LVPS-PDU EM3 HW design,dev & tests
- 269: ECHEANCE: NC Em3 Design&Development / FIN+NOM: 03/09/14 Em3 Design&Development
- 270: ECHEANCE: NC Complementary NCR investigation / FIN+NOM: 15/08/14 Complementary NCR investigation
- 271: ECHEANCE: NC H/W definition and schematics (update) / FIN+NOM: 15/08/14 H/W definition and schematics (update)
- 272: ECHEANCE: NC PCB layout / FIN+NOM: 18/08/14 PCB layout
- 273: ECHEANCE: NC MRR (light) / FIN+NOM: 19/08/14 MRR (light)
- 274: ECHEANCE: NC PCB Manufacturing / FIN+NOM: 02/09/14 PCB Manufacturing
- 275: ECHEANCE: NC FPGA ready for assembly (link with FPGA developpement) / FIN+NOM: 03/09/14 FPGA ready for assembly (link with FPGA developpement)
- 276: ECHEANCE: NC EM3 EEE Procurement / FIN+NOM: 29/08/14 EM3 EEE Procurement
- 277: FIN+NOM: 18/12/14 Em3 Parts assembly
- 278: ECHEANCE: NC PSU Assembly - part 1 (CSRC) / FIN+NOM: 09/09/14 PSU Assembly - part 1 (CSRC)
- 279: ECHEANCE: NC PSU Board delivery (CSRC to ASI) / FIN+NOM: 10/09/14 PSU Board delivery (CSRC to ASI)
- 280: ECHEANCE: NC PSU Reduced Electrical Test (Efficency and etc.) ASI / FIN+NOM: 17/09/14 PSU Reduced Electrical Test (Efficency and etc.) ASI
- 281: ECHEANCE: NC PSU Board delivery (to CSRC) / FIN+NOM: 18/09/14 PSU Board delivery (to CSRC)
- 282: ECHEANCE: NC PSU Assembly - part 2 (CSRC) / FIN+NOM: 03/10/14 PSU Assembly - part 2 (CSRC)
- 283: ECHEANCE: NC PDU Asembly - reprogamable FPGA ( CSRC) / FIN+NOM: 06/10/14 PDU Asembly - reprogamable FPGA ( CSRC)
- 284: ECHEANCE: NC Assembled boards delivery from CSRC to ASI (PDU+PSU) / FIN+NOM: 06/10/14 Assembled boards delivery from CSRC to ASI (PDU+PSU)
- 285: ECHEANCE: NC TRR (light) / FIN+NOM: 07/10/14 TRR (light)
- 286: ECHEANCE: NC Board testing full functional and performance - reprogamable FPGA / FIN+NOM: 13/10/14 Board testing full functional and performance - reprogamable FPGA
- 287: ECHEANCE: NC PDU assembly of OTP FPGA (CSRC) / FIN+NOM: 15/10/14 PDU assembly of OTP FPGA (CSRC)
- 288: ECHEANCE: NC Board testing full functional and performance / FIN+NOM: 05/11/14 Board testing full functional and performance
- 289: ECHEANCE: NC Board EMC Tests + Test report / FIN+NOM: 19/11/14 Board EMC Tests + Test report
- 290: ECHEANCE: NC Board thermal tests + Test Report / FIN+NOM: 08/12/14 Board thermal tests + Test Report
- 291: ECHEANCE: NC Test Results Review / FIN+NOM: 15/12/14 Test Results Review
- 292: ECHEANCE: NC Test Reports Finalization / FIN+NOM: 15/12/14 Test Reports Finalization
- 293: ECHEANCE: NC LVPS-PDU EM3 TRB and DRB (for acceptance) / FIN+NOM: 18/12/14 LVPS-PDU EM3 TRB and DRB (for acceptance)

| ID | WBS | Task | Duration | Start | Finish | Predecessors | Total slack | Constraint | Calendar | Text20 |
| --- | --- | --- | --- | --- | --- | --- | --- | --- | --- | --- |
| 294 | 3.2.2.2 | **LVPS-PDU Dummy HW design,dev & tests** | 33d | 2014-12-19 | 2015-02-03 | 293 | 0d |  | Cnes_LVPS_PDU | Yes |
| 295 | 3.2.2.2.1 | Design update | 8d | 2014-12-19 | 2014-12-30 |  | 0d | start no earlier than 2014-12-19 | Cnes_LVPS_PDU |  |
| 296 | 3.2.2.2.2 | Components procurement | 5d | 2014-12-31 | 2015-01-06 | 295 | 0d |  | Cnes_LVPS_PDU |  |
| 297 | 3.2.2.2.3 | MRR | 1d | 2015-01-07 | 2015-01-07 | 296 | 0d |  | Cnes_LVPS_PDU |  |
| 298 | 3.2.2.2.4 | Patrs assembly | 10d | 2015-01-08 | 2015-01-21 | 297 | 0d |  | Cnes_LVPS_PDU |  |
| 299 | 3.2.2.2.5 | Board testing | 7d | 2015-01-22 | 2015-01-30 | 298 | 0d |  | Cnes_LVPS_PDU |  |
| 300 | 3.2.2.2.6 | LVPS-PDU Dummy delivery | 2d | 2015-02-02 | 2015-02-03 | 299 | 0d |  | Cnes_LVPS_PDU |  |
| 301 | 3.2.2.3 | **LVPS-PDU EM4 HW design,dev & tests** | 117d | 2014-12-19 | 2015-06-02 |  | 0d |  | Cnes_LVPS_PDU | Yes |
| 302 | 3.2.2.3.1 | EM3 Acceptance Review (MEB EM2 coupling) + Redundancy testing (MEB EM) | 26d | 2014-12-19 | 2015-01-23 | 293 | 0d |  | Cnes_LVPS_PDU |  |
| 303 | 3.2.2.3.2 | NCR Investigations (if any) | 6d | 2015-01-26 | 2015-02-02 |  | 0d | start no earlier than 2015-01-26 | Cnes_LVPS_PDU |  |
| 304 | 3.2.2.3.3 | Schematics and PCB layout update (if any) | 6d | 2015-02-03 | 2015-02-10 | 303 | 0d |  | Cnes_LVPS_PDU |  |
| 305 | 3.2.2.3.4 | MRR | 1d | 2015-02-11 | 2015-02-11 | 304 | 0d |  | Cnes_LVPS_PDU |  |
| 306 | 3.2.2.3.5 | PCB Manufacturing | 16d | 2015-02-12 | 2015-03-05 | 305 | 0d |  | Cnes_LVPS_PDU |  |
| 307 | 3.2.2.3.6 | FPGA assembly | 1d | 2015-03-06 | 2015-03-06 | 374, 306 | 0d |  | Cnes_LVPS_PDU |  |
| 308 | 3.2.2.3.7 | **Parts Assembly** | 26d | 2015-03-09 | 2015-04-13 | 263, 306, 307 | 0d |  | Cnes_LVPS_PDU |  |
| 309 | 3.2.2.3.7.1 | PSU Assembly - part 1 (CSRC) | 5d | 2015-03-09 | 2015-03-13 |  | 0d |  | Cnes_LVPS_PDU |  |
| 310 | 3.2.2.3.7.2 | PSU Board delivery (CSRC to ASI) | 1d | 2015-03-16 | 2015-03-16 | 309 | 0d |  | Cnes_LVPS_PDU |  |
| 311 | 3.2.2.3.7.3 | PSU Reduced Electrical Test (Efficency and etc.) ASI | 7d | 2015-03-17 | 2015-03-25 | 310 | 0d |  | Cnes_LVPS_PDU |  |
| 312 | 3.2.2.3.7.4 | PSU Board delivery (to CSRC) | 1d | 2015-03-26 | 2015-03-26 | 311 | 0d |  | Cnes_LVPS_PDU |  |
| 313 | 3.2.2.3.7.5 | PSU Assembly - part 2 (CSRC) | 11d | 2015-03-27 | 2015-04-10 | 312 | 0d |  | Cnes_LVPS_PDU |  |
| 314 | 3.2.2.3.7.6 | PDU Asembly - reprogamable FPGA ( CSRC) | 24d | 2015-03-09 | 2015-04-09 |  | 1d | start no earlier than 2015-03-09 | Cnes_LVPS_PDU |  |
| 315 | 3.2.2.3.7.7 | Assembled boards delivery from CSRC to ASI (PDU+PSU) | 1d | 2015-04-13 | 2015-04-13 | 313, 314 | 0d |  | Cnes_LVPS_PDU |  |
| 316 | 3.2.2.3.8 | TRR | 1d | 2015-04-07 | 2015-04-07 | 308SS+13d | 0d | start no earlier than 2015-04-07 | Cnes_LVPS_PDU |  |
| 317 | 3.2.2.3.9 | Board Testing - functionality and performance | 15d | 2015-04-09 | 2015-04-29 | 316FS+1d | 0d |  | Cnes_LVPS_PDU |  |
| 318 | 3.2.2.3.10 | Board EMC Testing and thermal testing | 11d | 2015-04-30 | 2015-05-14 | 317 | 0d |  | Cnes_LVPS_PDU |  |
| 319 | 3.2.2.3.11 | TRR Documentation | 10d | 2015-05-15 | 2015-05-28 | 318 | 0d |  | Cnes_LVPS_PDU |  |
| 320 | 3.2.2.3.12 | TRB | 1d | 2015-05-29 | 2015-05-29 | 319 | 0d |  | Cnes_LVPS_PDU |  |
| 321 | 3.2.2.3.13 | EM4 ready for delivery | 1d | 2015-06-01 | 2015-06-01 | 320 | 0d |  | Cnes_LVPS_PDU |  |
| 322 | 3.2.2.3.14 | LVPS-PDU Em4 ready for delivery to LESIA / CNES for complementary tests | 1ed | 2015-06-01 | 2015-06-02 | 321SS | 0d | start no earlier than 2015-06-01 | Cnes_LVPS_PDU |  |

Notes:
- 294: ECHEANCE: NC LVPS-PDU Dummy HW design,dev & tests / FIN+NOM: 03/02/15 LVPS-PDU Dummy HW design,dev & tests
- 295: ECHEANCE: NC Design update / FIN+NOM: 30/12/14 Design update
- 296: ECHEANCE: NC Components procurement / FIN+NOM: 06/01/15 Components procurement
- 297: ECHEANCE: NC MRR / FIN+NOM: 07/01/15 MRR
- 298: ECHEANCE: NC Patrs assembly / FIN+NOM: 21/01/15 Patrs assembly
- 299: ECHEANCE: NC Board testing / FIN+NOM: 30/01/15 Board testing
- 300: ECHEANCE: NC LVPS-PDU Dummy delivery / FIN+NOM: 03/02/15 LVPS-PDU Dummy delivery
- 301: ECHEANCE: NC EM4 Development / FIN+NOM: 02/06/15 LVPS-PDU EM4 HW design,dev & tests
- 302: ECHEANCE: NC EM3 Acceptance Review (MEB EM2 coupling) + Redundancy testing (MEB EM) / FIN+NOM: 23/01/15 EM3 Acceptance Review (MEB EM2 coupling) + Redundancy testing (MEB EM)
- 303: ECHEANCE: NC NCR Investigations (if any) / FIN+NOM: 02/02/15 NCR Investigations (if any)
- 304: ECHEANCE: NC Schematics and PCB layout update (if any) / FIN+NOM: 10/02/15 Schematics and PCB layout update (if any)
- 305: ECHEANCE: NC MRR / FIN+NOM: 11/02/15 MRR
- 306: ECHEANCE: NC PCB Manufacturing / FIN+NOM: 05/03/15 PCB Manufacturing
- 307: ECHEANCE: NC FPGA assembly / FIN+NOM: 06/03/15 FPGA assembly
- 308: ECHEANCE: NC Parts Assembly / FIN+NOM: 13/04/15 Parts Assembly
- 309: ECHEANCE: NC PSU Assembly - part 1 (CSRC) / FIN+NOM: 13/03/15 PSU Assembly - part 1 (CSRC)
- 310: ECHEANCE: NC PSU Board delivery (CSRC to ASI) / FIN+NOM: 16/03/15 PSU Board delivery (CSRC to ASI)
- 311: ECHEANCE: NC PSU Reduced Electrical Test (Efficency and etc.) ASI / FIN+NOM: 25/03/15 PSU Reduced Electrical Test (Efficency and etc.) ASI
- 312: ECHEANCE: NC PSU Board delivery (to CSRC) / FIN+NOM: 26/03/15 PSU Board delivery (to CSRC)
- 313: ECHEANCE: NC PSU Assembly - part 2 (CSRC) / FIN+NOM: 10/04/15 PSU Assembly - part 2 (CSRC)
- 314: ECHEANCE: NC PDU Asembly - reprogamable FPGA ( CSRC) / FIN+NOM: 09/04/15 PDU Asembly - reprogamable FPGA ( CSRC)
- 315: ECHEANCE: NC Assembled boards delivery from CSRC to ASI (PDU+PSU) / FIN+NOM: 13/04/15 Assembled boards delivery from CSRC to ASI (PDU+PSU)
- 316: ECHEANCE: NC TRR / FIN+NOM: 07/04/15 TRR
- 317: ECHEANCE: NC Board Testing - functionality and performance / FIN+NOM: 29/04/15 Board Testing - functionality and performance
- 318: ECHEANCE: NC Board EMC Testing and thermal testing / FIN+NOM: 14/05/15 Board EMC Testing and thermal testing
- 319: ECHEANCE: NC TRR Documentation / FIN+NOM: 28/05/15 TRR Documentation
- 320: ECHEANCE: NC TRB / FIN+NOM: 29/05/15 TRB
- 321: ECHEANCE: NC EM4 ready for delivery / FIN+NOM: 01/06/15 EM4 ready for delivery
- 322: ECHEANCE: NC LVPS-PDU Em4 ready for delivery to LESIA / CNES for complementary tests / FIN+NOM: 02/06/15 LVPS-PDU Em4 ready for delivery to LESIA / CNES for complementary tests

| ID | WBS | Task | Type | Duration | Start | Finish | Predecessors | Total slack | Free slack | Calendar | Text20 |
| --- | --- | --- | --- | --- | --- | --- | --- | --- | --- | --- | --- |
| 323 | 3.2.2.4 | **LVPS-PDU PFM1 & PFM2 HW design and development** |  | 209.5d | 2015-02-03 | 2015-11-23 |  | 0d |  | Cnes_LVPS_PDU |  |
| 324 | 3.2.2.4.1 | Schematics and PCB layout update (if any) |  | 5d | 2015-02-03 | 2015-02-09 | 303 | 69.5d | 0d | Cnes_LVPS_PDU |  |
| 325 | 3.2.2.4.2 | MRR |  | 1d | 2015-02-11 | 2015-02-11 | 324FS+1d | 69.5d | 65.5d | Cnes_LVPS_PDU |  |
| 326 | 3.2.2.4.3 | PCB layout |  | 10d | 2015-02-12 | 2015-02-25 | 305 | 24.5d | 0d | Cnes_LVPS_PDU |  |
| 327 | 3.2.2.4.4 | PCB manufacturing |  | 35d | 2015-02-26 | 2015-04-15 | 326 | 24.5d | 21.5d | Cnes_LVPS_PDU |  |
| 328 | 3.2.2.4.5 | LVPS-PDU FPGA ready for assembly | milestone | 1d | 2015-03-17 | 2015-03-17 | 376 | 45.5d | 41.5d | Cnes_LVPS_PDU |  |
| 329 | 3.2.2.4.6 | LVPS-PDU Parts available for assembly | milestone | 1d | 2015-05-07 | 2015-05-07 | 266 | 8.5d | 6.5d | Cnes_LVPS_PDU |  |
| 330 | 3.2.2.4.7 | **LVPS-PDU PFM1 & PFM2 HW design,dev & tests** |  | 130d | 2015-05-20 | 2015-11-23 |  | 0d |  |  |  |
| 331 | 3.2.2.4.7.1 | Parts assembly |  | 25d | 2015-05-20 | 2015-06-24 | 325, 328, 329, 327, 318, 1065 | 0d |  | Cnes_LVPS_PDU |  |
| 332 | 3.2.2.4.7.2 | Board delivery |  | 2d | 2015-06-24 | 2015-06-26 | 331 | 0d |  | Cnes_LVPS_PDU |  |
| 333 | 3.2.2.4.7.3 | Board testing |  | 25d | 2015-06-26 | 2015-07-31 | 332 | 0d |  | Cnes_LVPS_PDU |  |
| 334 | 3.2.2.4.7.4 | Need date for mechanical frame |  | 1d | 2015-07-31 | 2015-08-03 | 333 | 0d |  | Cnes_LVPS_PDU |  |
| 335 | 3.2.2.4.7.5 | TRR preparation (documentation) |  | 5d | 2015-08-03 | 2015-08-10 | 334 | 0d |  | Cnes_LVPS_PDU |  |
| 336 | 3.2.2.4.7.6 | Boards ready for MIP and TRR |  | 1d | 2015-08-10 | 2015-08-11 | 335 | 0d |  | Cnes_LVPS_PDU |  |
| 337 | 3.2.2.4.7.7 | Integration of PCB and mechanical frame |  | 6d | 2015-08-11 | 2015-08-19 | 336 | 0d |  | Cnes_LVPS_PDU |  |
| 338 | 3.2.2.4.7.8 | TRR |  | 1d | 2015-08-19 | 2015-08-20 | 337 | 0d |  | Cnes_LVPS_PDU |  |
| 339 | 3.2.2.4.7.9 | Board full functional and performance tests |  | 25d | 2015-08-19 | 2015-09-23 | 337 | 0d |  | Cnes_LVPS_PDU |  |
| 340 | 3.2.2.4.7.10 | Board EMC & ReviewTests (EMC chamber) |  | 20d | 2015-09-23 | 2015-10-21 | 339 | 0d |  | Cnes_LVPS_PDU |  |
| 341 | 3.2.2.4.7.11 | Coating of PCB and integration into mechanical frame |  | 5d | 2015-10-21 | 2015-10-28 | 340 | 0d |  | Cnes_LVPS_PDU |  |
| 342 | 3.2.2.4.7.12 | Post-coating tests and characterization |  | 5d | 2015-10-28 | 2015-11-04 | 341 | 0d |  | Cnes_LVPS_PDU |  |
| 343 | 3.2.2.4.7.13 | Board thermal tests (if any) |  | 10d | 2015-11-04 | 2015-11-18 | 342 | 0d |  | Cnes_LVPS_PDU |  |
| 344 | 3.2.2.4.7.14 | TRB and DRB |  | 2d | 2015-11-18 | 2015-11-20 | 343 | 0d |  | Cnes_LVPS_PDU |  |
| 345 | 3.2.2.4.7.15 | LVPS-PDU PFM1 & PFM2 ready for delivery to lesia for AIT MEB |  | 1d | 2015-11-20 | 2015-11-23 | 344 | 0d |  | Cnes_LVPS_PDU |  |
| 346 | 3.2.2.5 | **FM Spare (consolidate logic starting the spare)** |  | 123d | 2015-11-23 | 2016-05-12 |  | 0d |  | Cnes_LVPS_PDU | Yes |
| 347 | 3.2.2.5.1 | MRR preparation (documentation) |  | 5d | 2015-11-23 | 2015-11-30 | 345 | 0d |  | Cnes_LVPS_PDU |  |
| 348 | 3.2.2.5.2 | MRR |  | 1d | 2015-11-30 | 2015-12-01 | 347 | 0d |  | Cnes_LVPS_PDU |  |
| 349 | 3.2.2.5.3 | PCB manufacturing |  | 20d | 2015-12-01 | 2015-12-29 | 348 | 0d |  | Cnes_LVPS_PDU |  |
| 350 | 3.2.2.5.4 | Parts assembly |  | 25d | 2015-12-29 | 2016-02-02 | 349 | 0d |  | Cnes_LVPS_PDU |  |
| 351 | 3.2.2.5.5 | Board delivery |  | 1d | 2016-02-02 | 2016-02-03 | 350 | 0d |  | Cnes_LVPS_PDU |  |
| 352 | 3.2.2.5.6 | Board testing |  | 25d | 2016-02-03 | 2016-03-09 | 351 | 0d |  | Cnes_LVPS_PDU |  |
| 353 | 3.2.2.5.7 | Need date for mechanical frame |  | 1d | 2016-03-09 | 2016-03-10 | 352 | 0d |  | Cnes_LVPS_PDU |  |
| 354 | 3.2.2.5.8 | Integration of PCB and mechanical frame |  | 5d | 2016-03-10 | 2016-03-17 | 353 | 0d |  | Cnes_LVPS_PDU |  |
| 355 | 3.2.2.5.9 | TRR |  | 2d | 2016-03-17 | 2016-03-21 | 354 | 0d |  | Cnes_LVPS_PDU |  |
| 356 | 3.2.2.5.10 | Board full functional and performance tests |  | 25d | 2016-03-21 | 2016-04-25 | 355 | 0d |  | Cnes_LVPS_PDU |  |
| 357 | 3.2.2.5.11 | Coating of PCB and integration into mechanical frame |  | 5d | 2016-04-25 | 2016-05-02 | 356 | 0d |  | Cnes_LVPS_PDU |  |
| 358 | 3.2.2.5.12 | Post-coating tests and characterization |  | 5d | 2016-05-02 | 2016-05-09 | 357 | 0d |  | Cnes_LVPS_PDU |  |
| 359 | 3.2.2.5.13 | TRB and DRB |  | 2d | 2016-05-09 | 2016-05-11 | 358 | 0d |  | Cnes_LVPS_PDU |  |
| 360 | 3.2.2.5.14 | LVPS-PDU FM Spare for delivery to lesia for AIT MEB |  | 1d | 2016-05-11 | 2016-05-12 | 359 | 0d |  | Cnes_LVPS_PDU |  |

Notes:
- 323: FIN+NOM: 23/11/15 LVPS-PDU PFM1 & PFM2 HW design and development
- 324: ECHEANCE: NC Schematics and PCB layout update (if any) / FIN+NOM: 09/02/15 Schematics and PCB layout update (if any)
- 325: ECHEANCE: NC MRR / FIN+NOM: 11/02/15 MRR
- 326: ECHEANCE: NC PCB layout / FIN+NOM: 25/02/15 PCB layout
- 327: ECHEANCE: NC PCB manufacturing / FIN+NOM: 15/04/15 PCB manufacturing
- 328: ECHEANCE: NC LVPS-PDU FPGA ready for assembly / FIN+NOM: 17/03/15 LVPS-PDU FPGA ready for assembly
- 329: ECHEANCE: NC LVPS-PDU Parts available for assembly / FIN+NOM: 07/05/15 LVPS-PDU Parts available for assembly
- 330: ECHEANCE: NC LVPS-PDU PFM1 & PFM2 HW assembly & tests / FIN+NOM: 23/11/15 LVPS-PDU PFM1 & PFM2 HW design,dev & tests
- 331: ECHEANCE: NC Parts assembly / FIN+NOM: 24/06/15 Parts assembly
- 332: ECHEANCE: NC Board delivery / FIN+NOM: 26/06/15 Board delivery
- 333: ECHEANCE: NC Board testing / FIN+NOM: 31/07/15 Board testing
- 334: ECHEANCE: NC Need date for mechanical frame / FIN+NOM: 03/08/15 Need date for mechanical frame
- 335: ECHEANCE: NC TRR preparation (documentation) / FIN+NOM: 10/08/15 TRR preparation (documentation)
- 336: ECHEANCE: NC Boards ready for MIP and TRR / FIN+NOM: 11/08/15 Boards ready for MIP and TRR
- 337: ECHEANCE: NC Integration of PCB and mechanical frame / FIN+NOM: 19/08/15 Integration of PCB and mechanical frame
- 338: ECHEANCE: NC TRR / FIN+NOM: 20/08/15 TRR
- 339: ECHEANCE: NC Board full functional and performance tests / FIN+NOM: 23/09/15 Board full functional and performance tests
- 340: ECHEANCE: NC Board EMC & ReviewTests (EMC chamber) / FIN+NOM: 21/10/15 Board EMC & ReviewTests (EMC chamber)
- 341: ECHEANCE: NC Coating of PCB and integration into mechanical frame / FIN+NOM: 28/10/15 Coating of PCB and integration into mechanical frame
- 342: ECHEANCE: NC Post-coating tests and characterization / FIN+NOM: 04/11/15 Post-coating tests and characterization
- 343: ECHEANCE: NC Board thermal tests (if any) / FIN+NOM: 18/11/15 Board thermal tests (if any)
- 344: ECHEANCE: NC TRB and DRB / FIN+NOM: 20/11/15 TRB and DRB
- 345: ECHEANCE: NC LVPS-PDU PFM1 & PFM2 ready for delivery to lesia for AIT MEB / FIN+NOM: 23/11/15 LVPS-PDU PFM1 & PFM2 ready for delivery to lesia for AIT MEB
- 346: ECHEANCE: NC FM HW design and development / FIN+NOM: 12/05/16 FM Spare (consolidate logic starting the spare)
- 347: ECHEANCE: NC MRR preparation (documentation) / FIN+NOM: 30/11/15 MRR preparation (documentation)
- 348: ECHEANCE: NC MRR / FIN+NOM: 01/12/15 MRR
- 349: ECHEANCE: NC PCB manufacturing / FIN+NOM: 29/12/15 PCB manufacturing
- 350: ECHEANCE: NC Parts assembly / FIN+NOM: 02/02/16 Parts assembly
- 351: ECHEANCE: NC Board delivery / FIN+NOM: 03/02/16 Board delivery
- 352: ECHEANCE: NC Board testing / FIN+NOM: 09/03/16 Board testing
- 353: ECHEANCE: NC Need date for mechanical frame / FIN+NOM: 10/03/16 Need date for mechanical frame
- 354: ECHEANCE: NC Integration of PCB and mechanical frame / FIN+NOM: 17/03/16 Integration of PCB and mechanical frame
- 355: ECHEANCE: NC TRR / FIN+NOM: 21/03/16 TRR
- 356: ECHEANCE: NC Board full functional and performance tests / FIN+NOM: 25/04/16 Board full functional and performance tests
- 357: ECHEANCE: NC Coating of PCB and integration into mechanical frame / FIN+NOM: 02/05/16 Coating of PCB and integration into mechanical frame
- 358: ECHEANCE: NC Post-coating tests and characterization / FIN+NOM: 09/05/16 Post-coating tests and characterization
- 359: ECHEANCE: NC TRB and DRB / FIN+NOM: 11/05/16 TRB and DRB
- 360: ECHEANCE: NC LVPS-PDU FM Spare for delivery to lesia for AIT MEB / FIN+NOM: 12/05/16 LVPS-PDU FM Spare for delivery to lesia for AIT MEB

| ID | WBS | Task | Duration | Start | Finish | Predecessors | Complete | Remaining | Baseline start | Baseline finish | Baseline duration | Total slack | Free slack | Constraint | Calendar | OldLg | Texte17 | Ancien Num |
| --- | --- | --- | --- | --- | --- | --- | --- | --- | --- | --- | --- | --- | --- | --- | --- | --- | --- | --- |
| 361 | 3.2.3 | **FPGA developments** | 161d | 2014-08-04 A | 2015-03-16 |  | 54% | 73.97d |  |  |  | 45.5d |  |  | Cnes_LVPS_PDU |  |  |  |
| 362 | 3.2.3.1 | **Em3 Firmware** | 22d | 2014-08-04 A | 2014-09-02 A |  | 100% |  |  |  |  |  |  |  | Cnes_LVPS_PDU |  |  |  |
| 363 | 3.2.3.1.1 | Functional simulation and post layout simulation, programming file generation | 21d | 2014-08-04 A | 2014-09-01 A |  | 100% |  |  |  |  |  |  | start no earlier than 2014-08-04 | Cnes_LVPS_PDU |  |  |  |
| 364 | 3.2.3.1.2 | Firmware ready for Em3 | 1d | 2014-09-02 A | 2014-09-02 A | 363 | 100% |  |  |  |  |  |  |  | Cnes_LVPS_PDU |  |  |  |
| 365 | 3.2.3.2 | **FM & EM4 firmware** | 156d | 2014-08-11 A | 2015-03-16 |  | 48% | 81.35d |  |  |  | 45.5d |  |  | Cnes_LVPS_PDU |  |  |  |
| 366 | 3.2.3.2.1 | Remaping to FM FPGA | 5d | 2014-08-11 A | 2014-08-15 A |  | 100% |  |  |  |  |  |  | start no earlier than 2014-08-11 | Cnes_LVPS_PDU |  |  |  |
| 367 | 3.2.3.2.2 | Post layout simulation, programming file generation | 15d | 2014-08-11 A | 2014-08-29 A |  | 100% |  |  |  |  |  |  | start no earlier than 2014-08-11 | Cnes_LVPS_PDU |  |  |  |
| 368 | 3.2.3.2.3 | Documentation, including simulation documentation, timing analysis | 50d | 2014-09-01 A | 2014-11-07 A | 367 | 100% |  |  |  |  |  |  |  | Cnes_LVPS_PDU |  |  |  |
| 369 | 3.2.3.2.4 | Tests result analysis (Cnes / Lesia) | 20d | 2014-11-10 A | 2014-12-05 | 368 | 40% | 12d |  |  |  | 0d |  |  | Cnes_LVPS_PDU |  |  |  |
| 370 | 3.2.3.2.5 | Validation KP | 10d | 2014-12-08 | 2014-12-19 | 369 |  |  |  |  |  | 0d |  |  | Cnes_LVPS_PDU |  |  |  |
| 371 | 3.2.3.2.6 | Complementary tests follow-up analysis | 20d | 2014-12-22 | 2015-01-16 | 370 |  |  |  |  |  | 0d |  |  | Cnes_LVPS_PDU |  |  |  |
| 372 | 3.2.3.2.7 | GO / NOGO FM FPGA ready for programming | 1d | 2015-01-19 | 2015-01-19 | 371 |  |  |  |  |  | 0d |  |  | Cnes_LVPS_PDU |  |  |  |
| 373 | 3.2.3.2.8 | FPGA delivery | 1d | 2015-01-09 | 2015-01-09 | 265 |  |  |  |  |  | 0d |  |  | Cnes_LVPS_PDU |  |  |  |
| 374 | 3.2.3.2.9 | FPGA programming | 10d | 2015-01-19 | 2015-01-30 | 371 |  |  |  |  |  | 24d | 0d |  |  |  |  |  |
| 375 | 3.2.3.2.10 | PPBI | 30d | 2015-02-02 | 2015-03-13 | 374 |  |  |  |  |  | 41.5d | 0d |  |  |  |  |  |
| 376 | 3.2.3.2.11 | Firmware ready for FM assembly | 1d | 2015-03-16 | 2015-03-16 | 375 |  |  |  |  |  | 41.5d | 0d |  |  |  |  |  |
| 377 | 3.2.4 | **GSE development** | 53d | 2014-08-04 A | 2014-10-15 A |  | 100% |  |  |  |  |  |  |  | Cnes_LVPS_PDU |  |  |  |
| 378 | 3.2.4.1 | **Em3 GSE develompment** | 53d | 2014-08-04 A | 2014-10-15 A |  | 100% |  |  |  |  |  |  |  | Cnes_LVPS_PDU |  |  |  |
| 379 | 3.2.4.1.1 | EGSE | 53d | 2014-08-04 A | 2014-10-15 A |  | 100% |  |  |  |  |  |  | start no earlier than 2014-08-04 | Cnes_LVPS_PDU |  |  |  |
| 380 | 3.2.4.1.2 | Frame Manufacturing | 20d | 2014-08-20 A | 2014-09-16 A | 273 | 100% |  |  |  |  |  |  |  | Cnes_LVPS_PDU |  |  |  |
| 381 | 3.3 | **BIAS** | 300.5d | 2014-07-22 A | 2015-09-29 |  | 39% | 182.63d | 2012-05-11 | 2014-07-29 | 556d | 0d |  |  |  | 246 | 307 | 261 |
| 382 | 3.3.1 | **Parts procurement** | 121d | 2014-08-20 A | 2015-02-20 |  | 50% | 60.96d |  |  |  | 62.5d |  |  | Cnes_BIAS |  |  |  |
| 383 | 3.3.1.1 | **FM parts** | 130d | 2014-08-20 A | 2015-02-20 |  | 50% | 65.5d |  |  |  | 58.5d |  |  |  |  |  |  |
| 384 | 3.3.1.1.1 | LLI parts | 130d | 2014-08-20 A | 2015-02-20 |  | 50% | 65d |  |  |  | 58.5d | 0d | start no earlier than 2014-08-20 |  |  |  |  |
| 385 | 3.3.1.1.2 | Parts | 1d | 2014-11-28 | 2014-11-28 |  |  |  |  |  |  | 0d |  | start no earlier than 2014-11-28 |  |  |  |  |

Notes:
- 361: FIN+NOM: 16/03/15 FPGA developments
- 362: FIN+NOM: 02/09/14 Em3 Firmware
- 363: ECHEANCE: NC Functional simulation and post layout simulation, programming file generation / FIN+NOM: 01/09/14 Functional simulation and post layout simulation, programming file generation
- 364: ECHEANCE: NC Firmware ready for Em3 / FIN+NOM: 02/09/14 Firmware ready for Em3
- 365: ECHEANCE: NC FM firmware / FIN+NOM: 16/03/15 FM & EM4 firmware
- 366: ECHEANCE: NC Remaping to FM FPGA / FIN+NOM: 15/08/14 Remaping to FM FPGA
- 367: ECHEANCE: NC Post layout simulation, programming file generation / FIN+NOM: 29/08/14 Post layout simulation, programming file generation
- 368: ECHEANCE: NC Documentation, including simulation documentation, timing analysis / FIN+NOM: 07/11/14 Documentation, including simulation documentation, timing analysis
- 369: ECHEANCE: NC Tests result analysis (Cnes / Lesia) / FIN+NOM: 05/12/14 Tests result analysis (Cnes / Lesia)
- 370: ECHEANCE: NC Validation KP / FIN+NOM: 19/12/14 Validation KP
- 371: ECHEANCE: NC Complementary tests follow-up analysis / FIN+NOM: 16/01/15 Complementary tests follow-up analysis
- 372: ECHEANCE: NC GO / NOGO FM FPGA ready for programming / FIN+NOM: 19/01/15 GO / NOGO FM FPGA ready for programming
- 373: ECHEANCE: NC FPGA delivery / FIN+NOM: 09/01/15 FPGA delivery
- 374: ECHEANCE: NC FPGA programming / FIN+NOM: 30/01/15 FPGA programming
- 375: ECHEANCE: NC PPBI / FIN+NOM: 13/03/15 PPBI
- 376: ECHEANCE: NC Firmware ready for FM assembly / FIN+NOM: 16/03/15 Firmware ready for FM assembly
- 377: ECHEANCE: NC GSE development / FIN+NOM: 15/10/14 GSE development
- 378: FIN+NOM: 15/10/14 Em3 GSE develompment
- 379: ECHEANCE: NC EGSE / FIN+NOM: 15/10/14 EGSE
- 380: ECHEANCE: NC Frame Manufacturing / FIN+NOM: 16/09/14 Frame Manufacturing
- 381: FIN+NOM: 29/09/15 BIAS
- 382: ECHEANCE: NC Parts procurement / FIN+NOM: 20/02/15 Parts procurement
- 383: ECHEANCE: NC FM parts / FIN+NOM: 20/02/15 FM parts
- 384: to discuss / high voltage capacitors / ECHEANCE: NC LLI parts / FIN+NOM: 20/02/15 LLI parts
- 385: ECHEANCE: NC Parts / FIN+NOM: 28/11/14 Parts

| ID | WBS | Task | Type | Duration | Start | Finish | Predecessors | Complete | Remaining | Total slack | Free slack | Constraint | Calendar | Text20 |
| --- | --- | --- | --- | --- | --- | --- | --- | --- | --- | --- | --- | --- | --- | --- |
| 386 | 3.3.2 | **Hardware developments** |  | 300.5d | 2014-07-22 A | 2015-09-29 |  | 28% | 217.16d | 0d |  |  |  |  |
| 387 | 3.3.2.1 | **Pre-EQM1 HW design and development** |  | 40d | 2014-07-22 A | 2014-09-16 A |  | 100% |  |  |  |  |  |  |
| 388 | 3.3.2.1.1 | Complementary NCR investigation |  | 10d | 2014-07-22 A | 2014-08-04 A |  | 100% |  |  |  | start no earlier than 2014-07-22 |  |  |
| 389 | 3.3.2.1.2 | Board update |  | 10d | 2014-07-22 A | 2014-08-04 A | 388SS | 100% |  |  |  |  |  |  |
| 390 | 3.3.2.1.3 | Board testing full functional and performance |  | 10d | 2014-08-18 A | 2014-08-29 A | 389 | 100% |  |  |  | start no earlier than 2014-08-15 |  |  |
| 391 | 3.3.2.1.4 | Board EMC Tests |  | 10d | 2014-09-01 A | 2014-09-12 A | 390 | 100% |  |  |  |  |  |  |
| 392 | 3.3.2.1.5 | TRB and DRB (for acceptance) |  | 1d | 2014-09-15 A | 2014-09-15 A | 391 | 100% |  |  |  |  |  |  |
| 393 | 3.3.2.1.6 | BIAS pre-EQM ready for delivery to LESIA / CNES for complementary tests |  | 1d | 2014-09-16 A | 2014-09-16 A | 392 | 100% |  |  |  |  |  |  |
| 394 | 3.3.2.2 | **BIAS Pre-EQM2 HW design,dev & tests (For MEB EM2)** |  | 80d | 2014-09-17 A | 2015-01-21 |  | 35% | 51.65d | 20d |  |  | Cnes_BIAS | Yes |
| 395 | 3.3.2.2.1 | Design consolidation |  | 20d | 2014-09-17 A | 2014-10-14 A | 393 | 100% |  |  |  |  | Cnes_BIAS |  |
| 396 | 3.3.2.2.2 | Preparation MRR documentation delivery |  | 8d | 2014-10-15 A | 2014-10-24 A | 395 | 100% |  |  |  |  | Cnes_BIAS |  |
| 397 | 3.3.2.2.3 | MRR by Telecom | milestone | 0d | 2014-10-31 | 2014-10-31 | 396FS+5d |  |  | 0d |  |  | Cnes_BIAS |  |
| 398 | 3.3.2.2.4 | Go-ahead for manufacturing | milestone | 0d | 2014-11-05 | 2014-11-05 | 397FS+3d |  |  | 0d |  |  | Cnes_BIAS |  |
| 399 | 3.3.2.2.5 | PCB manufacturing |  | 10d | 2014-11-06 | 2014-11-20 | 398 |  |  | 0d |  |  | Cnes_BIAS |  |
| 400 | 3.3.2.2.6 | Parts Assembly on PCB |  | 14d | 2014-11-21 | 2014-12-10 | 399 |  |  | 0d |  |  | Cnes_BIAS |  |
| 401 | 3.3.2.2.7 | TRR documentation preparation |  | 14d | 2014-11-21 | 2014-12-10 | 399 |  |  | 0d |  |  | Cnes_BIAS |  |
| 402 | 3.3.2.2.8 | TRR in IRF | milestone | 0d | 2014-12-12 | 2014-12-12 | 401FS+2d |  |  | 0d |  |  | Cnes_BIAS |  |
| 403 | 3.3.2.2.9 | Pre-EQM2 validation |  | 13d | 2014-12-15 | 2015-01-14 | 402 |  |  | 0d |  |  | Cnes_BIAS |  |
| 404 | 3.3.2.2.10 | Tests report delivery | milestone | 0d | 2015-01-14 | 2015-01-14 | 403 |  |  | 0d |  |  | Cnes_BIAS |  |
| 405 | 3.3.2.2.11 | Pre-EQM2 BIAS TRB/DRB in LESIA & delivery | milestone | 0d | 2015-01-21 | 2015-01-21 | 403FS+5d |  |  | 20d | 0d |  | Cnes_BIAS |  |
| 406 | 3.3.2.3 | **BIAS PFM HW design and development** |  | 229.5d | 2014-10-30 A | 2015-09-29 |  | 1% | 227.8d | 0d |  |  |  | Yes |
| 407 | 3.3.2.3.1 | **PCB** |  | 34d | 2015-01-22 | 2015-03-10 |  |  |  | 47.5d |  |  |  |  |
| 408 | 3.3.2.3.1.1 | H/W definition and schematics (update) |  | 2d | 2015-01-22 | 2015-01-23 | 405 |  |  | 47.5d | 0d |  |  |  |
| 409 | 3.3.2.3.1.2 | PCB layout |  | 2d | 2015-01-26 | 2015-01-27 | 408 |  |  | 47.5d | 0d |  |  |  |
| 410 | 3.3.2.3.1.3 | PCB manufacturing |  | 30d | 2015-01-28 | 2015-03-10 | 409 |  |  | 47.5d |  |  |  |  |
| 411 | 3.3.2.3.2 | MRR preparation (documentation) |  | 5d | 2015-01-22 | 2015-01-28 | 408SS |  |  | 75.5d |  |  |  |  |
| 412 | 3.3.2.3.3 | FPGA ready for assembly |  | 1d | 2014-10-30 A | 2014-10-30 A | 437 | 100% |  |  |  |  |  |  |
| 413 | 3.3.2.3.4 | BIAS PFM Parts available for assembly | milestone | 1d | 2015-02-23 | 2015-02-23 | 384 |  |  | 58.5d |  |  |  |  |

Notes:
- 386: ECHEANCE: NC Hardware developments / FIN+NOM: 29/09/15 Hardware developments
- 387: ECHEANCE: NC EQMx HW design and development / FIN+NOM: 16/09/14 Pre-EQM1 HW design and development
- 388: ECHEANCE: NC Complementary NCR investigation / FIN+NOM: 04/08/14 Complementary NCR investigation
- 389: ECHEANCE: NC Board update / FIN+NOM: 04/08/14 Board update
- 390: ECHEANCE: NC Board testing full functional and performance / FIN+NOM: 29/08/14 Board testing full functional and performance
- 391: ECHEANCE: NC Board EMC Tests / FIN+NOM: 12/09/14 Board EMC Tests
- 392: ECHEANCE: NC TRB and DRB (for acceptance) / FIN+NOM: 15/09/14 TRB and DRB (for acceptance)
- 393: ECHEANCE: NC BIAS pre-EQM ready for delivery to LESIA / CNES for complementary tests / FIN+NOM: 16/09/14 BIAS pre-EQM ready for delivery to LESIA / CNES for complementary tests
- 394: ECHEANCE: NC EQMx HW design and development / FIN+NOM: 21/01/15 BIAS Pre-EQM2 HW design,dev & tests (For MEB EM2)
- 395: ECHEANCE: NC Design consolidation / FIN+NOM: 14/10/14 Design consolidation
- 396: ECHEANCE: NC Preparation MRR documentation delivery / FIN+NOM: 24/10/14 Preparation MRR documentation delivery
- 397: ECHEANCE: NC MRR by Telecom / FIN+NOM: 31/10/14 MRR by Telecom
- 398: ECHEANCE: NC Go-ahead for manufacturing / FIN+NOM: 05/11/14 Go-ahead for manufacturing
- 399: ECHEANCE: NC PCB manufacturing / FIN+NOM: 20/11/14 PCB manufacturing
- 400: ECHEANCE: NC Parts Assembly on PCB / FIN+NOM: 10/12/14 Parts Assembly on PCB
- 401: ECHEANCE: NC TRR documentation preparation / FIN+NOM: 10/12/14 TRR documentation preparation
- 402: ECHEANCE: NC TRR in IRF / FIN+NOM: 12/12/14 TRR in IRF
- 403: ECHEANCE: NC Pre-EQM2 validation / FIN+NOM: 14/01/15 Pre-EQM2 validation
- 404: ECHEANCE: NC Tests report delivery / FIN+NOM: 14/01/15 Tests report delivery
- 405: ECHEANCE: NC Pre-EQM2 BIAS TRB/DRB in LESIA & delivery / FIN+NOM: 21/01/15 Pre-EQM2 BIAS TRB/DRB in LESIA & delivery
- 406: Assumed 4 weeks testing at LESIA/CNES before PFM go-ahead / ECHEANCE: NC FM HW design and development / FIN+NOM: 29/09/15 BIAS PFM HW design and development
- 407: ECHEANCE: NC PCB / FIN+NOM: 10/03/15 PCB
- 408: ECHEANCE: NC H/W definition and schematics (update) / FIN+NOM: 23/01/15 H/W definition and schematics (update)
- 409: ECHEANCE: NC PCB layout / FIN+NOM: 27/01/15 PCB layout
- 410: Invotec lead time 5 weeks plus delivery / ECHEANCE: NC PCB manufacturing / FIN+NOM: 10/03/15 PCB manufacturing
- 411: ECHEANCE: NC MRR preparation (documentation) / FIN+NOM: 28/01/15 MRR preparation (documentation)
- 412: ECHEANCE: NC FPGA ready for assembly / FIN+NOM: 30/10/14 FPGA ready for assembly
- 413: No date for LLI PFM parts / ECHEANCE: NC BIAS PFM Parts available for assembly / FIN+NOM: 23/02/15 BIAS PFM Parts available for assembly

| ID | WBS | Task | Type | Duration | Start | Finish | Predecessors | Complete | Total slack | Constraint | ECHEANCE |
| --- | --- | --- | --- | --- | --- | --- | --- | --- | --- | --- | --- |
| 414 | 3.3.2.3.5 | **BIAS PFM HW design,dev & tests** |  | 92d | 2015-05-20 | 2015-09-29 |  |  | 0d |  | NC BIAS PFM HW assembly & tests |
| 415 | 3.3.2.3.5.1 | MRR |  | 1d | 2015-05-20 | 2015-05-21 | 1065, 411 |  | 0d |  | NC MRR |
| 416 | 3.3.2.3.5.2 | Parts assembly and coating + testing at RUAG |  | 50d | 2015-05-21 | 2015-08-03 | 413, 412, 410, 415 |  | 0d |  | NC Parts assembly and coating + testing at RUAG |
| 417 | 3.3.2.3.5.3 | Board delivery |  | 1d | 2015-08-03 | 2015-08-04 | 416 |  | 0d |  | NC Board delivery |
| 418 | 3.3.2.3.5.4 | Need date for mechanical frame |  | 1d | 2015-08-04 | 2015-08-05 | 417 |  | 0d |  | NC Need date for mechanical frame |
| 419 | 3.3.2.3.5.5 | TRR preparation (documentation) |  | 1d | 2015-08-04 | 2015-08-05 | 417 |  | 0d |  | NC TRR preparation (documentation) |
| 420 | 3.3.2.3.5.6 | Boards ready for MIP and TRR |  | 1d | 2015-08-04 | 2015-08-05 | 417 |  | 0d |  | NC Boards ready for MIP and TRR |
| 421 | 3.3.2.3.5.7 | Integration in mechanical frame |  | 1d | 2015-08-05 | 2015-08-06 | 420, 260 |  | 0d |  | NC Integration in mechanical frame |
| 422 | 3.3.2.3.5.8 | TRR |  | 1d | 2015-08-06 | 2015-08-07 | 421, 420 |  | 0d |  | NC TRR |
| 423 | 3.3.2.3.5.9 | Board full functional and performance tests |  | 20d | 2015-08-07 | 2015-09-04 | 422 |  | 0d |  | NC Board full functional and performance tests |
| 424 | 3.3.2.3.5.10 | Board EMC and additional Tests |  | 10d | 2015-09-04 | 2015-09-18 | 423 |  | 0d |  | NC Board EMC and additional Tests |
| 425 | 3.3.2.3.5.11 | Board thermal tests (if any) |  | 5d | 2015-09-18 | 2015-09-25 | 424 |  | 0d |  | NC Board thermal tests (if any) |
| 426 | 3.3.2.3.5.12 | TRB and DRB |  | 1d | 2015-09-25 | 2015-09-28 | 425 |  | 0d |  | NC TRB and DRB |
| 427 | 3.3.2.3.5.13 | BIAS PFM ready for delivery to LESIA for AIT MEB |  | 1d | 2015-09-28 | 2015-09-29 | 426 |  | 0d |  | NC BIAS PFM ready for delivery to LESIA for AIT MEB |
| 428 | 3.3.3 | **FPGA developments** |  | 11d | 2014-10-15 A | 2014-10-29 A |  | 100% |  |  | NC FPGA developments |
| 429 | 3.3.3.1 | **PFM firmware** |  | 11d | 2014-10-15 A | 2014-10-29 A |  | 100% |  |  |  |
| 430 | 3.3.3.1.1 | Completion of the firmware and tests documentation |  | 5d | 2014-10-15 A | 2014-10-21 A |  | 100% |  | start no earlier than 2014-10-15 | NC Completion of the firmware and tests documentation |
| 431 | 3.3.3.1.2 | Tests result analysis (Cnes / Lesia) |  | 1d | 2014-10-22 A | 2014-10-22 A |  | 100% |  | start no earlier than 2014-10-22 | NC Tests result analysis (Cnes / Lesia) |
| 432 | 3.3.3.1.3 | Validation KP |  | 1d | 2014-10-23 A | 2014-10-23 A |  | 100% |  | start no earlier than 2014-10-23 | NC Validation KP |
| 433 | 3.3.3.1.4 | Complementary tests follow-up analysis |  | 1d | 2014-10-24 A | 2014-10-24 A |  | 100% |  | start no earlier than 2014-10-24 | NC Complementary tests follow-up analysis |
| 434 | 3.3.3.1.5 | GO / NOGO FM FPGA ready for programmation |  | 1d | 2014-10-27 A | 2014-10-27 A |  | 100% |  | start no earlier than 2014-10-27 | NC GO / NOGO FM FPGA ready for programmation |
| 435 | 3.3.3.1.6 | FPGA programmation |  | 1d | 2014-10-28 A | 2014-10-28 A |  | 100% |  | start no earlier than 2014-10-28 | NC FPGA programmation |
| 436 | 3.3.3.1.7 | PPBI | milestone | 0d | 2014-10-28 A | 2014-10-28 A |  | 100% |  | start no earlier than 2014-10-28 | NC PPBI |
| 437 | 3.3.3.1.8 | Firmware ready for FM assembly |  | 1d | 2014-10-29 A | 2014-10-29 A |  | 100% |  | start no earlier than 2014-10-29 | NC Firmware ready for FM assembly |

Notes:
- 414: FIN+NOM: 29/09/15 BIAS PFM HW design,dev & tests
- 415: FIN+NOM: 21/05/15 MRR
- 416: RUAG lead time 8-10 weeks, including Christmas shutdown. May be improved on after they have received the order and know their manufacturing schedule / FIN+NOM: 03/08/15 Parts assembly and coating + testing at RUAG
- 417: FIN+NOM: 04/08/15 Board delivery
- 418: New Link / FIN+NOM: 05/08/15 Need date for mechanical frame
- 419: FIN+NOM: 05/08/15 TRR preparation (documentation)
- 420: FIN+NOM: 05/08/15 Boards ready for MIP and TRR
- 421: No Linked with frame availability in chassi schedule because doesn't exist / FIN+NOM: 06/08/15 Integration in mechanical frame
- 422: FIN+NOM: 07/08/15 TRR
- 423: Including Easter / FIN+NOM: 04/09/15 Board full functional and performance tests
- 424: FIN+NOM: 18/09/15 Board EMC and additional Tests
- 425: FIN+NOM: 25/09/15 Board thermal tests (if any)
- 426: FIN+NOM: 28/09/15 TRB and DRB
- 427: FIN+NOM: 29/09/15 BIAS PFM ready for delivery to LESIA for AIT MEB
- 428: FIN+NOM: 29/10/14 FPGA developments
- 429: FIN+NOM: 29/10/14 PFM firmware
- 430: FIN+NOM: 21/10/14 Completion of the firmware and tests documentation
- 431: FIN+NOM: 22/10/14 Tests result analysis (Cnes / Lesia)
- 432: FIN+NOM: 23/10/14 Validation KP
- 433: FIN+NOM: 24/10/14 Complementary tests follow-up analysis
- 434: FIN+NOM: 27/10/14 GO / NOGO FM FPGA ready for programmation
- 435: FIN+NOM: 28/10/14 FPGA programmation
- 436: FIN+NOM: 28/10/14 PPBI
- 437: FIN+NOM: 29/10/14 Firmware ready for FM assembly

| ID | WBS | Task | Type | Duration | Start | Finish | Predecessors | Complete | Remaining | Baseline start | Baseline finish | Baseline duration | Total slack | Free slack | Constraint | Calendar | ECHEANCE | OldLg | Texte17 | Ancien Num |
| --- | --- | --- | --- | --- | --- | --- | --- | --- | --- | --- | --- | --- | --- | --- | --- | --- | --- | --- | --- | --- |
| 438 | 3.3.4 | **GSE develompment** |  | 15d | 2014-09-17 A | 2014-10-07 A |  | 100% |  |  |  |  |  |  |  |  |  |  |  |  |
| 439 | 3.3.4.1 | EGSE |  | 15d | 2014-09-17 A | 2014-10-07 A |  | 100% |  |  |  |  |  |  | start no earlier than 2014-09-17 |  | NC EGSE |  |  |  |
| 440 | 3.4 | **TDS** |  | 314.5d | 2014-06-25 A | 2015-10-02 |  | 32% | 214.54d | 2012-05-11 | 2014-07-29 | 556d | 0d |  |  | Cnes_TDS |  | 263 | 329 | 278 |
| 441 | 3.4.1 | **Parts procurement** |  | 65d | 2014-09-05 A | 2014-12-05 |  | 89% | 7.09d |  |  |  | 109.5d |  |  | Cnes_TDS | NC Parts procurement |  |  |  |
| 442 | 3.4.1.1 | **EQM/EM2 parts** |  | 45d | 2014-09-08 A | 2014-11-07 A |  | 100% |  |  |  |  |  |  |  | Cnes_TDS | NC EQM parts |  |  |  |
| 443 | 3.4.1.1.1 | LLI parts |  | 45d | 2014-09-08 A | 2014-11-07 A |  | 100% |  |  |  |  |  |  | start no earlier than 2014-09-08 | Cnes_TDS | NC LLI parts |  |  |  |
| 444 | 3.4.1.2 | **FM parts** |  | 65d | 2014-09-05 A | 2014-12-05 |  | 82% | 12d |  |  |  | 109.5d |  |  | Cnes_TDS | NC FM parts |  |  |  |
| 445 | 3.4.1.2.1 | LLI parts |  | 65d | 2014-09-05 A | 2014-12-05 |  | 82% | 12d |  |  |  | 109.5d | 0d | start no earlier than 2014-09-05 | Cnes_TDS | NC LLI parts |  |  |  |
| 446 | 3.4.2 | **Hardware developments** |  | 299.5d | 2014-07-17 A | 2015-10-02 |  | 35% | 193.79d |  |  |  | 0d |  |  | Cnes_TDS | NC Hardware developments |  |  |  |
| 447 | 3.4.2.1 | **pre-EQM HW design and development (if EQM supressed)** |  | 61d | 2014-07-17 A | 2014-10-17 A |  | 100% |  |  |  |  |  |  |  | Cnes_TDS | NC EQM HW design and development |  |  |  |
| 448 | 3.4.2.1.1 | NCR investigation, board testing and tuning |  | 4w | 2014-07-17 A | 2014-08-21 A |  | 100% |  |  |  |  |  |  | start no earlier than 2014-07-17 | Cnes_TDS | NC NCR investigation, board testing and tuning |  |  |  |
| 449 | 3.4.2.1.2 | Final pre-EQM testing |  | 3w | 2014-08-25 A | 2014-09-12 A | 448 | 100% |  |  |  |  |  |  | start no earlier than 2014-08-25 | Cnes_TDS | NC Final pre-EQM testing |  |  |  |
| 450 | 3.4.2.1.3 | TRR (light) |  | 2d | 2014-09-15 A | 2014-09-16 A | 449 | 100% |  |  |  |  |  |  |  | Cnes_TDS | NC TRR (light) |  |  |  |
| 451 | 3.4.2.1.4 | Board testing full functionnal and performance |  | 10d | 2014-09-18 A | 2014-10-01 A | 450FS+1d | 100% |  |  |  |  |  |  |  | Cnes_TDS | NC Board testing full functionnal and performance |  |  |  |
| 452 | 3.4.2.1.5 | Board EMC Tests |  | 10d | 2014-10-02 A | 2014-10-15 A | 451 | 100% |  |  |  |  |  |  |  | Cnes_TDS | NC Board EMC Tests |  |  |  |
| 453 | 3.4.2.1.6 | TDS pre-EM+ TRB and DRB (for acceptance) |  | 2d | 2014-10-16 A | 2014-10-17 A | 452 | 100% |  |  |  |  |  |  |  | Cnes_TDS | NC TDS pre-EM+ TRB and DRB (for acceptance) |  |  |  |
| 454 | 3.4.2.2 | **TDS EM2 HW design,dev & tests** |  | 95d | 2014-09-01 A | 2015-01-26 |  | 62% | 35.87d |  |  |  | 18.5d |  |  | Cnes_TDS | NC EM+ |  |  |  |
| 455 | 3.4.2.2.1 | PCB finalization |  | 25d | 2014-09-01 A | 2014-10-03 A |  | 100% |  |  |  |  |  |  | start no earlier than 2014-09-01 | Cnes_TDS | NC PCB finalization |  |  |  |
| 456 | 3.4.2.2.2 | MRR paperwork |  | 5d | 2014-09-29 A | 2014-10-03 A | 455FF | 100% |  |  |  |  |  |  |  | Cnes_TDS | NC MRR paperwork |  |  |  |
| 457 | 3.4.2.2.3 | light MRR |  | 5d | 2014-10-06 A | 2014-10-10 A | 455, 456 | 100% |  |  |  |  |  |  |  | Cnes_TDS | NC light MRR |  |  |  |
| 458 | 3.4.2.2.4 | PCB manufacturing (commercial) |  | 15d | 2014-10-13 A | 2014-10-31 A | 457 | 100% |  |  |  |  |  |  |  | Cnes_TDS | NC PCB manufacturing (commercial) |  |  |  |
| 459 | 3.4.2.2.5 | Assembly |  | 20d | 2014-11-04 A | 2014-12-02 | 458FS+1d, 443FS-2w, 497 | 55% | 9d |  |  |  | 18.5d | 0d |  | Cnes_TDS | NC Assembly |  |  |  |
| 460 | 3.4.2.2.6 | Testing validation Part 1 |  | 10d | 2014-12-04 | 2014-12-17 | 459FS+1d |  |  |  |  |  | 18.5d | 0d |  | Cnes_TDS | NC Testing validation Part 1 |  |  |  |
| 461 | 3.4.2.2.7 | TRR |  | 1d | 2014-12-18 | 2014-12-18 | 460 |  |  |  |  |  | 18.5d | 0d |  | Cnes_TDS | NC TRR |  |  |  |
| 462 | 3.4.2.2.8 | Tests part 2 (EMC & performance) |  | 15d | 2014-12-19 | 2015-01-22 | 461 |  |  |  |  |  | 18.5d | 0d |  | Cnes_TDS | NC Tests part 2 (EMC & performance) |  |  |  |
| 463 | 3.4.2.2.9 | Test report compilatoin |  | 2d | 2015-01-23 | 2015-01-26 | 462 |  |  |  |  |  | 18.5d | 0d |  | Cnes_TDS | NC Test report compilatoin |  |  |  |
| 464 | 3.4.2.2.10 | EM2 TDS Delivery to LESIA | milestone | 0d | 2015-01-26 | 2015-01-26 | 463 |  |  |  |  |  | 18.5d | 0d |  | Cnes_TDS | NC EM2 TDS Delivery to LESIA |  |  |  |

Notes:
- 438: FIN+NOM: 07/10/14 GSE develompment
- 439: FIN+NOM: 07/10/14 EGSE
- 440: FIN+NOM: 02/10/15 TDS
- 441: FIN+NOM: 05/12/14 Parts procurement
- 442: FIN+NOM: 07/11/14 EQM/EM2 parts
- 443: FIN+NOM: 07/11/14 LLI parts
- 444: FIN+NOM: 05/12/14 FM parts
- 445: FIN+NOM: 05/12/14 LLI parts
- 446: FIN+NOM: 02/10/15 Hardware developments
- 447: FIN+NOM: 17/10/14 pre-EQM HW design and development (if EQM supressed)
- 448: FIN+NOM: 21/08/14 NCR investigation, board testing and tuning
- 449: FIN+NOM: 12/09/14 Final pre-EQM testing
- 450: FIN+NOM: 16/09/14 TRR (light)
- 451: FIN+NOM: 01/10/14 Board testing full functionnal and performance
- 452: FIN+NOM: 15/10/14 Board EMC Tests
- 453: FIN+NOM: 17/10/14 TDS pre-EM+ TRB and DRB (for acceptance)
- 454: FIN+NOM: 26/01/15 TDS EM2 HW design,dev & tests
- 455: FIN+NOM: 03/10/14 PCB finalization
- 456: FIN+NOM: 03/10/14 MRR paperwork
- 457: FIN+NOM: 10/10/14 light MRR
- 458: FIN+NOM: 31/10/14 PCB manufacturing (commercial)
- 459: FIN+NOM: 02/12/14 Assembly
- 460: FIN+NOM: 17/12/14 Testing validation Part 1
- 461: FIN+NOM: 18/12/14 TRR
- 462: FIN+NOM: 22/01/15 Tests part 2 (EMC & performance)
- 463: FIN+NOM: 26/01/15 Test report compilatoin
- 464: FIN+NOM: 26/01/15 EM2 TDS Delivery to LESIA

| ID | WBS | Task | Type | Duration | Start | Finish | Predecessors | Total slack | Free slack | Calendar | ECHEANCE | FIN+NOM |
| --- | --- | --- | --- | --- | --- | --- | --- | --- | --- | --- | --- | --- |
| 465 | 3.4.2.3 | **TDS FM HW design and development** |  | 204.5d | 2014-12-05 | 2015-10-02 |  | 0d |  | Cnes_TDS | NC FM HW design and development | 02/10/15 TDS FM HW design and development |
| 466 | 3.4.2.3.1 | H/W definition and schematics (update) |  | 2w | 2015-01-27 | 2015-02-09 | 464 | 18.5d | 0d | Cnes_TDS | NC H/W definition and schematics (update) | 09/02/15 H/W definition and schematics (update) |
| 467 | 3.4.2.3.2 | PCB layout |  | 3w | 2015-02-10 | 2015-03-02 | 466 | 18.5d | 0d | Cnes_TDS | NC PCB layout | 02/03/15 PCB layout |
| 468 | 3.4.2.3.3 | PCB manufacturing |  | 40d | 2015-03-03 | 2015-04-27 | 467 | 18.5d | 15.5d | Cnes_TDS | NC PCB manufacturing | 27/04/15 PCB manufacturing |
| 469 | 3.4.2.3.4 | MRR preparation (documentation) |  | 3w | 2015-04-22 | 2015-05-13 | 473SF-1w | 0d |  | Cnes_TDS | NC MRR preparation (documentation) | 13/05/15 MRR preparation (documentation) |
| 470 | 3.4.2.3.5 | FPGA ready for assembly | milestone | 0d | 2015-03-06 | 2015-03-06 | 506 | 59.5d | 54.5d | Cnes_TDS | NC FPGA ready for assembly | 06/03/15 FPGA ready for assembly |
| 471 | 3.4.2.3.6 | Parts available for assembly | milestone | 0d | 2014-12-05 | 2014-12-05 | 445 | 109.5d |  | Cnes_TDS | NC Parts available for assembly | 05/12/14 Parts available for assembly |
| 472 | 3.4.2.3.7 | **TDS FM HW design,dev & tests** |  | 95d | 2015-05-20 | 2015-10-02 |  | 0d |  |  | NC TDS FM HW assembly & tests | 02/10/15 TDS FM HW design,dev & tests |
| 473 | 3.4.2.3.7.1 | MRR |  | 2d | 2015-05-20 | 2015-05-22 | 467FS+1w, 1065 | 0d |  | Cnes_TDS | NC MRR | 22/05/15 MRR |
| 474 | 3.4.2.3.7.2 | Parts assembly |  | 5w | 2015-05-22 | 2015-06-26 | 468, 470FS-1w, 471, 473 | 0d |  | Cnes_TDS | NC Parts assembly | 26/06/15 Parts assembly |
| 475 | 3.4.2.3.7.3 | Board delivery | milestone | 0d | 2015-06-29 | 2015-06-29 | 474FS+1d | 0d |  | Cnes_TDS | NC Board delivery | 29/06/15 Board delivery |
| 476 | 3.4.2.3.7.4 | Board testing |  | 3w | 2015-06-30 | 2015-07-21 | 475FS+1d | 0d |  | Cnes_TDS | NC Board testing | 21/07/15 Board testing |
| 477 | 3.4.2.3.7.5 | Need date for mechanical frame | milestone | 0d | 2015-07-21 | 2015-07-21 | 476 | 0d |  | Cnes_TDS | NC Need date for mechanical frame | 21/07/15 Need date for mechanical frame |
| 478 | 3.4.2.3.7.6 | TRR preparation (documentation) |  | 4w | 2015-06-17 | 2015-07-15 | 481SF-2w | 0d |  | Cnes_TDS | NC TRR preparation (documentation) | 15/07/15 TRR preparation (documentation) |
| 479 | 3.4.2.3.7.7 | Boards ready for MIP and TRR |  | 1d | 2015-07-21 | 2015-07-22 | 476 | 0d |  | Cnes_TDS | NC Boards ready for MIP and TRR | 22/07/15 Boards ready for MIP and TRR |
| 480 | 3.4.2.3.7.8 | Integration in mechanical frame |  | 1d | 2015-07-21 | 2015-07-22 | 477 | 0d |  | Cnes_TDS | NC Integration in mechanical frame | 22/07/15 Integration in mechanical frame |
| 481 | 3.4.2.3.7.9 | TRR | milestone | 0d | 2015-07-29 | 2015-07-29 | 479FS+1w | 0d |  | Cnes_TDS | NC TRR | 29/07/15 TRR |
| 482 | 3.4.2.3.7.10 | Board full fonctionnal and performance tests |  | 10d | 2015-07-30 | 2015-08-13 | 481FS+1d | 0d |  | Cnes_TDS | NC Board full fonctionnal and performance tests | 13/08/15 Board full fonctionnal and performance tests |
| 483 | 3.4.2.3.7.11 | Board EMC Tests |  | 5d | 2015-08-13 | 2015-08-20 | 482 | 0d |  | Cnes_TDS | NC Board EMC Tests | 20/08/15 Board EMC Tests |
| 484 | 3.4.2.3.7.12 | Coating |  | 8d | 2015-08-21 | 2015-09-02 | 483FS+1d | 0d |  | Cnes_TDS | NC Coating | 02/09/15 Coating |
| 485 | 3.4.2.3.7.13 | Post-coating tests and characterization |  | 10d | 2015-09-02 | 2015-09-16 | 484 | 0d |  | Cnes_TDS | NC Post-coating tests and characterization | 16/09/15 Post-coating tests and characterization |
| 486 | 3.4.2.3.7.14 | Board thermal tests (if any) |  | 3d | 2015-09-16 | 2015-09-21 | 485 | 0d |  | Cnes_TDS | NC Board thermal tests (if any) | 21/09/15 Board thermal tests (if any) |
| 487 | 3.4.2.3.7.15 | TRB and DRB |  | 2d | 2015-09-28 | 2015-09-30 | 486FS+1w | 0d |  | Cnes_TDS | NC TRB and DRB | 30/09/15 TRB and DRB |
| 488 | 3.4.2.3.7.16 | TDS FM ready for delivery to lesia for AIT MEB |  | 1d | 2015-10-01 | 2015-10-02 | 487FS+1d | 0d |  | Cnes_TDS | NC TDS FM ready for delivery to lesia for AIT MEB | 02/10/15 TDS FM ready for delivery to lesia for AIT MEB |

| ID | WBS | Task | Type | Duration | Start | Finish | Predecessors | Complete | Remaining | Total slack | Free slack | Constraint | Calendar |
| --- | --- | --- | --- | --- | --- | --- | --- | --- | --- | --- | --- | --- | --- |
| 489 | 3.4.3 | **FPGA developments** |  | 150d | 2014-07-17 A | 2015-03-06 |  | 57% | 64.14d | 59.5d |  |  | Cnes_TDS |
| 490 | 3.4.3.1 | **Emx and/or pre-EQM firmware** |  | 32d | 2014-07-17 A | 2014-09-08 A |  | 100% |  |  |  |  | Cnes_TDS |
| 491 | 3.4.3.1.1 | Development of V_0_4_8_0 |  | 20d | 2014-07-17 A | 2014-08-21 A |  | 100% |  |  |  | start no earlier than 2014-07-17 | Cnes_TDS |
| 492 | 3.4.3.1.2 | Final firmware ready for pre-EQM |  | 1d | 2014-08-22 A | 2014-08-22 A | 491 | 100% |  |  |  |  | Cnes_TDS |
| 493 | 3.4.3.1.3 | Replacement of AX2000 socket on pre-EQM with RTAX-PROTO (optional) |  | 10d | 2014-08-26 A | 2014-09-08 A | 492FS+1d | 100% |  |  |  |  | Cnes_TDS |
| 494 | 3.4.3.2 | **EM2 firmware** |  | 33d | 2014-09-01 A | 2014-10-15 A |  | 100% |  |  |  |  | Cnes_TDS |
| 495 | 3.4.3.2.1 | Development of V_0_5_0_0 |  | 30d | 2014-09-01 A | 2014-10-10 A |  | 100% |  |  |  | start no earlier than 2014-09-01 | Cnes_TDS |
| 496 | 3.4.3.2.2 | Final firmware ready for EM2 | milestone | 1d | 2014-10-13 A | 2014-10-13 A | 495 | 100% |  |  |  |  | Cnes_TDS |
| 497 | 3.4.3.2.3 | Programming of RTAX PROTO |  | 1d | 2014-10-15 A | 2014-10-15 A | 496FS+1d | 100% |  |  |  |  | Cnes_TDS |
| 498 | 3.4.3.3 | **FM firmware** |  | 89d | 2014-10-20 A | 2015-03-06 |  | 24% | 67.29d | 59.5d |  |  | Cnes_TDS |
| 499 | 3.4.3.3.1 | Completion of the firmware and tests documentation |  | 2w | 2014-10-20 A | 2014-10-31 A | 453 | 100% |  |  |  |  | Cnes_TDS |
| 500 | 3.4.3.3.2 | Tests result analysis (Cnes / Lesia) |  | 2w | 2014-11-04 A | 2014-11-18 A | 499FS+1d | 100% |  |  |  |  | Cnes_TDS |
| 501 | 3.4.3.3.3 | Validation KP |  | 1d | 2014-11-21 | 2014-11-21 | 500FS+2d |  |  | 59.5d | 0d |  | Cnes_TDS |
| 502 | 3.4.3.3.4 | Complementary tests follow-up analysis |  | 2w | 2014-11-24 | 2014-12-05 | 501 |  |  | 59.5d | 0d |  | Cnes_TDS |
| 503 | 3.4.3.3.5 | GO / NOGO FM FPGA ready for programmation | milestone | 0d | 2014-12-05 | 2014-12-05 | 502 |  |  | 59.5d | 0d |  | Cnes_TDS |
| 504 | 3.4.3.3.6 | FPGA programmation |  | 3w | 2014-12-10 | 2015-01-13 | 503FS+2d |  |  | 59.5d | 0d |  | Cnes_TDS |
| 505 | 3.4.3.3.7 | Electrical test (TCS) |  | 7w | 2015-01-14 | 2015-03-03 | 504 |  |  | 59.5d | 0d |  | Cnes_TDS |
| 506 | 3.4.3.3.8 | Firmware ready for FM assembly |  | 1d | 2015-03-06 | 2015-03-06 | 505FS+2d |  |  | 59.5d | 0d |  | Cnes_TDS |
| 507 | 3.4.4 | **Onboard analyser SW (or boot for DPU) developments** |  | 293d | 2014-06-25 | 2015-09-02 |  |  |  | 0d |  |  | Cnes_TDS |
| 508 | 3.4.4.1 | **R2 software** |  | 65d | 2014-06-25 | 2014-10-02 |  |  |  | 0d |  |  | Cnes_TDS |
| 509 | 3.4.4.1.1 | R2 2.0.0.0 (preliminary) delivered | milestone | 0d | 2014-06-25 | 2014-06-25 |  |  |  | 0d |  | start no earlier than 2014-06-25 | Cnes_TDS |
| 510 | 3.4.4.1.2 | R2 2.0.0.1 (validated) delivery + DRB datapack | milestone | 0d | 2014-07-11 | 2014-07-11 |  |  |  | 0d |  | start no earlier than 2014-07-11 | Cnes_TDS |
| 511 | 3.4.4.1.3 | DRB + CDR R2 |  | 2d | 2014-10-01 | 2014-10-02 |  |  |  | 0d |  | start no earlier than 2014-10-01 | Cnes_TDS |
| 512 | 3.4.4.2 | R3 software |  | 230d | 2014-10-03 | 2015-09-02 | 511 |  |  | 0d |  |  |  |

Notes:
- 489: ECHEANCE: NC FPGA developments / FIN+NOM: 06/03/15 FPGA developments
- 490: ECHEANCE: NC Emx and/or pre-EQM firmware / FIN+NOM: 08/09/14 Emx and/or pre-EQM firmware
- 491: ECHEANCE: NC Development of V_0_4_8_0 / FIN+NOM: 21/08/14 Development of V_0_4_8_0
- 492: ECHEANCE: NC Final firmware ready for pre-EQM / FIN+NOM: 22/08/14 Final firmware ready for pre-EQM
- 493: ECHEANCE: NC Replacement of AX2000 socket on pre-EQM with RTAX-PROTO (optional) / FIN+NOM: 08/09/14 Replacement of AX2000 socket on pre-EQM with RTAX-PROTO (optional)
- 494: FIN+NOM: 15/10/14 EM2 firmware
- 495: ECHEANCE: NC Development of V_0_5_0_0 / FIN+NOM: 10/10/14 Development of V_0_5_0_0
- 496: ECHEANCE: NC Final firmware ready for EM2 / FIN+NOM: 13/10/14 Final firmware ready for EM2
- 497: ECHEANCE: NC Programming of RTAX PROTO / FIN+NOM: 15/10/14 Programming of RTAX PROTO
- 498: ECHEANCE: NC FM firmware / FIN+NOM: 06/03/15 FM firmware
- 499: ECHEANCE: NC Completion of the firmware and tests documentation / FIN+NOM: 31/10/14 Completion of the firmware and tests documentation
- 500: ECHEANCE: NC Tests result analysis (Cnes / Lesia) / FIN+NOM: 18/11/14 Tests result analysis (Cnes / Lesia)
- 501: ECHEANCE: NC Validation KP / FIN+NOM: 21/11/14 Validation KP
- 502: ECHEANCE: NC Complementary tests follow-up analysis / FIN+NOM: 05/12/14 Complementary tests follow-up analysis
- 503: ECHEANCE: NC GO / NOGO FM FPGA ready for programmation / FIN+NOM: 05/12/14 GO / NOGO FM FPGA ready for programmation
- 504: ECHEANCE: NC FPGA programmation / FIN+NOM: 13/01/15 FPGA programmation
- 505: ECHEANCE: NC Electrical test (TCS) / FIN+NOM: 03/03/15 Electrical test (TCS)
- 506: ECHEANCE: NC Firmware ready for FM assembly / FIN+NOM: 06/03/15 Firmware ready for FM assembly
- 507: ECHEANCE: NC Onboard analyser SW (or boot for DPU) developments / FIN+NOM: 02/09/15 Onboard analyser SW (or boot for DPU) developments
- 508: ECHEANCE: NC R2 software / FIN+NOM: 02/10/14 R2 software
- 509: ECHEANCE: NC R2 2.0.0.0 (preliminary) delivered / FIN+NOM: 25/06/14 R2 2.0.0.0 (preliminary) delivered
- 510: ECHEANCE: NC R2 2.0.0.1 (validated) delivery + DRB datapack / FIN+NOM: 11/07/14 R2 2.0.0.1 (validated) delivery + DRB datapack
- 511: ECHEANCE: NC DRB + CDR R2 / FIN+NOM: 02/10/14 DRB + CDR R2
- 512: ECHEANCE: NC R3 software / FIN+NOM: 02/09/15 R3 software

| ID | WBS | Task | Type | Duration | Start | Finish | Predecessors | Complete | Remaining | Baseline start | Baseline finish | Baseline duration | Total slack | Free slack | Constraint | Calendar | OldLg | Texte17 | Ancien Num |
| --- | --- | --- | --- | --- | --- | --- | --- | --- | --- | --- | --- | --- | --- | --- | --- | --- | --- | --- | --- |
| 513 | 3.4.5 | **GSE develompment** |  | 80d | 2014-07-17 | 2014-11-14 |  |  |  |  |  |  | 0d |  |  | Cnes_TDS |  |  |  |
| 514 | 3.4.5.1 | SGSE |  | 4mo | 2014-07-17 | 2014-11-14 |  |  |  |  |  |  | 0d |  | start no earlier than 2014-07-17 | Cnes_TDS |  |  |  |
| 515 | 3.4.5.2 | SGSE |  | 2mo | 2014-07-17 | 2014-09-18 |  |  |  |  |  |  | 0d |  | start no earlier than 2014-07-17 | Cnes_TDS |  |  |  |
| 516 | 3.5 | **LFR** |  | 395d | 2014-04-04 A | 2015-10-30 |  | 29% | 281.22d | 2012-05-11 | 2014-07-29 | 556d | 0d |  |  |  | 282 | 377 | 297 |
| 517 | 3.5.1 | **Parts qualification** |  | 222d | 2014-04-04 A | 2015-03-24 |  | 12% | 195.88d |  |  |  | 58d |  |  | Cnes_LFR |  |  |  |
| 518 | 3.5.1.1 | Flight FPGA package qualification (CQ 352) - Qualif SWA/PAS |  | 80d | 2014-04-04 | 2014-07-31 |  |  |  |  |  |  | 200d |  | start no earlier than 2014-04-04 | Cnes_LFR |  |  |  |
| 519 | 3.5.1.2 | Flight RAM package procurement LPP (CQFP 132) |  | 59d | 2014-09-15 A | 2014-12-05 |  | 51% | 29d |  |  |  | 0d |  | start no earlier than 2014-09-15 | Cnes_LFR |  |  |  |
| 520 | 3.5.1.3 | Purchase for qualification STEEL+ assembly (PCB, stiffner,…) |  | 61d | 2014-09-29 | 2015-01-06 | 519SS+10d |  |  |  |  |  | 4d | 0d |  | Cnes_LFR |  |  |  |
| 521 | 3.5.1.4 | MIP (Cnes) |  | 1d | 2015-01-07 | 2015-01-07 | 520 |  |  |  |  |  | 4d | 0d |  |  |  |  |  |
| 522 | 3.5.1.5 | Integretion finalisation |  | 2d | 2015-01-08 | 2015-01-09 | 521 |  |  |  |  |  | 4d | 0d |  |  |  |  |  |
| 523 | 3.5.1.6 | Flight RAM package qualification (CQFP 132) |  | 36d | 2015-01-12 | 2015-03-02 | 522 |  |  |  |  |  | 4d | 0d |  | Cnes_LFR |  |  |  |
| 524 | 3.5.1.7 | MIP |  | 1d | 2015-03-03 | 2015-03-03 | 523 |  |  |  |  |  | 4d | 0d |  |  |  |  |  |
| 525 | 3.5.1.8 | DPA |  | 15d | 2015-03-04 | 2015-03-24 | 524 |  |  |  |  |  | 4d |  |  |  |  |  |  |
| 526 | 3.5.2 | **Hardware developments** |  | 369d | 2014-04-07 A | 2015-10-30 |  | 37% | 233.78d |  |  |  | 0d |  |  | Cnes_LFR |  |  |  |
| 527 | 3.5.2.1 | **LFR EM2 HW design,dev & tests** |  | 210d | 2014-04-07 A | 2015-03-09 |  | 61% | 82.87d |  |  |  | 0d |  |  | Cnes_LFR |  |  |  |
| 528 | 3.5.2.1.1 | H/W definition and schematics (update) |  | 70d | 2014-04-07 A | 2014-07-18 A |  | 100% |  |  |  |  |  |  | start no earlier than 2014-04-07 | Cnes_LFR |  |  |  |
| 529 | 3.5.2.1.2 | TCS design availability |  | 10d | 2014-09-22 A | 2014-10-03 A | 528 | 100% |  |  |  |  |  |  | start no earlier than 2014-09-22 | Cnes_LFR |  |  |  |
| 530 | 3.5.2.1.3 | Request for modification redaction |  | 5d | 2014-10-06 A | 2014-10-10 A | 529 | 100% |  |  |  |  |  |  |  | Cnes_LFR |  |  |  |
| 531 | 3.5.2.1.4 | PCB layout |  | 48d | 2014-10-13 A | 2014-12-18 | 530 | 42% | 28d |  |  |  | 0d |  |  | Cnes_LFR |  |  |  |
| 532 | 3.5.2.1.5 | MRR |  | 1d | 2014-12-19 | 2014-12-19 | 531 |  |  |  |  |  | 0d |  |  |  |  |  |  |
| 533 | 3.5.2.1.6 | PCB manufacturing |  | 10d | 2014-12-22 | 2015-01-06 | 532 |  |  |  |  |  | 0d |  |  |  |  |  |  |
| 534 | 3.5.2.1.7 | TCS Parts available for assembly |  | 30d | 2014-09-08 A | 2014-10-17 A |  | 100% |  |  |  |  |  |  | start no earlier than 2014-09-08 | Cnes_LFR |  |  |  |
| 535 | 3.5.2.1.8 | Parts available for assembly | milestone | 0d | 2014-10-17 A | 2014-10-17 A | 534 | 100% |  |  |  |  |  |  |  | Cnes_LFR |  |  |  |
| 536 | 3.5.2.1.9 | Mechanical frame available | milestone | 0d | 2015-01-06 | 2015-01-06 | 533FF |  |  |  |  |  | 0d |  |  | Cnes_LFR |  |  |  |
| 537 | 3.5.2.1.10 | Parts assembly& integration in mechanical frame |  | 20d | 2015-01-07 | 2015-02-03 | 536, 535, 533 |  |  |  |  |  | 0d |  |  | Cnes_LFR |  |  |  |
| 538 | 3.5.2.1.11 | FPGA programming with Proto FPGA | milestone | 0d | 2015-02-03 | 2015-02-03 | 537 |  |  |  |  |  | 0d |  |  | Cnes_LFR |  |  |  |
| 539 | 3.5.2.1.12 | Board delivery |  | 1d | 2015-02-04 | 2015-02-04 | 538 |  |  |  |  |  | 0d |  |  | Cnes_LFR |  |  |  |
| 540 | 3.5.2.1.13 | Board testing |  | 5d | 2015-02-05 | 2015-02-11 | 539 |  |  |  |  |  | 0d |  |  | Cnes_LFR |  |  |  |
| 541 | 3.5.2.1.14 | TRR preparation (documentation) |  | 5d | 2015-02-05 | 2015-02-11 | 539 |  |  |  |  |  | 0d |  |  | Cnes_LFR |  |  |  |
| 542 | 3.5.2.1.15 | Boards ready for TRR | milestone | 0d | 2015-02-11 | 2015-02-11 | 541 |  |  |  |  |  | 0d |  |  | Cnes_LFR |  |  |  |
| 543 | 3.5.2.1.16 | TRR |  | 1d | 2015-02-12 | 2015-02-12 | 542 |  |  |  |  |  | 0d |  |  | Cnes_LFR |  |  |  |
| 544 | 3.5.2.1.17 | Board full fonctionnal and performance tests |  | 8d | 2015-02-13 | 2015-02-24 | 543 |  |  |  |  |  | 0d |  |  | Cnes_LFR |  |  |  |
| 545 | 3.5.2.1.18 | TCS Validation |  | 1d | 2015-02-25 | 2015-02-25 | 544 |  |  |  |  |  | 0d |  |  |  |  |  |  |
| 546 | 3.5.2.1.19 | Board EMC Tests |  | 4d | 2015-02-26 | 2015-03-03 | 545 |  |  |  |  |  | 0d |  |  | Cnes_LFR |  |  |  |
| 547 | 3.5.2.1.20 | TRB Preparation |  | 3d | 2015-03-04 | 2015-03-06 | 546 |  |  |  |  |  | 0d |  |  | Cnes_LFR |  |  |  |
| 548 | 3.5.2.1.21 | TRB and DRB |  | 1d | 2015-03-09 | 2015-03-09 | 547 |  |  |  |  |  | 0d |  |  | Cnes_LFR |  |  |  |
| 549 | 3.5.2.1.22 | LFR EM2 ready for delivery to lesia for AIT MEB | milestone | 0d | 2015-03-09 | 2015-03-09 | 548 |  |  |  |  |  | 0d |  |  | Cnes_LFR |  |  |  |
| 550 | 3.5.2.1.23 | LFR EM2 for AIT MEB | milestone | 0d | 2015-03-09 | 2015-03-09 | 548 |  |  |  |  |  | 0d |  |  | Cnes_LFR |  |  |  |

Notes:
- 513: ECHEANCE: NC GSE develompment / FIN+NOM: 14/11/14 GSE develompment
- 514: ECHEANCE: NC SGSE / FIN+NOM: 14/11/14 SGSE
- 515: ECHEANCE: NC SGSE / FIN+NOM: 18/09/14 SGSE
- 516: ECHEANCE: NC LFR / FIN+NOM: 30/10/15 LFR
- 517: ECHEANCE: NC Parts qualification / FIN+NOM: 24/03/15 Parts qualification
- 518: Qualification not succesful. Rework in progress. / ECHEANCE: NC Flight FPGA package qualification (CQ 352) - Qualif SWA/PAS / FIN+NOM: 31/07/14 Flight FPGA package qualification (CQ 352) - Qualif SWA/PAS
- 519: ECHEANCE: NC Flight RAM package procurement LPP (CQFP 132) / FIN+NOM: 05/12/14 Flight RAM package procurement LPP (CQFP 132)
- 520: ECHEANCE: NC Purchase for qualification STEEL+ assembly (PCB, stiffner,…) / FIN+NOM: 06/01/15 Purchase for qualification STEEL+ assembly (PCB, stiffner,…)
- 521: ECHEANCE: NC MIP (Cnes) / FIN+NOM: 07/01/15 MIP (Cnes)
- 522: ECHEANCE: NC Integretion finalisation / FIN+NOM: 09/01/15 Integretion finalisation
- 523: ECHEANCE: NC Flight RAM package qualification (CQFP 132) / FIN+NOM: 02/03/15 Flight RAM package qualification (CQFP 132)
- 524: ECHEANCE: NC MIP / FIN+NOM: 03/03/15 MIP
- 525: ECHEANCE: NC DPA / FIN+NOM: 24/03/15 DPA
- 526: ECHEANCE: NC Hardware developments / FIN+NOM: 30/10/15 Hardware developments
- 527: ECHEANCE: NC EQMx HW design and development / FIN+NOM: 09/03/15 LFR EM2 HW design,dev & tests
- 528: ECHEANCE: NC H/W definition and schematics (update) / FIN+NOM: 18/07/14 H/W definition and schematics (update)
- 529: Date SCM / ECHEANCE: NC TCS design availability / FIN+NOM: 03/10/14 TCS design availability
- 530: ECHEANCE: NC Request for modification redaction / FIN+NOM: 10/10/14 Request for modification redaction
- 531: ECHEANCE: NC PCB layout / FIN+NOM: 18/12/14 PCB layout
- 532: ECHEANCE: NC MRR / FIN+NOM: 19/12/14 MRR
- 533: ECHEANCE: NC PCB manufacturing / FIN+NOM: 06/01/15 PCB manufacturing
- 534: opto coupleur EQM à recuperer de LVPS-PDU ou appro spécifique / ECHEANCE: NC TCS Parts available for assembly / FIN+NOM: 17/10/14 TCS Parts available for assembly
- 535: ECHEANCE: NC Parts available for assembly / FIN+NOM: 17/10/14 Parts available for assembly
- 536: ECHEANCE: NC Mechanical frame available / FIN+NOM: 06/01/15 Mechanical frame available
- 537: ECHEANCE: NC Parts assembly& integration in mechanical frame / FIN+NOM: 03/02/15 Parts assembly& integration in mechanical frame
- 538: ECHEANCE: NC FPGA programming with Proto FPGA / FIN+NOM: 03/02/15 FPGA programming with Proto FPGA
- 539: ECHEANCE: NC Board delivery / FIN+NOM: 04/02/15 Board delivery
- 540: ECHEANCE: NC Board testing / FIN+NOM: 11/02/15 Board testing
- 541: ECHEANCE: NC TRR preparation (documentation) / FIN+NOM: 11/02/15 TRR preparation (documentation)
- 542: ECHEANCE: NC Boards ready for TRR / FIN+NOM: 11/02/15 Boards ready for TRR
- 543: ECHEANCE: NC TRR / FIN+NOM: 12/02/15 TRR
- 544: ECHEANCE: NC Board full fonctionnal and performance tests / FIN+NOM: 24/02/15 Board full fonctionnal and performance tests
- 545: ECHEANCE: NC TCS Validation / FIN+NOM: 25/02/15 TCS Validation
- 546: ECHEANCE: NC Board EMC Tests / FIN+NOM: 03/03/15 Board EMC Tests
- 547: ECHEANCE: NC TRB Preparation / FIN+NOM: 06/03/15 TRB Preparation
- 548: ECHEANCE: NC TRB and DRB / FIN+NOM: 09/03/15 TRB and DRB
- 549: ECHEANCE: NC LFR EM2 ready for delivery to lesia for AIT MEB / FIN+NOM: 09/03/15 LFR EM2 ready for delivery to lesia for AIT MEB
- 550: ECHEANCE: NC LFR EM2 for AIT MEB / FIN+NOM: 09/03/15 LFR EM2 for AIT MEB

| ID | WBS | Task | Type | Duration | Start | Finish | Predecessors | Complete | Remaining | Total slack | Free slack | Constraint | Calendar |
| --- | --- | --- | --- | --- | --- | --- | --- | --- | --- | --- | --- | --- | --- |
| 551 | 3.5.2.2 | **LFR FM HW design and development** |  | 306d | 2014-07-09 A | 2015-10-30 |  | 22% | 239.04d | 0d |  |  | Cnes_LFR |
| 552 | 3.5.2.2.1 | H/W definition and schematics (update) |  | 15d | 2015-03-10 | 2015-03-30 | 548 |  |  | 0d |  |  | Cnes_LFR |
| 553 | 3.5.2.2.2 | PCB layout |  | 10d | 2015-03-31 | 2015-04-13 | 552, 1016, 525 |  |  | 0d |  |  | Cnes_LFR |
| 554 | 3.5.2.2.3 | KP PCB layout | milestone | 0d | 2015-04-13 | 2015-04-13 | 553 |  |  | 0d |  |  |  |
| 555 | 3.5.2.2.4 | PCB manufacturing |  | 40d | 2015-04-14 | 2015-06-12 | 553 |  |  | 0d |  |  |  |
| 556 | 3.5.2.2.5 | TCS Parts procurement |  | 205d | 2014-07-09 A | 2015-05-28 |  | 39% | 126d | 11d | 0d | start no earlier than 2014-07-09 | Cnes_LFR |
| 557 | 3.5.2.2.6 | LFR FM Parts available for assembly | milestone | 0d | 2015-05-28 | 2015-05-28 | 556 |  |  | 11d |  |  | Cnes_LFR |
| 558 | 3.5.2.2.7 | Mechanical frame availibity | milestone | 0d | 2015-04-20 | 2015-04-20 | 260 |  |  | 39d | 35d |  | Cnes_LFR |
| 559 | 3.5.2.2.8 | MRR preparation (documentation) |  | 1d | 2015-04-14 | 2015-04-14 | 553 |  |  | 0d |  |  | Cnes_LFR |
| 560 | 3.5.2.2.9 | **LFR FM HW design,dev & tests** |  | 99d | 2015-06-15 | 2015-10-30 |  |  |  | 0d |  |  |  |
| 561 | 3.5.2.2.9.1 | MRR |  | 1d | 2015-06-15 | 2015-06-15 | 523, 518, 558, 555, 1065, 557 |  |  | 0d |  |  | Cnes_LFR |
| 562 | 3.5.2.2.9.2 | Parts assembly and Integration in mechanical frame |  | 32d | 2015-06-16 | 2015-07-29 | 561 |  |  | 0d |  |  | Cnes_LFR |
| 563 | 3.5.2.2.9.3 | LFR FM FPGA validation in the dedicated socket (at STEEL) | milestone | 1d | 2015-07-30 | 2015-07-30 | 562 |  |  | 0d |  |  | Cnes_LFR |
| 564 | 3.5.2.2.9.4 | FPGA soldering |  | 5d | 2015-07-31 | 2015-08-20 | 563 |  |  | 0d |  |  | Cnes_LFR |
| 565 | 3.5.2.2.9.5 | Final validation by STEEL/LPP |  | 1d | 2015-08-21 | 2015-08-21 | 564 |  |  | 0d |  |  |  |
| 566 | 3.5.2.2.9.6 | TRR preparation (documentation) | milestone | 0d | 2015-08-21 | 2015-08-21 | 565 |  |  | 0d |  |  | Cnes_LFR |
| 567 | 3.5.2.2.9.7 | Boards ready for TRR | milestone | 0d | 2015-08-21 | 2015-08-21 | 565 |  |  | 0d |  |  | Cnes_LFR |
| 568 | 3.5.2.2.9.8 | TRR |  | 1d | 2015-08-24 | 2015-08-24 | 567 |  |  | 0d |  |  | Cnes_LFR |
| 569 | 3.5.2.2.9.9 | Board full fonctionnal and performance tests |  | 10d | 2015-08-25 | 2015-09-07 | 568 |  |  | 0d |  |  | Cnes_LFR |
| 570 | 3.5.2.2.9.10 | Calibration |  | 10d | 2015-09-08 | 2015-09-21 | 569 |  |  | 0d |  |  | Cnes_LFR |
| 571 | 3.5.2.2.9.11 | Board EMC Tests |  | 5d | 2015-09-22 | 2015-09-28 | 570 |  |  | 0d |  |  | Cnes_LFR |
| 572 | 3.5.2.2.9.12 | Board back to STEEL |  | 2d | 2015-09-29 | 2015-09-30 | 571 |  |  | 0d |  |  | Cnes_LFR |
| 573 | 3.5.2.2.9.13 | MIP |  | 1d | 2015-10-01 | 2015-10-01 | 572 |  |  | 0d |  |  | Cnes_LFR |
| 574 | 3.5.2.2.9.14 | Coating & Final mechanical integretion |  | 6d | 2015-10-02 | 2015-10-09 | 573 |  |  | 0d |  |  | Cnes_LFR |
| 575 | 3.5.2.2.9.15 | Delivery to LPP |  | 1d | 2015-10-12 | 2015-10-12 | 574 |  |  | 0d |  |  | Cnes_LFR |
| 576 | 3.5.2.2.9.16 | Post-coating tests and characterization |  | 5d | 2015-10-13 | 2015-10-19 | 575 |  |  | 0d |  |  | Cnes_LFR |
| 577 | 3.5.2.2.9.17 | Final delivery to LPP | milestone | 0d | 2015-10-19 | 2015-10-19 | 576 |  |  | 0d |  |  | Cnes_LFR |
| 578 | 3.5.2.2.9.18 | Board thermal tests (if any) |  | 3d | 2015-10-20 | 2015-10-22 | 577 |  |  | 0d |  |  | Cnes_LFR |
| 579 | 3.5.2.2.9.19 | TRB/DRB preparation (datapackage) |  | 5d | 2015-10-23 | 2015-10-29 | 578 |  |  | 0d |  |  |  |
| 580 | 3.5.2.2.9.20 | TRB and DRB |  | 1d | 2015-10-30 | 2015-10-30 | 579 |  |  | 0d |  |  | Cnes_LFR |
| 581 | 3.5.2.2.9.21 | LFR FM ready for delivery to lesia for AIT MEB | milestone | 0d | 2015-10-30 | 2015-10-30 | 580 |  |  | 0d |  |  | Cnes_LFR |

Notes:
- 551: ECHEANCE: NC FM HW design and development / FIN+NOM: 30/10/15 LFR FM HW design and development
- 552: ECHEANCE: NC H/W definition and schematics (update) / FIN+NOM: 30/03/15 H/W definition and schematics (update)
- 553: ECHEANCE: NC PCB layout / FIN+NOM: 13/04/15 PCB layout
- 554: ECHEANCE: NC KP PCB layout / FIN+NOM: 13/04/15 KP PCB layout
- 555: ECHEANCE: NC PCB manufacturing / FIN+NOM: 12/06/15 PCB manufacturing
- 556: ECHEANCE: NC TCS Parts procurement / FIN+NOM: 28/05/15 TCS Parts procurement
- 557: ECHEANCE: NC LFR FM Parts available for assembly / FIN+NOM: 28/05/15 LFR FM Parts available for assembly
- 558: ECHEANCE: NC Mechanical frame availibity / FIN+NOM: 20/04/15 Mechanical frame availibity
- 559: ECHEANCE: NC MRR preparation (documentation) / FIN+NOM: 14/04/15 MRR preparation (documentation)
- 560: ECHEANCE: NC LFR FM HW assembly & tests / FIN+NOM: 30/10/15 LFR FM HW design,dev & tests
- 561: ECHEANCE: NC MRR / FIN+NOM: 15/06/15 MRR
- 562: ECHEANCE: NC Parts assembly and Integration in mechanical frame / FIN+NOM: 29/07/15 Parts assembly and Integration in mechanical frame
- 563: ECHEANCE: NC LFR FM FPGA validation in the dedicated socket (at STEEL) / FIN+NOM: 30/07/15 LFR FM FPGA validation in the dedicated socket (at STEEL)
- 564: ECHEANCE: NC FPGA soldering / FIN+NOM: 20/08/15 FPGA soldering
- 565: ECHEANCE: NC Final validation by STEEL/LPP / FIN+NOM: 21/08/15 Final validation by STEEL/LPP
- 566: ECHEANCE: NC TRR preparation (documentation) / FIN+NOM: 21/08/15 TRR preparation (documentation)
- 567: ECHEANCE: NC Boards ready for TRR / FIN+NOM: 21/08/15 Boards ready for TRR
- 568: ECHEANCE: NC TRR / FIN+NOM: 24/08/15 TRR
- 569: ECHEANCE: NC Board full fonctionnal and performance tests / FIN+NOM: 07/09/15 Board full fonctionnal and performance tests
- 570: ECHEANCE: NC Calibration / FIN+NOM: 21/09/15 Calibration
- 571: ECHEANCE: NC Board EMC Tests / FIN+NOM: 28/09/15 Board EMC Tests
- 572: ECHEANCE: NC Board back to STEEL / FIN+NOM: 30/09/15 Board back to STEEL
- 573: ECHEANCE: NC MIP / FIN+NOM: 01/10/15 MIP
- 574: ECHEANCE: NC Coating & Final mechanical integretion / FIN+NOM: 09/10/15 Coating & Final mechanical integretion
- 575: ECHEANCE: NC Delivery to LPP / FIN+NOM: 12/10/15 Delivery to LPP
- 576: ECHEANCE: NC Post-coating tests and characterization / FIN+NOM: 19/10/15 Post-coating tests and characterization
- 577: ECHEANCE: NC Final delivery to LPP / FIN+NOM: 19/10/15 Final delivery to LPP
- 578: ECHEANCE: NC Board thermal tests (if any) / FIN+NOM: 22/10/15 Board thermal tests (if any)
- 579: ECHEANCE: NC TRB/DRB preparation (datapackage) / FIN+NOM: 29/10/15 TRB/DRB preparation (datapackage)
- 580: ECHEANCE: NC TRB and DRB / FIN+NOM: 30/10/15 TRB and DRB
- 581: ECHEANCE: NC LFR FM ready for delivery to lesia for AIT MEB / FIN+NOM: 30/10/15 LFR FM ready for delivery to lesia for AIT MEB

| ID | WBS | Task | Type | Duration | Start | Finish | Predecessors | Complete | Remaining | Total slack | Constraint | Calendar | ECHEANCE |
| --- | --- | --- | --- | --- | --- | --- | --- | --- | --- | --- | --- | --- | --- |
| 582 | 3.5.3 | **FPGA developments** |  | 157d | 2014-07-25 A | 2015-04-07 |  | 45% | 86.07d | 0d |  | Cnes_LFR |  |
| 583 | 3.5.3.1 | **EM2 firmware** |  | 90d | 2014-07-25 A | 2014-12-19 |  | 72% | 25.27d | 0d |  | Cnes_LFR |  |
| 584 | 3.5.3.1.1 | VHDL: waveform picker refinement |  | 83d | 2014-08-25 A | 2014-12-18 |  | 78% | 18d | 0d | start no earlier than 2014-08-25 | Cnes_LFR | NC VHDL: waveform picker refinement |
| 585 | 3.5.3.1.2 | **flight RAM evaluation board** |  | 24d | 2014-07-25 A | 2014-09-17 |  | 47% | 12.63d | 0d |  | Cnes_LFR |  |
| 586 | 3.5.3.1.2.1 | PCB design and manufacturing |  | 20d | 2014-07-25 | 2014-08-22 |  |  |  | 0d | start no earlier than 2014-07-25 |  | NC PCB design and manufacturing |
| 587 | 3.5.3.1.2.2 | flight RAM bending and cutting |  | 13d | 2014-08-25 A | 2014-09-10 A |  | 100% |  |  | start no earlier than 2014-08-25 | Cnes_LFR | NC flight RAM bending and cutting |
| 588 | 3.5.3.1.2.3 | Board population |  | 5d | 2014-09-11 A | 2014-09-17 A | 586, 587 | 100% |  |  |  | Cnes_LFR | NC Board population |
| 589 | 3.5.3.1.3 | VHDL: flight RAM memory controler |  | 66d | 2014-09-18 A | 2014-12-19 | 588 | 71% | 19d | 0d |  | Cnes_LFR | NC VHDL: flight RAM memory controler |
| 590 | 3.5.3.1.4 | Documentation |  | 16d | 2014-09-15 A | 2014-10-06 A | 584 | 100% |  |  | start no earlier than 2012-01-05 | Cnes_LFR | NC Documentation |
| 591 | 3.5.3.2 | **FM firmware** |  | 121d | 2014-10-06 A | 2015-04-07 |  | 17% | 100.73d | 0d |  | Cnes_LFR |  |
| 592 | 3.5.3.2.1 | VHDL: downsampling filter, all frequencies |  | 60d | 2014-10-06 A | 2015-01-12 |  | 53% | 28d | 0d |  | Cnes_LFR | NC VHDL: downsampling filter, all frequencies |
| 593 | 3.5.3.2.2 | VHDL: SCM calibration |  | 20d | 2015-01-13 | 2015-02-09 | 592 |  |  | 0d |  | Cnes_LFR | NC VHDL: SCM calibration |
| 594 | 3.5.3.2.3 | VHDL: housekeeping |  | 20d | 2015-01-13 | 2015-02-09 | 592 |  |  | 0d |  | Cnes_LFR | NC VHDL: housekeeping |
| 595 | 3.5.3.2.4 | Completion of the firmware and tests documentation |  | 20d | 2015-02-10 | 2015-03-09 | 594 |  |  | 0d |  | Cnes_LFR | NC Completion of the firmware and tests documentation |
| 596 | 3.5.3.2.5 | Tests result analysis (Cnes / Lesia) |  | 5d | 2015-03-10 | 2015-03-16 | 595 |  |  | 0d |  | Cnes_LFR | NC Tests result analysis (Cnes / Lesia) |
| 597 | 3.5.3.2.6 | Validation KP |  | 1d | 2015-03-17 | 2015-03-17 | 596 |  |  | 0d |  | Cnes_LFR | NC Validation KP |
| 598 | 3.5.3.2.7 | Complementary tests follow-up analysis |  | 5d | 2015-03-18 | 2015-03-24 | 597 |  |  | 0d |  | Cnes_LFR | NC Complementary tests follow-up analysis |
| 599 | 3.5.3.2.8 | GO / NOGO FM FPGA ready for programmation | milestone | 0d | 2015-03-24 | 2015-03-24 | 598 |  |  | 0d |  | Cnes_LFR | NC GO / NOGO FM FPGA ready for programmation |
| 600 | 3.5.3.2.9 | **PPBI** |  | 60d | 2015-01-14 | 2015-04-07 |  |  |  | 0d |  | Cnes_LFR |  |
| 601 | 3.5.3.2.9.1 | PPBI: NRE |  | 50d | 2015-01-14 | 2015-03-24 | 599FF |  |  | 0d |  | Cnes_LFR | NC PPBI: NRE |
| 602 | 3.5.3.2.9.2 | FPGA programmation |  | 1d | 2015-03-25 | 2015-03-25 | 599 |  |  | 0d |  | Cnes_LFR | NC FPGA programmation |
| 603 | 3.5.3.2.9.3 | PPBI: electrical tests |  | 9d | 2015-03-26 | 2015-04-07 | 602 |  |  | 0d |  | Cnes_LFR | NC PPBI: electrical tests |
| 604 | 3.5.3.2.10 | Firmware ready for FM assembly | milestone | 0d | 2015-04-07 | 2015-04-07 | 603 |  |  | 0d |  | Cnes_LFR | NC Firmware ready for FM assembly |
| 605 | 3.5.4 | **Onboard analyser SW developments** |  | 220d | 2014-10-01 | 2015-09-02 |  |  |  | 0d |  | Cnes_LFR |  |
| 606 | 3.5.4.1 | R2 DRB/CDR |  | 2d | 2014-10-01 | 2014-10-02 |  |  |  | 0d | start no earlier than 2014-10-01 | Cnes_LFR | NC R2 DRB/CDR |
| 607 | 3.5.4.2 | R3 software |  | 230d | 2014-10-03 | 2015-09-02 | 606 |  |  | 0d |  |  | NC R3 software |

Notes:
- 582: FIN+NOM: 07/04/15 FPGA developments
- 583: FIN+NOM: 19/12/14 EM2 firmware
- 584: FIN+NOM: 18/12/14 VHDL: waveform picker refinement
- 585: FIN+NOM: 17/09/14 flight RAM evaluation board
- 586: FIN+NOM: 22/08/14 PCB design and manufacturing
- 587: FIN+NOM: 10/09/14 flight RAM bending and cutting
- 588: FIN+NOM: 17/09/14 Board population
- 589: FIN+NOM: 19/12/14 VHDL: flight RAM memory controler
- 590: FIN+NOM: 06/10/14 Documentation
- 591: FIN+NOM: 07/04/15 FM firmware
- 592: FIN+NOM: 12/01/15 VHDL: downsampling filter, all frequencies
- 593: FIN+NOM: 09/02/15 VHDL: SCM calibration
- 594: FIN+NOM: 09/02/15 VHDL: housekeeping
- 595: FIN+NOM: 09/03/15 Completion of the firmware and tests documentation
- 596: FIN+NOM: 16/03/15 Tests result analysis (Cnes / Lesia)
- 597: FIN+NOM: 17/03/15 Validation KP
- 598: FIN+NOM: 24/03/15 Complementary tests follow-up analysis
- 599: FIN+NOM: 24/03/15 GO / NOGO FM FPGA ready for programmation
- 600: FIN+NOM: 07/04/15 PPBI
- 601: FIN+NOM: 24/03/15 PPBI: NRE
- 602: FIN+NOM: 25/03/15 FPGA programmation
- 603: FIN+NOM: 07/04/15 PPBI: electrical tests
- 604: FIN+NOM: 07/04/15 Firmware ready for FM assembly
- 605: FIN+NOM: 02/09/15 Onboard analyser SW developments
- 606: FIN+NOM: 02/10/14 R2 DRB/CDR
- 607: FIN+NOM: 02/09/15 R3 software

| ID | WBS | Task | Type | Duration | Start | Finish | Predecessors | Baseline start | Baseline finish | Baseline duration | Total slack | Free slack | Constraint | Calendar | OldLg | Texte17 | Ancien Num | FIN+NOM | ECHEANCE |
| --- | --- | --- | --- | --- | --- | --- | --- | --- | --- | --- | --- | --- | --- | --- | --- | --- | --- | --- | --- |
| 608 | 3.6 | **TNR/HFR** |  | 304.5d | 2014-06-30 | 2015-10-29 |  | 2012-06-11 | 2014-07-29 | 537d | 0d |  |  | Cnes_TNR_HFR | 298 | 399 | 313 | 29/10/15 TNR/HFR |  |
| 609 | 3.6.1 | **Parts procurement** |  | 1d | 2015-01-22 | 2015-01-22 |  |  |  |  | 87.5d |  |  | Cnes_TNR_HFR |  |  |  | 22/01/15 Parts procurement | NC Parts procurement |
| 610 | 3.6.1.1 | PFM LLI |  | 1d | 2015-01-22 | 2015-01-22 |  |  |  |  | 84.5d |  | start no earlier than 2015-01-22 |  |  |  |  | 22/01/15 PFM LLI | NC PFM LLI |
| 611 | 3.6.2 | **Assembly qualification** |  | 95d | 2014-12-08 | 2015-05-04 |  |  |  |  | 36.5d |  |  | Cnes_TNR_HFR |  |  |  | 04/05/15 Assembly qualification | NC Assembly qualification |
| 612 | 3.6.2.1 | Assembly qualification plan for FPGA |  | 10d | 2014-12-08 | 2014-12-19 |  |  |  |  | 36.5d | 8d | start no earlier than 2014-12-08 | Cnes_TNR_HFR |  |  |  | 19/12/14 Assembly qualification plan for FPGA | NC Assembly qualification plan for FPGA |
| 613 | 3.6.2.2 | Cnes approval |  | 5d | 2015-01-05 | 2015-01-09 | 612 |  |  |  | 36.5d | 0d |  | Cnes_TNR_HFR |  |  |  | 09/01/15 Cnes approval | NC Cnes approval |
| 614 | 3.6.2.3 | Assembly qualification for FPGA |  | 80d | 2015-01-12 | 2015-05-04 | 613 |  |  |  | 36.5d | 34.5d |  | Cnes_TNR_HFR |  |  |  | 04/05/15 Assembly qualification for FPGA | NC Assembly qualification for FPGA |
| 615 | 3.6.3 | **Hardware developments** |  | 275.5d | 2014-09-01 | 2015-10-29 |  |  |  |  | 0d |  |  | Cnes_TNR_HFR |  |  |  | 29/10/15 Hardware developments | NC Hardware developments |
| 616 | 3.6.3.1 | **TNR/HFR EM2 HW design,dev & tests** |  | 118d | 2014-09-01 | 2015-02-26 |  |  |  |  | 1d |  |  | Cnes_TNR_HFR |  |  |  | 26/02/15 TNR/HFR EM2 HW design,dev & tests |  |
| 617 | 3.6.3.1.1 | Design updates |  | 20d | 2014-09-01 | 2014-09-26 |  |  |  |  | 1d | 0d | start no earlier than 2014-09-01 | Cnes_TNR_HFR |  |  |  | 26/09/14 Design updates | NC Design updates |
| 618 | 3.6.3.1.2 | MRR preparation |  | 4d | 2014-09-29 | 2014-10-02 | 617 |  |  |  | 1d | 0d |  | Cnes_TNR_HFR |  |  |  | 02/10/14 MRR preparation | NC MRR preparation |
| 619 | 3.6.3.1.3 | MRR | milestone | 1d | 2014-10-03 | 2014-10-03 | 618 |  |  |  | 1d | 0d |  | Cnes_TNR_HFR |  |  |  | 03/10/14 MRR | NC MRR |
| 620 | 3.6.3.1.4 | Complementary design update |  | 49d | 2014-10-06 | 2014-12-12 | 619 |  |  |  | 1d | 0d |  | Cnes_TNR_HFR |  |  |  | 12/12/14 Complementary design update | NC Complementary design update |
| 621 | 3.6.3.1.5 | Complementary MRR |  | 1d | 2014-12-15 | 2014-12-15 | 620 |  |  |  | 1d | 0d |  | Cnes_TNR_HFR |  |  |  | 15/12/14 Complementary MRR | NC Complementary MRR |
| 622 | 3.6.3.1.6 | Manufacturing preparation |  | 2d | 2014-12-12 | 2014-12-15 | 621FS-2d |  |  |  | 1d | 0d |  | Cnes_TNR_HFR |  |  |  | 15/12/14 Manufacturing preparation | NC Manufacturing preparation |
| 623 | 3.6.3.1.7 | PCB 1 manufacturing |  | 5d | 2014-12-16 | 2015-01-05 | 622 |  |  |  | 1d | 0d |  | Cnes_TNR_HFR |  |  |  | 05/01/15 PCB 1 manufacturing | NC PCB 1 manufacturing |
| 624 | 3.6.3.1.8 | Parts assembly (PCB1) |  | 15d | 2015-01-06 | 2015-01-26 | 623 |  |  |  | 1d | 0d |  | Cnes_TNR_HFR |  |  |  | 26/01/15 Parts assembly (PCB1) | NC Parts assembly (PCB1) |
| 625 | 3.6.3.1.9 | Electrical tests (PCB1) |  | 3d | 2015-01-27 | 2015-01-29 | 624 |  |  |  | 1d | 0d |  | Cnes_TNR_HFR |  |  |  | 29/01/15 Electrical tests (PCB1) | NC Electrical tests (PCB1) |
| 626 | 3.6.3.1.10 | PCB 2 manufacturing |  | 10d | 2014-10-06 | 2014-10-17 | 619 |  |  |  | 31d |  |  | Cnes_TNR_HFR |  |  |  | 17/10/14 PCB 2 manufacturing | NC PCB 2 manufacturing |
| 627 | 3.6.3.1.11 | Parts delivery to RESA (PCB2) |  | 1d | 2014-12-03 | 2014-12-03 | 626 |  |  |  | 0d |  | start no earlier than 2014-12-03 |  |  |  |  | 03/12/14 Parts delivery to RESA (PCB2) | NC Parts delivery to RESA (PCB2) |
| 628 | 3.6.3.1.12 | Parts assembly PCB2 |  | 14d | 2014-12-04 | 2015-01-06 | 627 |  |  |  | 0d |  |  | Cnes_TNR_HFR |  |  |  | 06/01/15 Parts assembly PCB2 | NC Parts assembly PCB2 |
| 629 | 3.6.3.1.13 | FPGA assembly |  | 5d | 2015-01-07 | 2015-01-13 | 628, 663 |  |  |  | 0d |  |  | Cnes_TNR_HFR |  |  |  | 13/01/15 FPGA assembly | NC FPGA assembly |
| 630 | 3.6.3.1.14 | Electrical tests (PCB2) |  | 2d | 2015-01-14 | 2015-01-15 | 629 |  |  |  | 0d |  |  | Cnes_TNR_HFR |  |  |  | 15/01/15 Electrical tests (PCB2) | NC Electrical tests (PCB2) |
| 631 | 3.6.3.1.15 | TRR preparation |  | 9d | 2015-01-16 | 2015-01-28 | 630 |  |  |  | 0d |  |  | Cnes_TNR_HFR |  |  |  | 28/01/15 TRR preparation | NC TRR preparation |
| 632 | 3.6.3.1.16 | TRR | milestone | 1d | 2015-01-29 | 2015-01-29 | 631 |  |  |  | 0d |  |  | Cnes_TNR_HFR |  |  |  | 29/01/15 TRR | NC TRR |
| 633 | 3.6.3.1.17 | Functionl validation tests PCB |  | 10d | 2015-01-30 | 2015-02-12 | 630, 625 |  |  |  | 1d | 0d |  | Cnes_TNR_HFR |  |  |  | 12/02/15 Functionl validation tests PCB | NC Functionl validation tests PCB |
| 634 | 3.6.3.1.18 | EMC tests at board level |  | 5d | 2015-02-13 | 2015-02-19 | 633 |  |  |  | 1d | 0d |  | Cnes_TNR_HFR |  |  |  | 19/02/15 EMC tests at board level | NC EMC tests at board level |
| 635 | 3.6.3.1.19 | TRB/DRB preparation |  | 4d | 2015-02-20 | 2015-02-25 | 634 |  |  |  | 1d | 0d |  | Cnes_TNR_HFR |  |  |  | 25/02/15 TRB/DRB preparation | NC TRB/DRB preparation |
| 636 | 3.6.3.1.20 | TNR-HFR EM2 TRB/DRB | milestone | 1d | 2015-02-26 | 2015-02-26 | 635 |  |  |  | 1d | 0d |  | Cnes_TNR_HFR |  |  |  | 26/02/15 TNR-HFR EM2 TRB/DRB | NC TNR-HFR EM2 TRB/DRB |

| ID | WBS | Task | Duration | Start | Finish | Predecessors | Total slack | Free slack | Calendar | ECHEANCE | FIN+NOM |
| --- | --- | --- | --- | --- | --- | --- | --- | --- | --- | --- | --- |
| 637 | 3.6.3.2 | **TNR/HFR PFM HW design and development** | 157.5d | 2015-02-27 | 2015-10-29 |  | 0d |  | Cnes_TNR_HFR | NC FM HW design | 29/10/15 TNR/HFR PFM HW design and development |
| 638 | 3.6.3.2.1 | Design updates | 15d | 2015-02-27 | 2015-03-19 | 636 | 7.5d | 0d | Cnes_TNR_HFR | NC Design updates | 19/03/15 Design updates |
| 639 | 3.6.3.2.2 | PCB 1 manufacturing | 40d | 2015-03-20 | 2015-05-18 | 638 | 7.5d | 6.5d | Cnes_TNR_HFR | NC PCB 1 manufacturing | 18/05/15 PCB 1 manufacturing |
| 640 | 3.6.3.2.3 | PCB 2 manufacturing | 40d | 2015-03-20 | 2015-05-18 | 638 | 7.5d | 6.5d | Cnes_TNR_HFR | NC PCB 2 manufacturing | 18/05/15 PCB 2 manufacturing |
| 641 | 3.6.3.2.4 | MRR preparation | 4d | 2015-03-20 | 2015-03-25 | 638 | 37.5d | 35.5d | Cnes_TNR_HFR | NC MRR preparation | 25/03/15 MRR preparation |
| 642 | 3.6.3.2.5 | **TNR/HFR FM HW design,dev & tests** | 114d | 2015-05-20 | 2015-10-29 |  | 0d |  |  | NC TNR/HFR FM HW assembly & tests | 29/10/15 TNR/HFR FM HW design,dev & tests |
| 643 | 3.6.3.2.5.1 | MRR | 1d | 2015-05-20 | 2015-05-21 | 641, 1065 | 0d |  | Cnes_TNR_HFR | NC MRR | 21/05/15 MRR |
| 644 | 3.6.3.2.5.2 | Manufacturing preparation | 5d | 2015-05-21 | 2015-05-28 | 643 | 0d |  | Cnes_TNR_HFR | NC Manufacturing preparation | 28/05/15 Manufacturing preparation |
| 645 | 3.6.3.2.5.3 | Parts assembly (PCB1) | 25d | 2015-05-28 | 2015-07-02 | 639, 610, 644 | 0d |  | Cnes_TNR_HFR | NC Parts assembly (PCB1) | 02/07/15 Parts assembly (PCB1) |
| 646 | 3.6.3.2.5.4 | Parts assembly (PCB2) | 20d | 2015-05-28 | 2015-06-25 | 640, 644, 610 | 0d |  | Cnes_TNR_HFR | NC Parts assembly (PCB2) | 25/06/15 Parts assembly (PCB2) |
| 647 | 3.6.3.2.5.5 | FPGA assembly | 5d | 2015-06-25 | 2015-07-02 | 646, 614, 670 | 0d |  | Cnes_TNR_HFR | NC FPGA assembly | 02/07/15 FPGA assembly |
| 648 | 3.6.3.2.5.6 | Electrical tests | 4d | 2015-07-02 | 2015-07-08 | 647, 645, 646 | 0d |  | Cnes_TNR_HFR | NC Electrical tests | 08/07/15 Electrical tests |
| 649 | 3.6.3.2.5.7 | Boards installation in the frame | 1d | 2015-07-08 | 2015-07-09 | 648 | 0d |  | Cnes_TNR_HFR | NC Boards installation in the frame | 09/07/15 Boards installation in the frame |
| 650 | 3.6.3.2.5.8 | TRR preparation | 4d | 2015-07-09 | 2015-07-15 | 649, 677, 683 | 0d |  | Cnes_TNR_HFR | NC TRR preparation | 15/07/15 TRR preparation |
| 651 | 3.6.3.2.5.9 | TRR | 1d | 2015-07-15 | 2015-07-16 | 650 | 0d |  | Cnes_TNR_HFR | NC TRR | 16/07/15 TRR |
| 652 | 3.6.3.2.5.10 | Validation tests | 10d | 2015-07-16 | 2015-07-30 | 651 | 0d |  | Cnes_TNR_HFR | NC Validation tests | 30/07/15 Validation tests |
| 653 | 3.6.3.2.5.11 | EMC tests at board level | 5d | 2015-07-30 | 2015-08-27 | 652 | 0d |  | Cnes_TNR_HFR | NC EMC tests at board level | 27/08/15 EMC tests at board level |
| 654 | 3.6.3.2.5.12 | MIP before coating | 1d | 2015-08-27 | 2015-08-28 | 653 | 0d |  | Cnes_TNR_HFR | NC MIP before coating | 28/08/15 MIP before coating |
| 655 | 3.6.3.2.5.13 | Coating | 9d | 2015-08-28 | 2015-09-10 | 654 | 0d |  | Cnes_TNR_HFR | NC Coating | 10/09/15 Coating |
| 656 | 3.6.3.2.5.14 | Post-coating tests | 5d | 2015-09-10 | 2015-09-17 | 655 | 0d |  | Cnes_TNR_HFR | NC Post-coating tests | 17/09/15 Post-coating tests |
| 657 | 3.6.3.2.5.15 | Calibration at unit level | 15d | 2015-09-17 | 2015-10-08 | 656 | 0d |  | Cnes_TNR_HFR | NC Calibration at unit level | 08/10/15 Calibration at unit level |
| 658 | 3.6.3.2.5.16 | Thermal tests & PPBI | 10d | 2015-10-08 | 2015-10-22 | 657 | 0d |  |  | NC Thermal tests & PPBI | 22/10/15 Thermal tests & PPBI |
| 659 | 3.6.3.2.5.17 | TRB/DRB preparation | 4d | 2015-10-22 | 2015-10-28 | 658 | 0d |  | Cnes_TNR_HFR | NC TRB/DRB preparation | 28/10/15 TRB/DRB preparation |
| 660 | 3.6.3.2.5.18 | TNR/HFR - TRB/DRB | 1d | 2015-10-28 | 2015-10-29 | 659 | 0d |  | Cnes_TNR_HFR | NC TNR/HFR - TRB/DRB | 29/10/15 TNR/HFR - TRB/DRB |

| ID | WBS | Task | Type | Duration | Start | Finish | Predecessors | Total slack | Free slack | Constraint | Calendar | FIN+NOM | ECHEANCE |
| --- | --- | --- | --- | --- | --- | --- | --- | --- | --- | --- | --- | --- | --- |
| 661 | 3.6.4 | **FPGA developments** |  | 138d | 2014-11-17 | 2015-06-12 |  | 8.5d |  |  | Cnes_TNR_HFR | 12/06/15 FPGA developments |  |
| 662 | 3.6.4.1 | FPGA programming tests (using AX version) |  | 22d | 2014-11-17 | 2014-12-16 |  | 9d | 0d | start no earlier than 2014-11-17 |  | 16/12/14 FPGA programming tests (using AX version) | NC FPGA programming tests (using AX version) |
| 663 | 3.6.4.2 | EM2 FPGA programming |  | 4d | 2014-12-17 | 2014-12-22 | 662 | 9d |  |  |  | 22/12/14 EM2 FPGA programming | NC EM2 FPGA programming |
| 664 | 3.6.4.3 | Completion of the firmware |  | 40d | 2014-12-01 | 2015-02-06 |  | 9.5d | 0d | start no earlier than 2014-12-01 | Cnes_TNR_HFR | 06/02/15 Completion of the firmware | NC Completion of the firmware |
| 665 | 3.6.4.4 | FPGA validation |  | 50d | 2015-02-09 | 2015-04-17 | 664 | 9.5d | 0d |  | Cnes_TNR_HFR | 17/04/15 FPGA validation | NC FPGA validation |
| 666 | 3.6.4.5 | Completion of the documentation |  | 20d | 2015-04-20 | 2015-05-19 | 665 | 9.5d | 0d |  | Cnes_TNR_HFR | 19/05/15 Completion of the documentation | NC Completion of the documentation |
| 667 | 3.6.4.6 | KP FPGA |  | 1d | 2015-05-20 | 2015-05-20 | 666 | 8.5d | 0d |  |  | 20/05/15 KP FPGA | NC KP FPGA |
| 668 | 3.6.4.7 | Complementary validation |  | 10d | 2015-05-21 | 2015-06-04 | 667 | 8.5d | 0d |  |  | 04/06/15 Complementary validation | NC Complementary validation |
| 669 | 3.6.4.8 | FM FPGA programming |  | 5d | 2015-06-05 | 2015-06-11 | 668 | 8.5d | 0d |  | Cnes_TNR_HFR | 11/06/15 FM FPGA programming | NC FM FPGA programming |
| 670 | 3.6.4.9 | FPGA FM ready | milestone | 1d | 2015-06-12 | 2015-06-12 | 669 | 8.5d |  |  | Cnes_TNR_HFR | 12/06/15 FPGA FM ready | NC FPGA FM ready |
| 671 | 3.6.5 | **Onboard SW developments** |  | 213d | 2014-10-01 | 2015-09-02 |  | 0d |  |  | Cnes_TNR_HFR | 02/09/15 Onboard SW developments | NC Onboard SW developments |
| 672 | 3.6.5.1 | R2 DRB/CDR |  | 2d | 2014-10-01 | 2014-10-02 |  | 0d |  | start no earlier than 2014-10-01 | Cnes_LFR | 02/10/14 R2 DRB/CDR | NC R2 DRB/CDR |
| 673 | 3.6.5.2 | R3 software |  | 230d | 2014-10-03 | 2015-09-02 | 672 | 0d |  |  |  | 02/09/15 R3 software | NC R3 software |
| 674 | 3.6.6 | **GSE develompment** |  | 133d | 2014-06-30 | 2015-02-06 |  | 0d |  |  | Cnes_TNR_HFR | 06/02/15 GSE develompment | NC GSE develompment |
| 675 | 3.6.6.1 | **SGSE** |  | 108d | 2014-06-30 | 2014-12-19 |  | 131.5d |  |  | Cnes_TNR_HFR | 19/12/14 SGSE | NC SGSE |
| 676 | 3.6.6.1.1 | Completion of the SGSE |  | 107d | 2014-06-30 | 2014-12-18 |  | 131.5d | 0d | start no earlier than 2014-06-30 | Cnes_TNR_HFR | 18/12/14 Completion of the SGSE | NC Completion of the SGSE |
| 677 | 3.6.6.1.2 | SGSE ready |  | 1d | 2014-12-19 | 2014-12-19 | 676 | 131.5d |  |  | Cnes_TNR_HFR | 19/12/14 SGSE ready | NC SGSE ready |
| 678 | 3.6.6.2 | **EGSE** |  | 133d | 2014-06-30 | 2015-02-06 |  | 0d |  |  | Cnes_TNR_HFR | 06/02/15 EGSE | NC EGSE |
| 679 | 3.6.6.2.1 | Communication with stimuli modules |  | 59d | 2014-06-30 | 2014-10-10 |  | 0d |  | start no earlier than 2014-06-30 | Cnes_TNR_HFR | 10/10/14 Communication with stimuli modules | NC Communication with stimuli modules |
| 680 | 3.6.6.2.2 | Script interpreter |  | 64d | 2014-09-01 | 2014-11-28 | 679FS-30d | 0d |  |  | Cnes_TNR_HFR | 28/11/14 Script interpreter | NC Script interpreter |
| 681 | 3.6.6.2.3 | Remote synchro with SGSE |  | 10d | 2014-12-01 | 2014-12-12 | 680 | 0d |  |  | Cnes_TNR_HFR | 12/12/14 Remote synchro with SGSE | NC Remote synchro with SGSE |
| 682 | 3.6.6.2.4 | Global tests |  | 9d | 2014-12-15 | 2015-01-08 | 681 | 0d |  |  | Cnes_TNR_HFR | 08/01/15 Global tests | NC Global tests |
| 683 | 3.6.6.2.5 | EGSE ready |  | 1d | 2015-01-09 | 2015-01-09 | 682 | 0d |  |  | Cnes_TNR_HFR | 09/01/15 EGSE ready | NC EGSE ready |
| 684 | 3.6.6.2.6 | Documentation |  | 20d | 2015-01-12 | 2015-02-06 | 683 | 0d |  |  | Cnes_TNR_HFR | 06/02/15 Documentation | NC Documentation |

| ID | WBS | Task | Type | Duration | Start | Finish | Predecessors | Complete | Remaining | Baseline start | Baseline finish | Baseline duration | Total slack | Free slack | Constraint | Calendar | OldLg | Texte17 | Ancien Num | FIN+NOM | ECHEANCE |
| --- | --- | --- | --- | --- | --- | --- | --- | --- | --- | --- | --- | --- | --- | --- | --- | --- | --- | --- | --- | --- | --- |
| 685 | 3.7 | **DPU** |  | 513.5d | 2013-09-02 A | 2015-09-24 |  | 55% | 231.9d | 2012-07-18 | 2014-07-29 | 510d | 0d |  |  | Cnes_DPU | 311 | 457 | 326 | 24/09/15 DPU |  |
| 686 | 3.7.1 | **Procurement & Production** |  | 299d | 2013-09-02 A | 2014-11-11 A |  | 100% |  |  |  |  |  |  |  | Cnes_DPU |  |  |  | 11/11/14 Procurement & Production | NC Procurement & Production |
| 687 | 3.7.1.1 | Procurement ALTER 1 |  | 150d | 2013-09-02 A | 2014-04-07 A |  | 100% |  |  |  |  |  |  | start no earlier than 2013-09-02 | Cnes_DPU |  |  |  | 07/04/14 Procurement ALTER 1 | NC Procurement ALTER 1 |
| 688 | 3.7.1.2 | Procurement PROTEC |  | 100d | 2013-12-06 A | 2014-05-06 A |  | 100% |  |  |  |  |  |  | start no earlier than 2013-12-06 | Cnes_DPU |  |  |  | 06/05/14 Procurement PROTEC | NC Procurement PROTEC |
| 689 | 3.7.1.3 | Procurement ALTER 2 |  | 70d | 2014-08-05 A | 2014-11-11 A |  | 100% |  |  |  |  |  |  | start no earlier than 2014-08-05 | Cnes_DPU |  |  |  | 11/11/14 Procurement ALTER 2 | NC Procurement ALTER 2 |
| 690 | 3.7.1.4 | Delivery of last QM component | milestone | 0d | 2014-05-06 A | 2014-05-06 A | 688 | 100% |  |  |  |  |  |  |  | Cnes_DPU |  |  |  | 06/05/14 Delivery of last QM component | NC Delivery of last QM component |
| 691 | 3.7.1.5 | Delivery of last FM component | milestone | 0d | 2014-11-11 A | 2014-11-11 A | 689 | 100% |  |  |  |  |  |  |  | Cnes_DPU |  |  |  | 11/11/14 Delivery of last FM component | NC Delivery of last FM component |
| 692 | 3.7.1.6 | NCR investigations |  | 30d | 2014-06-18 A | 2014-07-30 A |  | 100% |  |  |  |  |  |  | start no earlier than 2014-06-18 | Cnes_DPU |  |  |  | 30/07/14 NCR investigations | NC NCR investigations |
| 693 | 3.7.1.7 | PCB EM2B manufacturing |  | 40d | 2014-09-15 A | 2014-11-07 A | 692 | 100% |  |  |  |  |  |  | start no earlier than 2014-09-15 | Cnes_DPU |  |  |  | 07/11/14 PCB EM2B manufacturing | NC PCB EM2B manufacturing |
| 694 | 3.7.1.8 | Update of test procedures BLT, FT, TT, EMC |  | 20d | 2014-09-15 A | 2014-10-10 A |  | 100% |  |  |  |  |  |  | start no earlier than 2014-09-15 | Cnes_DPU |  |  |  | 10/10/14 Update of test procedures BLT, FT, TT, EMC | NC Update of test procedures BLT, FT, TT, EMC |
| 695 | 3.7.1.9 | Approval of test procedures |  | 10d | 2014-10-13 A | 2014-10-24 A | 694 | 100% |  |  |  |  |  |  |  | Cnes_DPU |  |  |  | 24/10/14 Approval of test procedures | NC Approval of test procedures |
| 696 | 3.7.1.10 | MRR for EM2B | milestone | 0d | 2014-11-07 A | 2014-11-07 A | 695, 693 | 100% |  |  |  |  |  |  |  | Cnes_DPU |  |  |  | 07/11/14 MRR for EM2B | NC MRR for EM2B |
| 697 | 3.7.2 | **DPU Pre-EQM HW design,dev & tests** |  | 123d | 2014-07-07 A | 2014-12-30 |  | 79% | 25.7d |  |  |  | 0d |  |  |  |  |  |  | 30/12/14 DPU Pre-EQM HW design,dev & tests | NC Pre-EQM assembly & test |
| 698 | 3.7.2.1 | NCR investigations & pre-EQM delivery to LESIA |  | 72d | 2014-07-07 A | 2014-10-15 A |  | 100% |  |  |  |  |  |  | start no earlier than 2014-07-07 | Cnes_DPU |  |  |  | 15/10/14 NCR investigations & pre-EQM delivery to LESIA | NC NCR investigations & pre-EQM delivery to LESIA |
| 699 | 3.7.2.2 | Pré-EQM2 delivery |  | 52d | 2014-10-16 A | 2014-12-30 | 698 | 46% | 28d |  |  |  | 0d |  |  |  |  |  |  | 30/12/14 Pré-EQM2 delivery | NC Pré-EQM2 delivery |
| 700 | 3.7.2.3 | Pre-EQM acceptance test by LESIA & Cnes |  | 10d | 2014-10-16 A | 2014-10-29 A | 698 | 100% |  |  |  |  |  |  |  |  |  |  |  | 29/10/14 Pre-EQM acceptance test by LESIA & Cnes | NC Pre-EQM acceptance test by LESIA & Cnes |
| 701 | 3.7.2.4 | close out of NCR | milestone | 0d | 2014-10-29 A | 2014-10-29 A | 700 | 100% |  |  |  |  |  |  |  | Cnes_DPU |  |  |  | 29/10/14 close out of NCR | NC close out of NCR |
| 702 | 3.7.3 | **DPU EM2B HW design,dev & tests** |  | 69d | 2014-10-13 A | 2015-01-23 |  | 21% | 54.53d |  |  |  | 18.5d |  |  | Cnes_DPU |  |  |  | 23/01/15 DPU EM2B HW design,dev & tests |  |
| 703 | 3.7.3.1 | Preparation of EEE components |  | 5d | 2014-10-13 A | 2014-10-17 A | 694 | 100% |  |  |  |  |  |  |  | Cnes_DPU |  |  |  | 17/10/14 Preparation of EEE components | NC Preparation of EEE components |
| 704 | 3.7.3.2 | EM2B PCB preparation |  | 1d | 2014-11-10 A | 2014-11-10 A | 696 | 100% |  |  |  |  |  |  |  | Cnes_DPU |  |  |  | 10/11/14 EM2B PCB preparation | NC EM2B PCB preparation |
| 705 | 3.7.3.3 | EM2B vapour phase soldering |  | 2d | 2014-11-11 A | 2014-11-12 A | 704, 703 | 100% |  |  |  |  |  |  |  | Cnes_DPU |  |  |  | 12/11/14 EM2B vapour phase soldering | NC EM2B vapour phase soldering |
| 706 | 3.7.3.4 | EM2B hand soldering |  | 5d | 2014-11-13 A | 2014-11-19 A | 705 | 100% |  |  |  |  |  |  |  | Cnes_DPU |  |  |  | 19/11/14 EM2B hand soldering | NC EM2B hand soldering |
| 707 | 3.7.3.5 | EM2B Board level test |  | 5d | 2014-11-20 | 2014-11-26 | 706 |  |  |  |  |  | 0d |  |  | Cnes_DPU |  |  |  | 26/11/14 EM2B Board level test | NC EM2B Board level test |
| 708 | 3.7.3.6 | Preparation test results BLT |  | 5d | 2014-11-27 | 2014-12-03 | 707 |  |  |  |  |  | 0d |  |  | Cnes_DPU |  |  |  | 03/12/14 Preparation test results BLT | NC Preparation test results BLT |
| 709 | 3.7.3.7 | EM2B PROM soldering |  | 2d | 2014-11-27 | 2014-11-28 | 707 |  |  |  |  |  | 0d |  |  | Cnes_DPU |  |  |  | 28/11/14 EM2B PROM soldering | NC EM2B PROM soldering |
| 710 | 3.7.3.8 | EM2B Staking of components |  | 1d | 2014-12-01 | 2014-12-01 | 709 |  |  |  |  |  | 0d |  |  | Cnes_DPU |  |  |  | 01/12/14 EM2B Staking of components | NC EM2B Staking of components |
| 711 | 3.7.3.9 | EM2B MIP |  | 2d | 2014-12-02 | 2014-12-03 | 710 |  |  |  |  |  | 0d |  |  | Cnes_DPU |  |  |  | 03/12/14 EM2B MIP | NC EM2B MIP |
| 712 | 3.7.3.10 | EM2B reserve for PCB corrections |  | 3d | 2014-12-04 | 2014-12-09 | 711 |  |  |  |  |  | 0d |  |  | Cnes_DPU |  |  |  | 09/12/14 EM2B reserve for PCB corrections | NC EM2B reserve for PCB corrections |
| 713 | 3.7.3.11 | EM2B Thermal glue |  | 1d | 2014-12-10 | 2014-12-10 | 712 |  |  |  |  |  | 0d |  |  | Cnes_DPU |  |  |  | 10/12/14 EM2B Thermal glue | NC EM2B Thermal glue |
| 714 | 3.7.3.12 | EM2B Installation into frame |  | 1d | 2014-12-11 | 2014-12-11 | 713 |  |  |  |  |  | 0d |  |  | Cnes_DPU |  |  |  | 11/12/14 EM2B Installation into frame | NC EM2B Installation into frame |
| 715 | 3.7.3.13 | EM2B Coating |  | 2d | 2014-12-12 | 2014-12-15 | 714 |  |  |  |  |  | 0d |  |  | Cnes_DPU |  |  |  | 15/12/14 EM2B Coating | NC EM2B Coating |
| 716 | 3.7.3.14 | EM2B functional test |  | 5d | 2014-12-16 | 2014-12-22 | 715 |  |  |  |  |  | 0d |  |  | Cnes_DPU |  |  |  | 22/12/14 EM2B functional test | NC EM2B functional test |
| 717 | 3.7.3.15 | Preparation test results FT |  | 2d | 2014-12-23 | 2014-12-29 | 716 |  |  |  |  |  | 0d |  |  | Cnes_DPU |  |  |  | 29/12/14 Preparation test results FT | NC Preparation test results FT |
| 718 | 3.7.3.16 | EM2B thermal cycling |  | 5d | 2014-12-23 | 2015-01-05 | 716 |  |  |  |  |  | 0d |  |  | Cnes_DPU |  |  |  | 05/01/15 EM2B thermal cycling | NC EM2B thermal cycling |
| 719 | 3.7.3.17 | Prepare test results TT |  | 1d | 2015-01-06 | 2015-01-06 | 718 |  |  |  |  |  | 0d |  |  | Cnes_DPU |  |  |  | 06/01/15 Prepare test results TT | NC Prepare test results TT |
| 720 | 3.7.3.18 | EM2B EMC test |  | 5d | 2015-01-06 | 2015-01-12 | 718 |  |  |  |  |  | 18.5d | 0d |  | Cnes_DPU |  |  |  | 12/01/15 EM2B EMC test | NC EM2B EMC test |
| 721 | 3.7.3.19 | Prepare test results EMC |  | 2d | 2015-01-13 | 2015-01-14 | 720 |  |  |  |  |  | 18.5d | 0d |  | Cnes_DPU |  |  |  | 14/01/15 Prepare test results EMC | NC Prepare test results EMC |
| 722 | 3.7.3.20 | Prepare EM2B DataPack |  | 5d | 2015-01-15 | 2015-01-21 | 721, 720 |  |  |  |  |  | 18.5d | 0d |  | Cnes_DPU |  |  |  | 21/01/15 Prepare EM2B DataPack | NC Prepare EM2B DataPack |
| 723 | 3.7.3.21 | EM2B TRB/DRB |  | 2d | 2015-01-22 | 2015-01-23 | 722 |  |  |  |  |  | 18.5d | 0d |  | Cnes_DPU |  |  |  | 23/01/15 EM2B TRB/DRB | NC EM2B TRB/DRB |
| 724 | 3.7.3.22 | DPU EM2B Delivery | milestone | 0d | 2015-01-23 | 2015-01-23 | 723 |  |  |  |  |  | 18.5d | 0d |  | Cnes_DPU |  |  |  | 23/01/15 DPU EM2B Delivery | NC DPU EM2B Delivery |

| ID | WBS | Task | Type | Duration | Start | Finish | Predecessors | Complete | Remaining | Baseline start | Baseline finish | Baseline duration | Total slack | Free slack | Constraint | Calendar | FIN+NOM | ECHEANCE | OldLg | Texte17 | Ancien Num |
| --- | --- | --- | --- | --- | --- | --- | --- | --- | --- | --- | --- | --- | --- | --- | --- | --- | --- | --- | --- | --- | --- |
| 725 | 3.7.4 | **Qualification of hand soldering** |  | 185d | 2014-06-23 A | 2015-03-17 |  | 65% | 65.59d |  |  |  | 0d |  |  | Cnes_DPU | 17/03/15 Qualification of hand soldering |  |  |  |  |
| 726 | 3.7.4.1 | Establish detailed plan |  | 45d | 2014-06-23 A | 2014-08-25 A |  | 100% |  |  |  |  |  |  | start no earlier than 2014-06-23 | Cnes_DPU | 25/08/14 Establish detailed plan | NC Establish detailed plan |  |  |  |
| 727 | 3.7.4.2 | Update test plan |  | 15d | 2014-08-26 A | 2014-09-15 A | 726 | 100% |  |  |  |  |  |  |  | Cnes_DPU | 15/09/14 Update test plan | NC Update test plan |  |  |  |
| 728 | 3.7.4.3 | Review of qualification plan by LESIA & CNES |  | 10d | 2014-09-16 A | 2014-09-29 A | 727 | 100% |  |  |  |  |  |  |  | Cnes_DPU | 29/09/14 Review of qualification plan by LESIA & CNES | NC Review of qualification plan by LESIA & CNES |  |  |  |
| 729 | 3.7.4.4 | Design of test board |  | 10d | 2014-08-26 A | 2014-09-08 A | 726 | 100% |  |  |  |  |  |  |  | Cnes_DPU | 08/09/14 Design of test board | NC Design of test board |  |  |  |
| 730 | 3.7.4.5 | Design of mechanical test adapter |  | 10d | 2014-08-26 A | 2014-09-08 A | 726 | 100% |  |  |  |  |  |  |  | Cnes_DPU | 08/09/14 Design of mechanical test adapter | NC Design of mechanical test adapter |  |  |  |
| 731 | 3.7.4.6 | Manufacturing PCB |  | 40d | 2014-09-30 A | 2014-11-24 | 728, 729, 730 | 93% | 3d |  |  |  | 0d |  |  | Cnes_DPU | 24/11/14 Manufacturing PCB | NC Manufacturing PCB |  |  |  |
| 732 | 3.7.4.7 | Manufacturing test adapter |  | 15d | 2014-09-30 A | 2014-10-20 A | 730, 728, 729 | 100% |  | 2013-07-16 | 2014-04-01 | 180d |  |  |  | Cnes_DPU | 20/10/14 Manufacturing test adapter | NC Manufacturing test adapter | 317 | 464 | 332 |
| 733 | 3.7.4.8 | Soldering process |  | 7d | 2014-11-25 | 2014-12-03 | 732, 731 |  |  | 2013-07-16 | 2014-04-01 | 9mo | 0d |  |  | Cnes_DPU | 03/12/14 Soldering process | NC Soldering process | 319 | 466 | 334 |
| 734 | 3.7.4.9 | Staking & coating |  | 3d | 2014-12-04 | 2014-12-09 | 733 |  |  |  |  |  | 0d |  |  | Cnes_DPU | 09/12/14 Staking & coating | NC Staking & coating |  |  |  |
| 735 | 3.7.4.10 | Vibration test |  | 5d | 2014-12-10 | 2014-12-16 | 734 |  |  |  |  |  | 0d |  |  | Cnes_DPU | 16/12/14 Vibration test | NC Vibration test |  | 467 |  |
| 736 | 3.7.4.11 | Thermal cycling |  | 15d | 2014-12-17 | 2015-01-13 | 735 |  |  |  |  |  | 0d |  |  | Cnes_DPU | 13/01/15 Thermal cycling | NC Thermal cycling |  | 468 |  |
| 737 | 3.7.4.12 | Thermal cycling |  | 20d | 2015-01-14 | 2015-02-10 | 736 |  |  |  |  |  | 0d |  |  | Cnes_DPU | 10/02/15 Thermal cycling | NC Thermal cycling |  | 469 |  |
| 738 | 3.7.4.13 | Microsectioning |  | 15d | 2015-02-11 | 2015-03-03 | 737 |  |  |  |  |  | 0d |  |  | Cnes_DPU | 03/03/15 Microsectioning | NC Microsectioning |  | 470 |  |
| 739 | 3.7.4.14 | Generation of test report |  | 10d | 2015-03-04 | 2015-03-17 | 738 |  |  |  |  |  | 0d |  |  | Cnes_DPU | 17/03/15 Generation of test report | NC Generation of test report |  |  |  |
| 740 | 3.7.4.15 | Acceptance of soldering process | milestone | 0d | 2015-03-17 | 2015-03-17 | 739 |  |  |  |  |  | 0d |  |  | Cnes_DPU | 17/03/15 Acceptance of soldering process | NC Acceptance of soldering process |  |  |  |
| 741 | 3.7.5 | **EM2B FPGA programming cycle** |  | 58d | 2014-10-06 A | 2014-12-30 |  | 57% | 25d |  |  |  | 0d |  |  | Cnes_DPU | 30/12/14 EM2B FPGA programming cycle |  |  |  |  |
| 742 | 3.7.5.1 | FPGA final design tested |  | 10d | 2014-10-06 A | 2014-10-17 A |  | 100% |  |  |  |  |  |  | start no earlier than 2014-10-06 | Cnes_DPU | 17/10/14 FPGA final design tested | NC FPGA final design tested |  |  |  |
| 743 | 3.7.5.2 | FPGA go-ahead | milestone | 0d | 2014-10-17 A | 2014-10-17 A | 742 | 100% |  |  |  |  |  |  |  | Cnes_DPU | 17/10/14 FPGA go-ahead | NC FPGA go-ahead |  |  |  |
| 744 | 3.7.5.3 | Preparation as/if |  | 15d | 2014-10-20 A | 2014-11-07 A | 743 | 100% |  |  |  |  |  |  |  | Cnes_DPU | 07/11/14 Preparation as/if | NC Preparation as/if |  |  |  |
| 745 | 3.7.5.4 | FPGA programming |  | 3d | 2014-11-10 A | 2014-11-12 A | 744 | 100% |  |  |  |  |  |  |  | Cnes_DPU | 12/11/14 FPGA programming | NC FPGA programming |  |  |  |
| 746 | 3.7.5.5 | FPGA PPBI |  | 20d | 2014-11-13 A | 2014-12-11 | 745 | 25% | 15d |  |  |  | 0d |  |  | Cnes_DPU | 11/12/14 FPGA PPBI | NC FPGA PPBI |  |  |  |
| 747 | 3.7.5.6 | Test report FPGA PPBI |  | 10d | 2014-12-12 | 2014-12-30 | 746 |  |  |  |  |  | 0d |  |  | Cnes_DPU | 30/12/14 Test report FPGA PPBI | NC Test report FPGA PPBI |  |  |  |
| 748 | 3.7.6 | **DBS test and PROM prearation** |  | 259d | 2014-04-29 | 2015-05-12 |  |  |  |  |  |  | 5.5d |  |  |  | 12/05/15 DBS test and PROM prearation | NC DBS test and PROM prearation |  |  |  |
| 749 | 3.7.6.1 | TRR V1.0 |  | 2d | 2014-04-29 | 2014-04-30 |  |  |  |  |  |  | 9d | 0d | start no earlier than 2014-04-29 | Cnes_DPU | 30/04/14 TRR V1.0 | NC TRR V1.0 |  |  |  |
| 750 | 3.7.6.2 | Validation test V1.0 |  | 30d | 2014-05-02 | 2014-06-16 | 749 |  |  |  |  |  | 9d | 7d |  | Cnes_DPU | 16/06/14 Validation test V1.0 | NC Validation test V1.0 |  |  |  |
| 751 | 3.7.6.3 | Test review V1.0 |  | 1d | 2014-06-26 | 2014-06-26 | 750 |  |  |  |  |  | 3d | 0d | start no earlier than 2014-06-26 | Cnes_DPU | 26/06/14 Test review V1.0 | NC Test review V1.0 |  |  |  |
| 752 | 3.7.6.4 | Coding V1.1 |  | 12d | 2014-06-27 | 2014-07-14 | 751 |  |  |  |  |  | 3d | 0d |  | Cnes_DPU | 14/07/14 Coding V1.1 | NC Coding V1.1 |  |  |  |
| 753 | 3.7.6.5 | Testing V1.1 |  | 15d | 2014-07-15 | 2014-08-04 | 752 |  |  |  |  |  | 3d |  |  | Cnes_DPU | 04/08/14 Testing V1.1 | NC Testing V1.1 |  |  |  |
| 754 | 3.7.6.6 | Delivery V1.1 | milestone | 0d | 2014-08-08 | 2014-08-08 | 753 |  |  |  |  |  | 0d |  | start no earlier than 2014-08-08 | Cnes_DPU | 08/08/14 Delivery V1.1 | NC Delivery V1.1 |  |  |  |
| 755 | 3.7.6.7 | QM PROM Programming |  | 1d | 2014-08-08 | 2014-08-08 | 754 |  |  |  |  |  | 0d |  |  | Cnes_DPU | 08/08/14 QM PROM Programming | NC QM PROM Programming |  |  |  |
| 756 | 3.7.6.8 | QM PROM PPBI test |  | 15d | 2014-08-11 | 2014-09-01 | 755 |  |  |  |  |  | 0d |  |  | Cnes_DPU | 01/09/14 QM PROM PPBI test | NC QM PROM PPBI test |  |  |  |
| 757 | 3.7.6.9 | Coding and testing V1.2 as/if |  | 15d | 2015-01-21 | 2015-02-10 | 860 |  |  |  |  |  | 0d |  |  | Cnes_DPU | 10/02/15 Coding and testing V1.2 as/if | NC Coding and testing V1.2 as/if |  |  |  |
| 758 | 3.7.6.10 | TRR V1.2 |  | 1d | 2015-02-11 | 2015-02-11 | 757 |  |  |  |  |  | 0d |  |  | Cnes_DPU | 11/02/15 TRR V1.2 | NC TRR V1.2 |  |  |  |
| 759 | 3.7.6.11 | Validation Test V1.2 |  | 20d | 2015-02-12 | 2015-03-11 | 758 |  |  |  |  |  | 0d |  |  | Cnes_DPU | 11/03/15 Validation Test V1.2 | NC Validation Test V1.2 |  |  |  |
| 760 | 3.7.6.12 | TRB/QR Final version |  | 1d | 2015-03-12 | 2015-03-12 | 759 |  |  |  |  |  | 0d |  |  | Cnes_DPU | 12/03/15 TRB/QR Final version | NC TRB/QR Final version |  | 471 |  |
| 761 | 3.7.6.13 | LESIA acceptance tests |  | 20d | 2015-03-13 | 2015-04-10 | 760 |  |  |  |  |  | 5.5d | 0d |  |  | 10/04/15 LESIA acceptance tests | NC LESIA acceptance tests |  |  |  |
| 762 | 3.7.6.14 | PROM Programming final |  | 1d | 2015-04-13 | 2015-04-13 | 761 |  |  |  |  |  | 5.5d | 0d |  | Cnes_DPU | 13/04/15 PROM Programming final | NC PROM Programming final |  |  |  |
| 763 | 3.7.6.15 | PROM PPBI |  | 15d | 2015-04-14 | 2015-05-05 | 762 |  |  |  |  |  | 5.5d | 0d |  | Cnes_DPU | 05/05/15 PROM PPBI | NC PROM PPBI |  |  |  |
| 764 | 3.7.6.16 | Prepare test report |  | 5d | 2015-05-06 | 2015-05-12 | 763 |  |  |  |  |  | 5.5d |  |  | Cnes_DPU | 12/05/15 Prepare test report | NC Prepare test report |  |  |  |

| ID | WBS | Task | Type | Duration | Start | Finish | Predecessors | Total slack | Free slack | Constraint | Calendar | Text24 | FIN+NOM | ECHEANCE |
| --- | --- | --- | --- | --- | --- | --- | --- | --- | --- | --- | --- | --- | --- | --- |
| 765 | 3.7.7 | **FM FPGA programming cycle** |  | 43d | 2015-01-30 | 2015-03-31 |  | 31.5d |  |  | Cnes_DPU | MASQ | 31/03/15 FM FPGA programming cycle |  |
| 766 | 3.7.7.1 | FM FPGA go-ahead | milestone | 0d | 2015-01-30 | 2015-01-30 | 724 | 31.5d | 0d | start no earlier than 2015-01-30 | Cnes_DPU | MASQ | 30/01/15 FM FPGA go-ahead | NC FM FPGA go-ahead |
| 767 | 3.7.7.2 | Preparation as/if |  | 10d | 2015-01-30 | 2015-02-12 | 766 | 31.5d | 0d |  | Cnes_DPU | MASQ | 12/02/15 Preparation as/if | NC Preparation as/if |
| 768 | 3.7.7.3 | FPGA programming |  | 3d | 2015-02-13 | 2015-02-17 | 767 | 31.5d | 0d |  | Cnes_DPU | MASQ | 17/02/15 FPGA programming | NC FPGA programming |
| 769 | 3.7.7.4 | FPGA PPBI |  | 20d | 2015-02-18 | 2015-03-17 | 768 | 31.5d | 0d |  | Cnes_DPU | MASQ | 17/03/15 FPGA PPBI | NC FPGA PPBI |
| 770 | 3.7.7.5 | Test report FPGA PPBI |  | 10d | 2015-03-18 | 2015-03-31 | 769 | 31.5d |  |  | Cnes_DPU | MASQ | 31/03/15 Test report FPGA PPBI | NC Test report FPGA PPBI |
| 771 | 3.7.8 | Design consolidation |  | 10d | 2015-01-26 | 2015-02-06 | 723 | 68.5d |  |  |  |  | 06/02/15 Design consolidation | NC Design consolidation |
| 772 | 3.7.9 | FM PCB manufacturing |  | 40d | 2015-01-26 | 2015-03-20 | 724 | 18.5d | 0d |  | Cnes_DPU | MASQ | 20/03/15 FM PCB manufacturing | NC FM PCB manufacturing |
| 773 | 3.7.10 | Preparation of EEE components |  | 10d | 2015-03-23 | 2015-04-07 | 772 | 18.5d | 0d |  | Cnes_DPU | MASQ | 07/04/15 Preparation of EEE components | NC Preparation of EEE components |
| 774 | 3.7.11 | MRR preparation (documentation) |  | 10d | 2015-04-08 | 2015-04-21 | 773 | 18.5d | 17.5d |  | Cnes_DPU | MASQ | 21/04/15 MRR preparation (documentation) | NC MRR preparation (documentation) |
| 775 | 3.7.12 | MRR for FM1& FM2 | milestone | 0d | 2015-05-20 | 2015-05-20 | 770, 771, 1065, 774 | 0d |  |  | Cnes_DPU | MASQ | 20/05/15 MRR for FM1& FM2 | NC MRR for FM1& FM2 |
| 776 | 3.7.13 | **DPU FM1 HW design,dev & tests** |  | 47d | 2015-05-20 | 2015-07-28 |  | 0d |  |  | Cnes_DPU |  | 28/07/15 DPU FM1 HW design,dev & tests |  |
| 777 | 3.7.13.1 | FM1 PCB preparation |  | 1d | 2015-05-20 | 2015-05-21 | 775, 772 | 0d |  |  | Cnes_DPU |  | 21/05/15 FM1 PCB preparation | NC FM1 PCB preparation |
| 778 | 3.7.13.2 | FM1 Hand soldering of components |  | 20d | 2015-05-21 | 2015-06-22 | 777, 764 | 0d |  |  | Cnes_DPU |  | 22/06/15 FM1 Hand soldering of components | NC FM1 Hand soldering of components |
| 779 | 3.7.13.3 | FM1 Board level test |  | 5d | 2015-06-22 | 2015-06-29 | 778 | 0d |  |  | Cnes_DPU |  | 29/06/15 FM1 Board level test | NC FM1 Board level test |
| 780 | 3.7.13.4 | FM1 PROM soldering |  | 2d | 2015-06-29 | 2015-07-01 | 779 | 0d |  |  | Cnes_DPU |  | 01/07/15 FM1 PROM soldering | NC FM1 PROM soldering |
| 781 | 3.7.13.5 | FM1 Staking of components |  | 1d | 2015-07-01 | 2015-07-02 | 780 | 0d |  |  | Cnes_DPU |  | 02/07/15 FM1 Staking of components | NC FM1 Staking of components |
| 782 | 3.7.13.6 | FM1 MIP |  | 2d | 2015-07-02 | 2015-07-06 | 781 | 0d |  |  | Cnes_DPU |  | 06/07/15 FM1 MIP | NC FM1 MIP |
| 783 | 3.7.13.7 | FM1 reserve for PCB corrections |  | 3d | 2015-07-06 | 2015-07-09 | 782 | 0d |  |  | Cnes_DPU |  | 09/07/15 FM1 reserve for PCB corrections | NC FM1 reserve for PCB corrections |
| 784 | 3.7.13.8 | FM1 Thermal glue |  | 1d | 2015-07-09 | 2015-07-10 | 783 | 0d |  |  | Cnes_DPU |  | 10/07/15 FM1 Thermal glue | NC FM1 Thermal glue |
| 785 | 3.7.13.9 | FM1 Installation into frame |  | 1d | 2015-07-10 | 2015-07-13 | 784 | 0d |  |  | Cnes_DPU |  | 13/07/15 FM1 Installation into frame | NC FM1 Installation into frame |
| 786 | 3.7.13.10 | FM1 Coating |  | 2d | 2015-07-13 | 2015-07-15 | 785 | 0d |  |  | Cnes_DPU |  | 15/07/15 FM1 Coating | NC FM1 Coating |
| 787 | 3.7.13.11 | FM1 functional test |  | 5d | 2015-07-15 | 2015-07-22 | 786 | 0d |  |  | Cnes_DPU |  | 22/07/15 FM1 functional test | NC FM1 functional test |
| 788 | 3.7.13.12 | FM1 thermal cycling |  | 2d | 2015-07-22 | 2015-07-24 | 787 | 0d |  |  | Cnes_DPU |  | 24/07/15 FM1 thermal cycling | NC FM1 thermal cycling |
| 789 | 3.7.13.13 | FM1 final preparation |  | 2d | 2015-07-24 | 2015-07-28 | 788 | 0d |  |  | Cnes_DPU |  | 28/07/15 FM1 final preparation | NC FM1 final preparation |
| 790 | 3.7.13.14 | DPU FM1 Delivery | milestone | 0d | 2015-07-28 | 2015-07-28 | 789 | 0d |  |  | Cnes_DPU |  | 28/07/15 DPU FM1 Delivery | NC DPU FM1 Delivery |

| ID | WBS | Task | Type | Duration | Start | Finish | Predecessors | Total slack | Calendar | ECHEANCE | FIN+NOM |
| --- | --- | --- | --- | --- | --- | --- | --- | --- | --- | --- | --- |
| 791 | 3.7.14 | **DPU FM2 HW design,dev & tests** |  | 47d | 2015-06-22 | 2015-08-26 |  | 0d | Cnes_DPU | NC | 26/08/15 DPU FM2 HW design,dev & tests |
| 792 | 3.7.14.1 | FM2 PCB preparation |  | 1d | 2015-06-22 | 2015-06-23 | 778 | 0d | Cnes_DPU | NC FM2 PCB preparation | 23/06/15 FM2 PCB preparation |
| 793 | 3.7.14.2 | FM2 Hand soldering of components |  | 20d | 2015-06-23 | 2015-07-21 | 792 | 0d | Cnes_DPU | NC FM2 Hand soldering of components | 21/07/15 FM2 Hand soldering of components |
| 794 | 3.7.14.3 | FM2 Board level test |  | 5d | 2015-07-21 | 2015-07-28 | 793 | 0d | Cnes_DPU | NC FM2 Board level test | 28/07/15 FM2 Board level test |
| 795 | 3.7.14.4 | FM2 PROM soldering |  | 2d | 2015-07-28 | 2015-07-30 | 794 | 0d | Cnes_DPU | NC FM2 PROM soldering | 30/07/15 FM2 PROM soldering |
| 796 | 3.7.14.5 | FM2 Staking of components |  | 1d | 2015-07-30 | 2015-07-31 | 795 | 0d | Cnes_DPU | NC FM2 Staking of components | 31/07/15 FM2 Staking of components |
| 797 | 3.7.14.6 | FM2 MIP |  | 2d | 2015-07-31 | 2015-08-04 | 796 | 0d | Cnes_DPU | NC FM2 MIP | 04/08/15 FM2 MIP |
| 798 | 3.7.14.7 | FM2 reserve for PCB correction |  | 3d | 2015-08-04 | 2015-08-07 | 797 | 0d | Cnes_DPU | NC FM2 reserve for PCB correction | 07/08/15 FM2 reserve for PCB correction |
| 799 | 3.7.14.8 | FM2 Thermal glue |  | 1d | 2015-08-07 | 2015-08-10 | 798 | 0d | Cnes_DPU | NC FM2 Thermal glue | 10/08/15 FM2 Thermal glue |
| 800 | 3.7.14.9 | FM2 Installation into frame |  | 1d | 2015-08-10 | 2015-08-11 | 799 | 0d | Cnes_DPU | NC FM2 Installation into frame | 11/08/15 FM2 Installation into frame |
| 801 | 3.7.14.10 | FM2 Coating |  | 2d | 2015-08-11 | 2015-08-13 | 800 | 0d | Cnes_DPU | NC FM2 Coating | 13/08/15 FM2 Coating |
| 802 | 3.7.14.11 | FM2 functional test |  | 5d | 2015-08-13 | 2015-08-20 | 801 | 0d | Cnes_DPU | NC FM2 functional test | 20/08/15 FM2 functional test |
| 803 | 3.7.14.12 | FM2 thermal cycling |  | 2d | 2015-08-20 | 2015-08-24 | 802 | 0d | Cnes_DPU | NC FM2 thermal cycling | 24/08/15 FM2 thermal cycling |
| 804 | 3.7.14.13 | FM2 final preparation |  | 2d | 2015-08-24 | 2015-08-26 | 803 | 0d | Cnes_DPU | NC FM2 final preparation | 26/08/15 FM2 final preparation |
| 805 | 3.7.14.14 | DPU FM2 Delivery | milestone | 0d | 2015-08-26 | 2015-08-26 | 804 | 0d | Cnes_DPU | NC DPU FM2 Delivery | 26/08/15 DPU FM2 Delivery |
| 806 | 3.7.15 | MRR for Spare | milestone | 0d | 2015-07-21 | 2015-07-21 | 773, 793 | 0d | Cnes_DPU | NC MRR for Spare | 21/07/15 MRR for Spare |
| 807 | 3.7.16 | **FM_Spare assembly & test** |  | 47d | 2015-07-21 | 2015-09-24 |  | 0d | Cnes_DPU |  | 24/09/15 FM_Spare assembly & test |
| 808 | 3.7.16.1 | FM_Spare PCB preparation |  | 1d | 2015-07-21 | 2015-07-22 | 806 | 0d | Cnes_DPU | NC FM_Spare PCB preparation | 22/07/15 FM_Spare PCB preparation |
| 809 | 3.7.16.2 | FM_Spare Hand soldering of components |  | 20d | 2015-07-22 | 2015-08-19 | 808 | 0d | Cnes_DPU | NC FM_Spare Hand soldering of components | 19/08/15 FM_Spare Hand soldering of components |
| 810 | 3.7.16.3 | FM_Spare Board level test |  | 5d | 2015-08-19 | 2015-08-26 | 809 | 0d | Cnes_DPU | NC FM_Spare Board level test | 26/08/15 FM_Spare Board level test |
| 811 | 3.7.16.4 | FM_Spare PROM soldering |  | 2d | 2015-08-26 | 2015-08-28 | 810 | 0d | Cnes_DPU | NC FM_Spare PROM soldering | 28/08/15 FM_Spare PROM soldering |
| 812 | 3.7.16.5 | FM_Spare Staking of components |  | 1d | 2015-08-28 | 2015-08-31 | 811 | 0d | Cnes_DPU | NC FM_Spare Staking of components | 31/08/15 FM_Spare Staking of components |
| 813 | 3.7.16.6 | FM_Spare MIP |  | 2d | 2015-08-31 | 2015-09-02 | 812 | 0d | Cnes_DPU | NC FM_Spare MIP | 02/09/15 FM_Spare MIP |
| 814 | 3.7.16.7 | FM_Spare spare for PCB correction |  | 3d | 2015-09-02 | 2015-09-07 | 813 | 0d | Cnes_DPU | NC FM_Spare spare for PCB correction | 07/09/15 FM_Spare spare for PCB correction |
| 815 | 3.7.16.8 | FM_Spare Thermal glue |  | 1d | 2015-09-07 | 2015-09-08 | 814 | 0d | Cnes_DPU | NC FM_Spare Thermal glue | 08/09/15 FM_Spare Thermal glue |
| 816 | 3.7.16.9 | FM_Spare Installation into frame |  | 1d | 2015-09-08 | 2015-09-09 | 815 | 0d | Cnes_DPU | NC FM_Spare Installation into frame | 09/09/15 FM_Spare Installation into frame |
| 817 | 3.7.16.10 | FM_Spare Coating |  | 2d | 2015-09-09 | 2015-09-11 | 816 | 0d | Cnes_DPU | NC FM_Spare Coating | 11/09/15 FM_Spare Coating |
| 818 | 3.7.16.11 | FM_Spare functional test |  | 5d | 2015-09-11 | 2015-09-18 | 817 | 0d | Cnes_DPU | NC FM_Spare functional test | 18/09/15 FM_Spare functional test |
| 819 | 3.7.16.12 | FM_Spare thermal cycling |  | 2d | 2015-09-18 | 2015-09-22 | 818 | 0d | Cnes_DPU | NC FM_Spare thermal cycling | 22/09/15 FM_Spare thermal cycling |
| 820 | 3.7.16.13 | FM_Spare final preparation |  | 2d | 2015-09-22 | 2015-09-24 | 819 | 0d | Cnes_DPU | NC FM_Spare final preparation | 24/09/15 FM_Spare final preparation |
| 821 | 3.7.16.14 | DPU FM_Spare Delivery | milestone | 0d | 2015-09-24 | 2015-09-24 | 820 | 0d | Cnes_DPU | NC DPU FM_Spare Delivery | 24/09/15 DPU FM_Spare Delivery |

| ID | WBS | Task | Type | Duration | Start | Finish | Predecessors | Complete | Remaining | Baseline start | Baseline finish | Baseline duration | Total slack | Free slack | Constraint | Calendar | OldLg | Texte17 | Ancien Num |
| --- | --- | --- | --- | --- | --- | --- | --- | --- | --- | --- | --- | --- | --- | --- | --- | --- | --- | --- | --- |
| 822 | 3.8 | **EGSE/SGSE update for MEB & RPW tests** |  | 258d? | 2014-09-01 | 2015-09-08 |  |  |  | 2012-12-24 | 2014-07-30 | 398d | 0d |  |  |  | 395 | 578 | 411 |
| 823 | 3.8.1 | SGSE update |  | 252d | 2014-09-01 | 2015-08-31 |  |  |  |  |  |  | 0d |  | start no earlier than 2014-09-01 |  |  |  |  |
| 824 | 3.8.2 | EGSE stimuli part | milestone | 1d | 2015-04-07 | 2015-04-07 |  |  |  |  |  |  | 0d |  | start no earlier than 2015-04-07 |  |  |  |  |
| 825 | 3.8.3 | EGSE synchronisation part | milestone | 1d? | 2015-09-08 | 2015-09-08 |  |  |  |  |  |  | 0d |  | start no earlier than 2015-09-08 |  |  |  |  |
| 826 | 3.9 | **Harness (MEB>MEB)** |  | 201.5d | 2014-11-27 | 2015-09-16 |  |  |  | 2012-11-12 | 2014-03-26 | 346d | 0d |  |  |  | 325 | 501 | 340 |
| 827 | 3.9.1 | **Harness MEB EM2** |  | 71d | 2014-11-27 | 2015-03-09 |  |  |  |  |  |  | 0d |  |  |  |  | 512 |  |
| 828 | 3.9.1.1 | **Harnesses procurement EM2** |  | 71d | 2014-11-27 | 2015-03-09 |  |  |  |  |  |  | 0d |  |  |  |  | 513 |  |
| 829 | 3.9.1.1.1 | Internal MEB2 Harnesses Delivery |  | 27d | 2015-01-09 | 2015-02-16 |  |  |  |  |  |  | 0d |  | start no earlier than 2015-01-09 |  |  |  |  |
| 830 | 3.9.1.1.2 | **MEB2 to Spacecraft I/F** |  | 71d | 2014-11-27 | 2015-03-09 |  |  |  |  |  |  | 0d |  |  |  |  |  |  |
| 831 | 3.9.1.1.2.1 | Complementary Cnes tests |  | 16d | 2014-11-27 | 2014-12-18 |  |  |  |  |  |  | 0d |  | start no earlier than 2014-11-27 |  |  |  |  |
| 832 | 3.9.1.1.2.2 | Development Harnesses EM2 |  | 45d | 2015-01-06 | 2015-03-09 |  |  |  |  |  |  | 17.5d |  | start no earlier than 2015-01-06 |  |  |  |  |
| 833 | 3.9.2 | **Harness MEB FM** |  | 83d | 2015-05-20 | 2015-09-16 |  |  |  | 2013-11-04 | 2014-03-26 | 100d | 0d |  |  |  | 336 | 518 | 351 |
| 834 | 3.9.2.1 | **Harnesses procurement FM** |  | 83d | 2015-05-20 | 2015-09-16 |  |  |  |  |  |  | 0d |  |  |  |  | 519 |  |
| 835 | 3.9.2.1.1 | Development of DPU Harnesses |  | 47d | 2015-05-20 | 2015-07-28 | 1065 |  |  |  |  |  | 2d |  | start no earlier than 2014-11-27 |  |  |  |  |
| 836 | 3.9.2.1.2 | Procurement of all others harnesses |  | 83d | 2015-05-20 | 2015-09-16 | 1065 |  |  |  |  |  | 0d |  | start no earlier than 2014-10-16 |  |  | 520 |  |
| 837 | 3.9.2.1.3 | Harnesses delivery | milestone | 0d | 2015-09-16 | 2015-09-16 | 836 |  |  |  |  |  | 0d |  |  |  |  | 522 |  |
| 838 | 3.10 | **Software developments** |  | 788d | 2012-12-06 A | 2016-01-29 |  | 10% | 710.57d | 2012-04-30 | 2015-01-05 | 673d | 0d |  |  | Cnes_DAS_IDB | 350 | 536 | 365 |
| 839 | 3.10.1 | **Software analysers (LFR, TDS, TNR/HFR)** |  | 249d | 2014-10-01 | 2015-09-25 |  |  |  |  |  |  | 0d |  |  |  |  |  |  |
| 840 | 3.10.1.1 | DRB/CDR R2 analysers |  | 2d | 2014-10-01 | 2014-10-02 |  |  |  |  |  |  | 0d |  | start no earlier than 2014-10-01 |  |  |  |  |
| 841 | 3.10.1.2 | SW analysers R3 Development |  | 104d | 2014-10-03 | 2015-03-02 | 840 |  |  |  |  |  | 0d |  |  |  |  |  |  |
| 842 | 3.10.1.3 | SW analysers R3 finalisation |  | 110d | 2015-03-24 | 2015-09-01 | 848, 841 |  |  |  |  |  | 0d |  |  |  |  |  |  |
| 843 | 3.10.1.4 | DRB/QR R3 (before PFMs boards delivery) |  | 15d | 2015-09-07 | 2015-09-25 |  |  |  |  |  |  | 0d |  | start no earlier than 2015-09-07 |  |  |  |  |
| 844 | 3.10.2 | **DAS** |  | 790d | 2012-12-06 A | 2016-01-29 |  | 31% | 545.82d |  |  |  | 0d |  |  |  |  |  |  |
| 845 | 3.10.2.1 | PDR DAS |  | 34d | 2012-12-06 A | 2013-01-24 A |  | 100% |  | 2012-12-06 | 2013-01-21 | 31d |  |  | start no earlier than 2012-12-06 |  | 352 | 538 | 367 |
| 846 | 3.10.2.2 | DAS R2 DRB/CDR |  | 2d | 2014-10-17 | 2014-10-20 |  |  |  |  |  |  | 134d |  | start no earlier than 2014-10-17 |  |  |  |  |
| 847 | 3.10.2.3 | DAS R3 beta1 : delivery for FM AIT preparation & pre-validation | milestone | 0d | 2015-02-27 | 2015-02-27 |  |  |  |  |  |  | 2d |  | start no earlier than 2015-02-27 |  |  |  |  |
| 848 | 3.10.2.4 | DAS R3 beta1 / Analyzer S/W R3 coupling tests |  | 15d | 2015-03-03 | 2015-03-23 | 841, 847 |  |  |  |  |  | 0d |  |  |  |  |  |  |
| 849 | 3.10.2.5 | DAS R3 beta2 (2.6) : delivery for FM AIT preparation & pre-validation | milestone | 0d | 2015-05-04 | 2015-05-04 | 846 |  |  |  |  |  | 0d |  | start no earlier than 2015-05-04 |  |  |  |  |
| 850 | 3.10.2.6 | DAS R3 beta2 (2.8) : delivery for FM AIT preparation & pre-validation | milestone | 0d | 2015-07-13 | 2015-07-13 |  |  |  |  |  |  | 10.5d |  | start no earlier than 2015-07-13 |  |  |  |  |
| 851 | 3.10.2.7 | DAS R3 (3.0.0.0) : delivery for Validation | milestone | 0d | 2015-08-31 | 2015-08-31 |  |  |  |  |  |  | 11d | 0d | start no earlier than 2015-08-31 |  |  |  |  |
| 852 | 3.10.2.8 | DAS R3 TRR | milestone | 0d | 2015-09-15 | 2015-09-15 | 851 |  |  |  |  |  | 0d |  | start no earlier than 2015-09-15 |  |  |  |  |
| 853 | 3.10.2.9 | DAS R3 - validation |  | 40d | 2015-09-01 | 2015-10-26 | 851FS+1d |  |  |  |  |  | 27d | 0d |  |  |  |  |  |
| 854 | 3.10.2.10 | DAS R3 - finalization |  | 19d | 2015-10-27 | 2015-11-23 | 853 |  |  |  |  |  | 27d | 0d |  |  |  |  |  |
| 855 | 3.10.2.11 | DAS R3 : final delivery for PFM | milestone | 0d | 2015-11-23 | 2015-11-23 | 854 |  |  |  |  |  | 27d |  |  |  |  |  |  |
| 856 | 3.10.2.12 | DAS QR / AR | milestone | 0d | 2016-01-29 | 2016-01-29 | 855 |  |  |  |  |  | 0d |  | start no earlier than 2016-01-29 |  |  |  |  |

Notes:
- 822: ECHEANCE: NC EGSE/SGSE update for MEB & RPW tests / FIN+NOM: 08/09/15 EGSE/SGSE update for MEB & RPW tests
- 823: ECHEANCE: NC SGSE update / FIN+NOM: 31/08/15 SGSE update
- 824: ECHEANCE: NC EGSE stimuli part / FIN+NOM: 07/04/15 EGSE stimuli part
- 825: ECHEANCE: NC EGSE synchronisation part / FIN+NOM: 08/09/15 EGSE synchronisation part
- 826: FIN+NOM: 16/09/15 Harness (MEB>MEB)
- 827: FIN+NOM: 09/03/15 Harness MEB EM2
- 828: FIN+NOM: 09/03/15 Harnesses procurement EM2
- 829: ECHEANCE: NC Internal MEB2 Harnesses Delivery / FIN+NOM: 16/02/15 Internal MEB2 Harnesses Delivery
- 830: ECHEANCE: NC MEB2 to Spacecraft I/F / FIN+NOM: 09/03/15 MEB2 to Spacecraft I/F
- 831: ECHEANCE: NC Complementary Cnes tests / FIN+NOM: 18/12/14 Complementary Cnes tests
- 832: ECHEANCE: NC Development Harnesses EM2 / FIN+NOM: 09/03/15 Development Harnesses EM2
- 833: FIN+NOM: 16/09/15 Harness MEB FM
- 834: FIN+NOM: 16/09/15 Harnesses procurement FM
- 835: ECHEANCE: NC Development of DPU Harnesses / FIN+NOM: 28/07/15 Development of DPU Harnesses
- 836: ECHEANCE: NC Procurement of all others harnesses / FIN+NOM: 16/09/15 Procurement of all others harnesses
- 837: ECHEANCE: NC Harnesses delivery / FIN+NOM: 16/09/15 Harnesses delivery
- 838: FIN+NOM: 29/01/16 Software developments
- 839: ECHEANCE: NC Software analysers / FIN+NOM: 25/09/15 Software analysers (LFR, TDS, TNR/HFR)
- 840: ECHEANCE: NC DRB/CDR R2 analysers / FIN+NOM: 02/10/14 DRB/CDR R2 analysers
- 841: ECHEANCE: NC SW analysers R3 Development / FIN+NOM: 02/03/15 SW analysers R3 Development
- 842: ECHEANCE: NC SW analysers R3 finalisation / FIN+NOM: 01/09/15 SW analysers R3 finalisation
- 843: ECHEANCE: NC DRB/QR R3 (before PFMs boards delivery) / FIN+NOM: 25/09/15 DRB/QR R3 (before PFMs boards delivery)
- 844: ECHEANCE: NC DAS / FIN+NOM: 29/01/16 DAS
- 845: ECHEANCE: NC PDR DAS / FIN+NOM: 24/01/13 PDR DAS
- 846: ECHEANCE: NC DAS R2 DRB/CDR / FIN+NOM: 20/10/14 DAS R2 DRB/CDR
- 847: ECHEANCE: NC DAS R3 beta1 : delivery for FM AIT preparation & pre-validation / FIN+NOM: 27/02/15 DAS R3 beta1 : delivery for FM AIT preparation & pre-validation
- 848: ECHEANCE: NC DAS R3 beta1 / Analyzer S/W R3 coupling tests / FIN+NOM: 23/03/15 DAS R3 beta1 / Analyzer S/W R3 coupling tests
- 849: ECHEANCE: NC DAS R3 beta2 (2.6) : delivery for FM AIT preparation & pre-validation / FIN+NOM: 04/05/15 DAS R3 beta2 (2.6) : delivery for FM AIT preparation & pre-validation
- 850: ECHEANCE: NC DAS R3 beta2 (2.8) : delivery for FM AIT preparation & pre-validation / FIN+NOM: 13/07/15 DAS R3 beta2 (2.8) : delivery for FM AIT preparation & pre-validation
- 851: ECHEANCE: NC DAS R3 (3.0.0.0) : delivery for Validation / FIN+NOM: 31/08/15 DAS R3 (3.0.0.0) : delivery for Validation
- 852: ECHEANCE: NC DAS R3 TRR / FIN+NOM: 15/09/15 DAS R3 TRR
- 853: ECHEANCE: NC DAS R3 - validation / FIN+NOM: 26/10/15 DAS R3 - validation
- 854: ECHEANCE: NC DAS R3 - finalization / FIN+NOM: 23/11/15 DAS R3 - finalization
- 855: ECHEANCE: NC DAS R3 : final delivery for PFM / FIN+NOM: 23/11/15 DAS R3 : final delivery for PFM
- 856: ECHEANCE: NC DAS QR / AR / FIN+NOM: 29/01/16 DAS QR / AR

| ID | WBS | Task | Type | Duration | Start | Finish | Predecessors | Complete | Remaining | Baseline start | Baseline finish | Baseline duration | Total slack | Free slack | Constraint | ECHEANCE | FIN+NOM | OldLg | Texte17 | Ancien Num |
| --- | --- | --- | --- | --- | --- | --- | --- | --- | --- | --- | --- | --- | --- | --- | --- | --- | --- | --- | --- | --- |
| 857 | 3.10.3 | **DBS** |  | 181d | 2014-06-26 | 2015-03-12 |  |  |  |  |  |  | 0d |  |  | NC DBS | 12/03/15 DBS |  |  |  |
| 858 | 3.10.3.1 | DBS QR/DRB (V1.0) |  | 2d | 2014-06-26 | 2014-06-27 |  |  |  |  |  |  | 0d |  | start no earlier than 2014-06-26 | NC DBS QR/DRB (V1.0) | 27/06/14 DBS QR/DRB (V1.0) |  |  |  |
| 859 | 3.10.3.2 | DBS acceptance (V1.1) | milestone | 1d | 2014-12-01 | 2014-12-01 |  |  |  |  |  |  | 0d |  | start no earlier than 2014-11-30 | NC DBS acceptance (V1.1) | 01/12/14 DBS acceptance (V1.1) |  |  |  |
| 860 | 3.10.3.3 | Wait for esa inputs for DBS final version V1.2 | milestone | 1d | 2015-01-20 | 2015-01-20 |  |  |  |  |  |  | 0d |  | start no earlier than 2015-01-20 | NC Wait for esa inputs for DBS final version V1.2 | 20/01/15 Wait for esa inputs for DBS final version V1.2 |  |  |  |
| 861 | 3.10.3.4 | DBS TRB/QR (V1.2) | milestone | 1d | 2015-03-12 | 2015-03-12 | 760SS |  |  |  |  |  | 0d |  | start no earlier than 2014-12-08 | NC DBS TRB/QR (V1.2) | 12/03/15 DBS TRB/QR (V1.2) |  |  |  |
| 862 | 3.11 | **IDB** |  | 430d | 2014-04-15 | 2016-01-04 |  |  |  |  |  |  | 0d |  |  | NC IDB | 04/01/16 IDB |  |  |  |
| 863 | 3.11.1 | IDB EM to ESA | milestone | 0d | 2014-04-15 | 2014-04-15 |  |  |  |  |  |  | 0d |  | start no earlier than 2014-04-15 | NC IDB EM to ESA | 15/04/14 IDB EM to ESA |  |  |  |
| 864 | 3.11.2 | IDB PFM to ESA | milestone | 0d | 2016-01-04 | 2016-01-04 | 855 |  |  |  |  |  | 0d |  | start no earlier than 2016-01-04 | NC IDB PFM to ESA | 04/01/16 IDB PFM to ESA |  |  |  |
| 865 | 3.12 | **AIT MEB** |  | 457.5d | 2014-07-21 A | 2016-05-11 |  | 2% | 447.3d |  |  |  | 0d |  |  | NC AIT MEB | 11/05/16 AIT MEB |  |  |  |
| 866 | 3.12.1 | **MEB EM2 integration** |  | 258.5d | 2014-07-21 A | 2015-07-30 |  | 4% | 248.16d | 2014-04-01 | 2014-07-29 | 80d | 0d |  |  |  | 30/07/15 MEB EM2 integration | 570 | 719 | 596 |
| 867 | 3.12.1.1 | **EM2 Units Delivery** |  | 216d | 2014-07-21 A | 2015-06-01 |  | 50% | 108d |  |  |  | 40.5d |  |  | NC EQM Units Delivery… à compléter | 01/06/15 EM2 Units Delivery |  |  |  |
| 868 | 3.12.1.1.1 | Chassis EQM delivery | milestone | 0d | 2014-07-21 A | 2014-07-21 A | 243SS | 100% |  |  |  |  |  |  |  | NC Chassis EQM delivery | 21/07/14 Chassis EQM delivery |  |  |  |
| 869 | 3.12.1.1.2 | LVPS-PDU EM3 Delivery | milestone | 0d | 2014-12-16 | 2014-12-16 | 293SS |  |  |  |  |  | 42d | 0d |  | NC LVPS-PDU EM3 Delivery | 16/12/14 LVPS-PDU EM3 Delivery |  |  |  |
| 870 | 3.12.1.1.3 | LVPS-PDU EM4 dummy Delivery | milestone | 0d | 2015-03-02 | 2015-03-02 |  |  |  |  |  |  | 16d | 0d | start no earlier than 2015-03-02 | NC LVPS-PDU EM4 dummy Delivery | 02/03/15 LVPS-PDU EM4 dummy Delivery |  |  |  |
| 871 | 3.12.1.1.4 | LVPS-PDU EM4 Delivery | milestone | 0d | 2015-06-01 | 2015-06-01 | 322SS |  |  |  |  |  | 40.5d | 0d |  | NC LVPS-PDU EM4 Delivery | 01/06/15 LVPS-PDU EM4 Delivery |  |  |  |
| 872 | 3.12.1.1.5 | BIAS Pre-EQM2 delivery | milestone | 0d | 2015-01-21 | 2015-01-21 | 405SS |  |  |  |  |  | 20d | 0d |  | NC BIAS Pre-EQM2 delivery | 21/01/15 BIAS Pre-EQM2 delivery |  |  |  |
| 873 | 3.12.1.1.6 | TDS EM2 delivery | milestone | 0d | 2015-01-26 | 2015-01-26 | 464SS |  |  |  |  |  | 22d | 0d |  | NC TDS EM2 delivery | 26/01/15 TDS EM2 delivery |  |  |  |
| 874 | 3.12.1.1.7 | LFR EM2 delivery | milestone | 0d | 2015-03-09 | 2015-03-09 | 550SS, 549SS |  |  |  |  |  | 0d |  |  | NC LFR EM2 delivery | 09/03/15 LFR EM2 delivery |  |  |  |
| 875 | 3.12.1.1.8 | TNR/HFR EM2 delivery | milestone | 0d | 2015-02-26 | 2015-02-26 | 636SS |  |  |  |  |  | 1d | 0d |  | NC TNR/HFR EM2 delivery | 26/02/15 TNR/HFR EM2 delivery |  |  |  |
| 876 | 3.12.1.1.9 | DPU Pre-EQM delivery | milestone | 0d | 2014-10-16 A | 2014-10-16 A | 700SS | 100% |  |  |  |  |  |  |  | NC DPU Pre-EQM delivery | 16/10/14 DPU Pre-EQM delivery |  |  |  |
| 877 | 3.12.1.1.10 | DPU Pre-EQM + DAS R2 Tests |  | 5d | 2014-10-16 A | 2014-10-22 A | 876 | 100% |  |  |  |  |  |  |  | NC DPU Pre-EQM + DAS R2 Tests | 22/10/14 DPU Pre-EQM + DAS R2 Tests |  |  |  |
| 878 | 3.12.1.1.11 | DPU EM2B delivery | milestone | 0d | 2015-01-23 | 2015-01-23 | 724SS |  |  |  |  |  | 35d | 0d |  | NC DPU EM2B delivery | 23/01/15 DPU EM2B delivery |  |  |  |
| 879 | 3.12.1.1.12 | DPU EM2B + DAS R2 Tests |  | 5d | 2015-01-26 | 2015-01-30 | 878 |  |  |  |  |  | 35d | 0d |  | NC DPU EM2B + DAS R2 Tests | 30/01/15 DPU EM2B + DAS R2 Tests |  |  |  |
| 880 | 3.12.1.1.13 | PCB PA LF tested (STEEL) | milestone | 0d | 2014-12-17 | 2014-12-17 |  |  |  |  |  |  | 0d |  | start no earlier than 2014-12-17 | NC PCB PA LF tested (STEEL) | 17/12/14 PCB PA LF tested (STEEL) |  |  |  |

| ID | WBS | Task | Duration | Start | Finish | Predecessors | Complete | Remaining | Total slack | Free slack | Constraint |
| --- | --- | --- | --- | --- | --- | --- | --- | --- | --- | --- | --- |
| 881 | 3.12.1.2 | **Subunit acceptance** | 102d | 2014-10-16 A | 2015-03-11 |  | 13% | 88.4d | 9d |  |  |
| 882 | 3.12.1.2.1 | LVPS-PDU EM3 acceptance | 2d | 2014-12-16 | 2014-12-17 | 869 |  |  | 42d | 0d |  |
| 883 | 3.12.1.2.2 | LVPS-PDU EM4 dummy acceptance | 1d | 2015-03-02 | 2015-03-02 | 870 |  |  | 16d |  | start no earlier than 2015-03-02 |
| 884 | 3.12.1.2.3 | BIAS Pre-EQM2 acceptance | 2d | 2015-01-22 | 2015-01-23 | 872 |  |  | 20d | 0d |  |
| 885 | 3.12.1.2.4 | TDS EM2 acceptance | 2d | 2015-01-27 | 2015-01-28 | 873 |  |  | 22d | 0d |  |
| 886 | 3.12.1.2.5 | LFR EM2 acceptance | 2d | 2015-03-10 | 2015-03-11 | 874 |  |  | 0d |  |  |
| 887 | 3.12.1.2.6 | TNR/HFR EM2 acceptance | 2d | 2015-02-26 | 2015-02-27 | 875 |  |  | 1d | 0d |  |
| 888 | 3.12.1.2.7 | DPU Pre-EQM acceptance | 2d | 2014-10-16 A | 2014-10-17 A | 876 | 100% |  |  |  |  |
| 889 | 3.12.1.2.8 | DPU EM2B acceptance | 2d | 2015-02-02 | 2015-02-03 | 879 |  |  | 35d |  |  |
| 890 | 3.12.1.3 | **MEB EM2 Integration tests** | 73.5d | 2014-12-18 | 2015-04-02 |  |  |  | 0d |  |  |
| 891 | 3.12.1.3.1 | **Electrical coupling tests** | 62d | 2014-12-18 | 2015-03-17 |  |  |  | 0d |  |  |
| 892 | 3.12.1.3.1.1 | Electrical coupling with DPU Pre-EQM + LVPS-PDU EM3 | 3d | 2014-12-18 | 2014-12-22 | 888, 882 |  |  | 42d | 22d |  |
| 893 | 3.12.1.3.1.2 | Electrical coupling with BIAS | 3d | 2015-01-26 | 2015-01-28 | 892, 884 |  |  | 20d | 0d |  |
| 894 | 3.12.1.3.1.3 | Electrical coupling with TDS | 3d | 2015-01-29 | 2015-02-02 | 885, 892 |  |  | 22d | 2d |  |
| 895 | 3.12.1.3.1.4 | Electrical coupling with LFR | 3d | 2015-03-12 | 2015-03-16 | 886, 892 |  |  | 0d |  |  |
| 896 | 3.12.1.3.1.5 | Coupling with SCM TCS | 0.5d | 2015-03-17 | 2015-03-17 | 895 |  |  | 0.5d |  |  |
| 897 | 3.12.1.3.1.6 | Electrical coupling with TNR/HFR | 3d | 2015-03-02 | 2015-03-04 | 892, 887 |  |  | 1d | 0d |  |
| 898 | 3.12.1.3.1.7 | Primary power variation | 1d | 2015-03-17 | 2015-03-17 | 892, 893, 894, 895, 897 |  |  | 0d |  |  |
| 899 | 3.12.1.3.2 | **Function validation tests** | 39d | 2015-01-29 | 2015-03-24 |  |  |  | 0d |  |  |
| 900 | 3.12.1.3.2.1 | Function validation tests for BIAS (with EM PAs TBC) | 5d | 2015-01-29 | 2015-02-04 | 893 |  |  | 20d | 0d |  |
| 901 | 3.12.1.3.2.2 | Function validation tests for TDS (incl. SW init.) LF part | 1d | 2015-02-05 | 2015-02-05 | 894, 900 |  |  | 20d | 0d |  |
| 902 | 3.12.1.3.2.3 | Function validation tests for TDS (incl. SW init.) HF part | 4d | 2015-02-06 | 2015-02-11 | 894, 901 |  |  | 20d | 19d |  |
| 903 | 3.12.1.3.2.4 | Function validation tests for LFR (incl. SW init.) LF part | 4d | 2015-03-18 | 2015-03-23 | 900, 898, 896 |  |  | 0d |  |  |
| 904 | 3.12.1.3.2.5 | Function validation tests for LFR (incl. SW init.) HF part | 1d | 2015-03-24 | 2015-03-24 | 895, 903 |  |  | 0d |  |  |
| 905 | 3.12.1.3.2.6 | Function validation tests for TNR/HFR (incl. SW init.) | 4d | 2015-03-05 | 2015-03-10 | 897, 900 |  |  | 1d | 0d |  |

Notes:
- 881: ECHEANCE: NC Subunit acceptance / FIN+NOM: 11/03/15 Subunit acceptance
- 882: ECHEANCE: NC LVPS-PDU EM3 acceptance / FIN+NOM: 17/12/14 LVPS-PDU EM3 acceptance
- 883: ECHEANCE: NC LVPS-PDU EM4 dummy acceptance / FIN+NOM: 02/03/15 LVPS-PDU EM4 dummy acceptance
- 884: ECHEANCE: NC BIAS Pre-EQM2 acceptance / FIN+NOM: 23/01/15 BIAS Pre-EQM2 acceptance
- 885: ECHEANCE: NC TDS EM2 acceptance / FIN+NOM: 28/01/15 TDS EM2 acceptance
- 886: ECHEANCE: NC LFR EM2 acceptance / FIN+NOM: 11/03/15 LFR EM2 acceptance
- 887: ECHEANCE: NC TNR/HFR EM2 acceptance / FIN+NOM: 27/02/15 TNR/HFR EM2 acceptance
- 888: ECHEANCE: NC DPU Pre-EQM acceptance / FIN+NOM: 17/10/14 DPU Pre-EQM acceptance
- 889: ECHEANCE: NC DPU EM2B acceptance / FIN+NOM: 03/02/15 DPU EM2B acceptance
- 890: ECHEANCE: NC MEB EM2 Integration tests / FIN+NOM: 02/04/15 MEB EM2 Integration tests
- 891: ECHEANCE: NC Electrical coupling tests / FIN+NOM: 17/03/15 Electrical coupling tests
- 892: ECHEANCE: NC Electrical coupling with DPU Pre-EQM + LVPS-PDU EM3 / FIN+NOM: 22/12/14 Electrical coupling with DPU Pre-EQM + LVPS-PDU EM3
- 893: ECHEANCE: NC Electrical coupling with BIAS / FIN+NOM: 28/01/15 Electrical coupling with BIAS
- 894: ECHEANCE: NC Electrical coupling with TDS / FIN+NOM: 02/02/15 Electrical coupling with TDS
- 895: ECHEANCE: NC Electrical coupling with LFR / FIN+NOM: 16/03/15 Electrical coupling with LFR
- 896: ECHEANCE: NC Coupling with SCM TCS / FIN+NOM: 17/03/15 Coupling with SCM TCS
- 897: ECHEANCE: NC Electrical coupling with TNR/HFR / FIN+NOM: 04/03/15 Electrical coupling with TNR/HFR
- 898: ECHEANCE: NC Primary power variation / FIN+NOM: 17/03/15 Primary power variation
- 899: ECHEANCE: NC Function validation tests / FIN+NOM: 24/03/15 Function validation tests
- 900: ECHEANCE: NC Function validation tests for BIAS (with EM PAs TBC) / FIN+NOM: 04/02/15 Function validation tests for BIAS (with EM PAs TBC)
- 901: ECHEANCE: NC Function validation tests for TDS (incl. SW init.) LF part / FIN+NOM: 05/02/15 Function validation tests for TDS (incl. SW init.) LF part
- 902: ECHEANCE: NC Function validation tests for TDS (incl. SW init.) HF part / FIN+NOM: 11/02/15 Function validation tests for TDS (incl. SW init.) HF part
- 903: ECHEANCE: NC Function validation tests for LFR (incl. SW init.) LF part / FIN+NOM: 23/03/15 Function validation tests for LFR (incl. SW init.) LF part
- 904: ECHEANCE: NC Function validation tests for LFR (incl. SW init.) HF part / FIN+NOM: 24/03/15 Function validation tests for LFR (incl. SW init.) HF part
- 905: ECHEANCE: NC Function validation tests for TNR/HFR (incl. SW init.) / FIN+NOM: 10/03/15 Function validation tests for TNR/HFR (incl. SW init.)

| ID | WBS | Task | Type | Duration | Start | Finish | Predecessors | Baseline start | Baseline finish | Baseline duration | Total slack | Free slack | Constraint | Calendar | ECHEANCE | FIN+NOM | Texte17 | OldLg | Ancien Num |
| --- | --- | --- | --- | --- | --- | --- | --- | --- | --- | --- | --- | --- | --- | --- | --- | --- | --- | --- | --- |
| 906 | 3.12.1.3.3 | **Unitary performance tests (resp. Cnes)** |  | 9d | 2015-03-11 | 2015-03-23 |  |  |  |  | 1d |  |  |  | NC Unitary performance tests (resp. Cnes) | 23/03/15 Unitary performance tests (resp. Cnes) |  |  |  |
| 907 | 3.12.1.3.3.1 | Performance tests without LFR |  | 9d | 2015-03-11 | 2015-03-23 | 900, 905, 902 |  |  |  | 1d |  |  |  | NC Performance tests without LFR | 23/03/15 Performance tests without LFR |  |  |  |
| 908 | 3.12.1.3.4 | MEB Assembly |  | 1d | 2015-03-25 | 2015-03-25 | 904, 907, 889, 883 |  |  |  | 0d |  |  |  | NC MEB Assembly | 25/03/15 MEB Assembly |  |  |  |
| 909 | 3.12.1.3.5 | Coupling with SIIS |  | 0.5d | 2015-03-26 | 2015-03-26 | 908 |  |  |  | 0d |  |  |  | NC Coupling with SIIS | 26/03/15 Coupling with SIIS |  |  |  |
| 910 | 3.12.1.3.6 | FFT MEB |  | 3d | 2015-03-26 | 2015-03-31 | 909 |  |  |  | 0d |  |  |  | NC FFT MEB | 31/03/15 FFT MEB |  |  |  |
| 911 | 3.12.1.3.7 | MEB delivery to Cnes (finalisation doc) |  | 2d | 2015-03-31 | 2015-04-02 | 910 |  |  |  | 0d |  |  |  | NC MEB delivery to Cnes (finalisation doc) | 02/04/15 MEB delivery to Cnes (finalisation doc) |  |  |  |
| 912 | 3.12.1.4 | **MEB EM2 Complementary Tests & GSE integration** |  | 85d | 2015-04-02 | 2015-07-30 |  |  |  |  | 0d |  |  | Cnes_MEB_AIT |  | 30/07/15 MEB EM2 Complementary Tests & GSE integration | 728 |  |  |
| 913 | 3.12.1.4.1 | MEB EM2 Complementary Tests |  | 47d | 2015-05-22 | 2015-07-30 | 950SF |  |  |  | 0d |  |  |  | NC MEB EM2 Complementary Tests | 30/07/15 MEB EM2 Complementary Tests |  |  |  |
| 914 | 3.12.1.4.2 | Complementary Performances Tests (Cnes) |  | 5d | 2015-05-13 | 2015-05-20 | 1063 |  |  |  | 0d |  |  | Cnes_MEB_AIT | NC Complementary Performances Tests (Cnes) | 20/05/15 Complementary Performances Tests (Cnes) | 730 |  |  |
| 915 | 3.12.1.4.3 | Assembly and physical properties (Complementary) |  | 2d | 2015-05-20 | 2015-05-22 | 914 |  |  |  | 0d |  |  | Cnes_MEB_AIT | NC Assembly and physical properties (Complementary) | 22/05/15 Assembly and physical properties (Complementary) | 729 |  |  |
| 916 | 3.12.1.4.4 | Complementary Functional Tests (optional) |  | 2d | 2015-05-22 | 2015-05-26 | 915 |  |  |  | 0d |  |  | Cnes_MEB_AIT | NC Complementary Functional Tests (optional) | 26/05/15 Complementary Functional Tests (optional) | 729 |  |  |
| 917 | 3.12.1.4.5 | R3 Update (DAS Beta version + SW R3) |  | 20d | 2015-05-26 | 2015-06-23 | 916 |  |  |  | 0d |  |  | Cnes_MEB_AIT | NC R3 Update (DAS Beta version + SW R3) | 23/06/15 R3 Update (DAS Beta version + SW R3) | 730 |  |  |
| 918 | 3.12.1.4.6 | **GSE integration (LESIA)** |  | 21d | 2015-04-02 | 2015-05-01 |  |  |  |  | 0d |  |  | Cnes_MEB_AIT |  | 01/05/15 GSE integration (LESIA) | 720 |  |  |
| 919 | 3.12.1.4.6.1 | GSE delivery |  | 1d | 2015-04-02 | 2015-04-03 | 911 |  |  |  | 0d |  | start no earlier than 2014-11-17 | Cnes_MEB_AIT | NC GSE delivery | 03/04/15 GSE delivery | 721 |  |  |
| 920 | 3.12.1.4.6.2 | GSE deployement and tests |  | 5d | 2015-04-03 | 2015-04-10 | 919 |  |  |  | 0d |  |  | Cnes_MEB_AIT | NC GSE deployement and tests | 10/04/15 GSE deployement and tests | 722 |  |  |
| 921 | 3.12.1.4.6.3 | Testing of scripts and debug |  | 10d | 2015-04-10 | 2015-04-24 | 920 |  |  |  | 0d |  |  | Cnes_MEB_AIT | NC Testing of scripts and debug | 24/04/15 Testing of scripts and debug | 723 |  |  |
| 922 | 3.12.1.4.6.4 | GSE integration in AIT procedures |  | 5d | 2015-04-24 | 2015-05-01 | 921 |  |  |  | 0d |  |  | Cnes_MEB_AIT | NC GSE integration in AIT procedures | 01/05/15 GSE integration in AIT procedures | 724 |  |  |
| 923 | 3.12.1.4.7 | ROC (RPW Operation Center) delivery |  | 1d | 2015-06-30 | 2015-06-30 |  |  |  |  | 0d |  | start no earlier than 2015-06-30 |  | NC ROC (RPW Operation Center) delivery | 30/06/15 ROC (RPW Operation Center) delivery |  |  |  |
| 924 | 3.12.1.4.8 | MEB EM2 delivery to Cnes + update GSE |  | 1d | 2015-07-01 | 2015-07-01 | 923 |  |  |  | 0d |  |  |  | NC MEB EM2 delivery to Cnes + update GSE | 01/07/15 MEB EM2 delivery to Cnes + update GSE |  |  |  |
| 925 | 3.12.2 | **MEB PFM integration** |  | 270.5d | 2015-04-20 | 2016-05-11 |  | 2014-07-30 | 2014-12-04 | 90d | 0d |  |  | Cnes_MEB_AIT |  | 11/05/16 MEB PFM integration | 805 | 618 | 644 |
| 926 | 3.12.2.1 | **PFM Units Delivery** |  | 270.5d | 2015-04-20 | 2016-05-11 |  |  |  |  | 0d |  |  | Cnes_MEB_AIT | NC EQM Units Delivery… à compléter | 11/05/16 PFM Units Delivery |  |  |  |
| 927 | 3.12.2.1.1 | Chassis PFM delivery for integration | milestone | 0d | 2015-04-20 | 2015-04-20 | 260SS |  |  |  | 0d |  |  | Cnes_MEB_AIT | NC Chassis PFM delivery for integration | 20/04/15 Chassis PFM delivery for integration |  |  |  |
| 928 | 3.12.2.1.2 | LVPS-PDU PFM nom+ red Delivery for integration | milestone | 0d | 2015-11-20 | 2015-11-20 | 345SS |  |  |  | 0d |  |  | Cnes_MEB_AIT | NC LVPS-PDU PFM nom+ red Delivery for integration | 20/11/15 LVPS-PDU PFM nom+ red Delivery for integration |  |  |  |
| 929 | 3.12.2.1.3 | LVPS-PDU PFMs | milestone | 0d | 2015-11-20 | 2015-11-20 | 345SS |  |  |  | 1d | 0d |  | Cnes_MEB_AIT | NC LVPS-PDU PFMs | 20/11/15 LVPS-PDU PFMs |  |  |  |
| 930 | 3.12.2.1.4 | LVPS-PDU FM spare Delivery for integration | milestone | 0d | 2016-05-11 | 2016-05-11 | 360SS |  |  |  | 0d |  |  | Cnes_MEB_AIT | NC LVPS-PDU FM spare Delivery for integration | 11/05/16 LVPS-PDU FM spare Delivery for integration |  |  |  |
| 931 | 3.12.2.1.5 | BIAS PFM delivery for integration | milestone | 0d | 2015-09-28 | 2015-09-28 | 427SS |  |  |  | 85.5d | 0d |  | Cnes_MEB_AIT | NC BIAS PFM delivery for integration | 28/09/15 BIAS PFM delivery for integration |  |  |  |
| 932 | 3.12.2.1.6 | TDS PFM delivery for integration | milestone | 0d | 2015-10-01 | 2015-10-01 | 488SS |  |  |  | 92.5d | 0d |  | Cnes_MEB_AIT | NC TDS PFM delivery for integration | 01/10/15 TDS PFM delivery for integration |  |  |  |
| 933 | 3.12.2.1.7 | LFR PFM delivery for integration | milestone | 0d | 2015-10-30 | 2015-10-30 | 581SS |  |  |  | 66d | 0d |  | Cnes_MEB_AIT | NC LFR PFM delivery for integration | 30/10/15 LFR PFM delivery for integration |  |  |  |
| 934 | 3.12.2.1.8 | TNR/HFR PFM delivery for integration | milestone | 0d | 2015-10-28 | 2015-10-28 | 660SS |  |  |  | 83.5d | 0d |  | Cnes_MEB_AIT | NC TNR/HFR PFM delivery for integration | 28/10/15 TNR/HFR PFM delivery for integration |  |  |  |
| 935 | 3.12.2.1.9 | DPU PFM1 delivery for integration | milestone | 0d | 2015-07-28 | 2015-07-28 | 790SS |  |  |  | 0d |  |  | Cnes_MEB_AIT | NC DPU PFM1 delivery for integration | 28/07/15 DPU PFM1 delivery for integration |  |  |  |
| 936 | 3.12.2.1.10 | DPU PFM2 delivery for integration | milestone | 0d | 2015-08-26 | 2015-08-26 | 805SS |  |  |  | 64d | 0d |  | Cnes_MEB_AIT | NC DPU PFM2 delivery for integration | 26/08/15 DPU PFM2 delivery for integration |  |  |  |
| 937 | 3.12.2.1.11 | DPU PFM spare delivery for integration | milestone | 0d | 2015-09-24 | 2015-09-24 | 821SS |  |  |  | 0d |  |  | Cnes_MEB_AIT | NC DPU PFM spare delivery for integration | 24/09/15 DPU PFM spare delivery for integration |  |  |  |
| 938 | 3.12.2.1.12 | Harness (MEB>MEB) delivery for integration | milestone | 0d | 2015-09-16 | 2015-09-16 | 837SS |  |  |  | 0d |  |  | Cnes_MEB_AIT | NC Harness (MEB>MEB) delivery for integration | 16/09/15 Harness (MEB>MEB) delivery for integration |  |  |  |
| 939 | 3.12.2.1.13 | DAS R3 beta2 Integration with DPU PFM1 |  | 1d | 2015-07-28 | 2015-07-29 | 935, 850 |  |  |  | 0d |  |  | Cnes_MEB_AIT | NC DAS R3 beta2 Integration with DPU PFM1 | 29/07/15 DAS R3 beta2 Integration with DPU PFM1 |  |  |  |

Notes:
- 913: Tâche pour chronologie

| ID | WBS | Task | Type | Duration | Start | Finish | Predecessors | Total slack | Free slack |
| --- | --- | --- | --- | --- | --- | --- | --- | --- | --- |
| 940 | 3.12.2.2 | **Subunit acceptance** |  | 124.5d | 2015-06-01 | 2015-11-24 |  | 40.5d |  |
| 941 | 3.12.2.2.1 | LVPS-PDU PFM nom+ red acceptance |  | 2d | 2015-11-20 | 2015-11-24 | 929 | 1d | 0d |
| 942 | 3.12.2.2.2 | LVPS-PDU EM4 acceptance |  | 2d | 2015-06-01 | 2015-06-02 | 871 | 40.5d |  |
| 943 | 3.12.2.2.3 | BIAS PFM acceptance |  | 2d | 2015-09-28 | 2015-09-30 | 931 | 89.5d | 0d |
| 944 | 3.12.2.2.4 | TDS FM acceptance |  | 2d | 2015-10-01 | 2015-10-05 | 932 | 96.5d | 0d |
| 945 | 3.12.2.2.5 | LFR FM acceptance |  | 2d | 2015-11-02 | 2015-11-03 | 933 | 70d | 0d |
| 946 | 3.12.2.2.6 | TNR/HFR FM acceptance |  | 2d | 2015-10-28 | 2015-10-30 | 934 | 87.5d | 0d |
| 947 | 3.12.2.2.7 | DPU PFM1 acceptance |  | 2d | 2015-07-28 | 2015-07-30 | 935 | 0d |  |
| 948 | 3.12.2.2.8 | DPU PFM2 acceptance |  | 2d | 2015-08-26 | 2015-08-28 | 936 | 63d | 62d |
| 949 | 3.12.2.3 | **Electrical coupling tests (first part)** |  | 3d | 2015-07-30 | 2015-08-04 |  | 0d |  |
| 950 | 3.12.2.3.1 | DPU PFM1/LVPS-PDU EM4 coupling | milestone | 3d | 2015-07-30 | 2015-08-04 | 947, 942, 835 | 0d |  |
| 951 | 3.12.2.4 | **Wait for boards deliveries** |  | 41d | 2015-08-04 | 2015-09-30 | 950 | 0d |  |
| 952 | 3.12.2.4.1 | Wait for boards deliveries (Begin) | milestone | 0d | 2015-08-04 | 2015-08-04 | 950FF | 0d |  |
| 953 | 3.12.2.4.2 | Wait for boards deliveries (End) | milestone | 0d | 2015-09-30 | 2015-09-30 | 954SS | 0d |  |
| 954 | 3.12.2.5 | **AIT MEB** |  | 116.5d | 2015-09-30 | 2016-03-15 |  | 0d |  |
| 955 | 3.12.2.5.1 | **MEB PFM AIT Electrical coupling with all PFM boards** |  | 28.5d | 2015-09-30 | 2015-11-09 |  | 88d |  |
| 956 | 3.12.2.5.1.1 | Electrical coupling with BIAS |  | 3d | 2015-09-30 | 2015-10-05 | 950, 943, 836 | 89.5d | 0d |
| 957 | 3.12.2.5.1.2 | Electrical coupling with TDS |  | 3d | 2015-10-05 | 2015-10-08 | 950, 944, 836 | 96.5d | 21.5d |
| 958 | 3.12.2.5.1.3 | Electrical coupling with LFR |  | 3d | 2015-11-04 | 2015-11-06 | 950, 945, 836 | 70d | 0d |
| 959 | 3.12.2.5.1.4 | Coupling with SCM TCS |  | 0.5d | 2015-11-09 | 2015-11-09 | 958 | 88.5d |  |
| 960 | 3.12.2.5.1.5 | Electrical coupling with TNR/HFR |  | 3d | 2015-10-30 | 2015-11-04 | 950, 946, 836 | 87.5d | 0d |
| 961 | 3.12.2.5.1.6 | Primary power variation |  | 1d | 2015-11-09 | 2015-11-09 | 950, 956, 957, 958, 960 | 88d |  |
| 962 | 3.12.2.5.2 | **Function validation tests** |  | 34.5d | 2015-10-05 | 2015-11-23 |  | 79d |  |
| 963 | 3.12.2.5.2.1 | Function validation tests for BIAS (with EM PAs TBC) |  | 5d | 2015-10-05 | 2015-10-12 | 956 | 89.5d | 17d |
| 964 | 3.12.2.5.2.2 | Function validation tests for TDS (incl. SW init.) LF part |  | 1d | 2015-11-17 | 2015-11-17 | 963, 957, 967 | 70d | 0d |
| 965 | 3.12.2.5.2.3 | Function validation tests for TDS (incl. SW init.) HF part |  | 4d | 2015-11-18 | 2015-11-23 | 957, 964, 963 | 70d | 0d |
| 966 | 3.12.2.5.2.4 | Function validation tests for LFR (incl. SW init.) LF part |  | 4d | 2015-11-09 | 2015-11-13 | 963, 958 | 70d | 0d |
| 967 | 3.12.2.5.2.5 | Function validation tests for LFR (incl. SW init.) HF part |  | 1d | 2015-11-16 | 2015-11-16 | 966, 963 | 70d | 0d |
| 968 | 3.12.2.5.2.6 | Function validation tests for TNR/HFR (incl. SW init.) |  | 4d | 2015-11-04 | 2015-11-10 | 960, 963 | 87.5d |  |

Notes:
- 940: ECHEANCE: NC Subunit acceptance / FIN+NOM: 24/11/15 Subunit acceptance
- 941: ECHEANCE: NC LVPS-PDU PFM nom+ red acceptance / FIN+NOM: 24/11/15 LVPS-PDU PFM nom+ red acceptance
- 942: ECHEANCE: NC LVPS-PDU EM4 acceptance / FIN+NOM: 02/06/15 LVPS-PDU EM4 acceptance
- 943: ECHEANCE: NC BIAS PFM acceptance / FIN+NOM: 30/09/15 BIAS PFM acceptance
- 944: ECHEANCE: NC TDS FM acceptance / FIN+NOM: 05/10/15 TDS FM acceptance
- 945: ECHEANCE: NC LFR FM acceptance / FIN+NOM: 03/11/15 LFR FM acceptance
- 946: ECHEANCE: NC TNR/HFR FM acceptance / FIN+NOM: 30/10/15 TNR/HFR FM acceptance
- 947: ECHEANCE: NC DPU PFM1 acceptance / FIN+NOM: 30/07/15 DPU PFM1 acceptance
- 948: ECHEANCE: NC DPU PFM2 acceptance / FIN+NOM: 28/08/15 DPU PFM2 acceptance
- 949: ECHEANCE: NC Electrical coupling tests / FIN+NOM: 04/08/15 Electrical coupling tests (first part)
- 950: ECHEANCE: NC DPU PFM1/LVPS-PDU EM4 coupling / FIN+NOM: 04/08/15 DPU PFM1/LVPS-PDU EM4 coupling
- 951: ECHEANCE: NC Wait for boards deliveries / FIN+NOM: 30/09/15 Wait for boards deliveries
- 952: ECHEANCE: NC Wait for boards deliveries (Begin) / FIN+NOM: 04/08/15 Wait for boards deliveries (Begin)
- 953: ECHEANCE: NC Wait for boards deliveries (End) / FIN+NOM: 30/09/15 Wait for boards deliveries (End)
- 954: ECHEANCE: NC AIT MEB / FIN+NOM: 15/03/16 AIT MEB
- 955: ECHEANCE: NC MEB PFM AIT Electrical coupling with all PFM boards / FIN+NOM: 09/11/15 MEB PFM AIT Electrical coupling with all PFM boards
- 956: ECHEANCE: NC Electrical coupling with BIAS / FIN+NOM: 05/10/15 Electrical coupling with BIAS
- 957: ECHEANCE: NC Electrical coupling with TDS / FIN+NOM: 08/10/15 Electrical coupling with TDS
- 958: ECHEANCE: NC Electrical coupling with LFR / FIN+NOM: 06/11/15 Electrical coupling with LFR
- 959: ECHEANCE: NC Coupling with SCM TCS / FIN+NOM: 09/11/15 Coupling with SCM TCS
- 960: ECHEANCE: NC Electrical coupling with TNR/HFR / FIN+NOM: 04/11/15 Electrical coupling with TNR/HFR
- 961: ECHEANCE: NC Primary power variation / FIN+NOM: 09/11/15 Primary power variation
- 962: ECHEANCE: NC Function validation tests / FIN+NOM: 23/11/15 Function validation tests
- 963: ECHEANCE: NC Function validation tests for BIAS (with EM PAs TBC) / FIN+NOM: 12/10/15 Function validation tests for BIAS (with EM PAs TBC)
- 964: ECHEANCE: NC Function validation tests for TDS (incl. SW init.) LF part / FIN+NOM: 17/11/15 Function validation tests for TDS (incl. SW init.) LF part
- 965: ECHEANCE: NC Function validation tests for TDS (incl. SW init.) HF part / FIN+NOM: 23/11/15 Function validation tests for TDS (incl. SW init.) HF part
- 966: ECHEANCE: NC Function validation tests for LFR (incl. SW init.) LF part / FIN+NOM: 13/11/15 Function validation tests for LFR (incl. SW init.) LF part
- 967: ECHEANCE: NC Function validation tests for LFR (incl. SW init.) HF part / FIN+NOM: 16/11/15 Function validation tests for LFR (incl. SW init.) HF part
- 968: ECHEANCE: NC Function validation tests for TNR/HFR (incl. SW init.) / FIN+NOM: 10/11/15 Function validation tests for TNR/HFR (incl. SW init.)

| ID | WBS | Task | Type | Duration | Start | Finish | Predecessors | Complete | Remaining | Baseline start | Baseline finish | Baseline duration | Total slack | Free slack | Constraint | Calendar | Texte17 | OldLg | Ancien Num |
| --- | --- | --- | --- | --- | --- | --- | --- | --- | --- | --- | --- | --- | --- | --- | --- | --- | --- | --- | --- |
| 969 | 3.12.2.5.3 | **Unitary performance tests (resp. Cnes)** |  | 9d | 2015-11-24 | 2015-12-04 |  |  |  |  |  |  | 70d |  |  |  |  |  |  |
| 970 | 3.12.2.5.3.1 | Performance tests without TNR/HFR |  | 9d | 2015-11-24 | 2015-12-04 | 965 |  |  |  |  |  | 70d |  |  |  |  |  |  |
| 971 | 3.12.2.5.4 | MEB Assembly |  | 1d | 2015-11-24 | 2015-11-25 | 941 |  |  |  |  |  | 1d | 0d |  |  |  |  |  |
| 972 | 3.12.2.5.5 | Electrical coupling all units |  | 8d | 2015-11-25 | 2015-12-07 | 971, 948 |  |  |  |  |  | 1d | 0d |  |  |  |  |  |
| 973 | 3.12.2.5.6 | **TRR (LESIA)** |  | 5d | 2015-12-07 | 2015-12-14 |  |  |  |  |  |  | 1d |  |  |  |  |  |  |
| 974 | 3.12.2.5.6.1 | TRR datapack preparation |  | 4d | 2015-12-07 | 2015-12-11 | 972 |  |  |  |  |  | 1d | 0d |  |  |  |  |  |
| 975 | 3.12.2.5.6.2 | TRR |  | 1d | 2015-12-11 | 2015-12-14 | 974 |  |  |  |  |  | 1d | 0d |  |  |  |  |  |
| 976 | 3.12.2.5.7 | Coupling with SIIS |  | 0.5d | 2015-12-14 | 2015-12-14 | 975 |  |  |  |  |  | 1d | 0d |  |  |  |  |  |
| 977 | 3.12.2.5.8 | Redundancy swapping |  | 3d | 2015-12-15 | 2015-12-17 | 976 |  |  |  |  |  | 1d | 0d |  |  |  |  |  |
| 978 | 3.12.2.5.9 | FFT MEB |  | 3d | 2015-12-18 | 2015-12-22 | 977 |  |  |  |  |  | 1d | 0d |  |  |  |  |  |
| 979 | 3.12.2.5.10 | FDIR tests |  | 10d | 2015-12-23 | 2016-01-07 | 978 |  |  |  |  |  | 1d |  |  |  |  |  |  |
| 980 | 3.12.2.5.11 | Thermal vaccum tests (responsability LESIA) |  | 8d | 2016-01-11 | 2016-01-20 | 220, 979 |  |  |  |  |  | 0d |  |  |  |  |  |  |
| 981 | 3.12.2.5.12 | Thermal calibration / noise flow & dynamique (responsability Cnes) |  | 20d | 2016-01-21 | 2016-02-17 | 980, 220 |  |  |  |  |  | 0d |  |  |  |  |  |  |
| 982 | 3.12.2.5.13 | Transportation to Mechano-ID |  | 2d | 2016-02-18 | 2016-02-19 | 981 |  |  |  |  |  | 0d |  |  |  |  |  |  |
| 983 | 3.12.2.5.14 | Shock tests |  | 1d | 2016-02-22 | 2016-02-22 | 982 |  |  |  |  |  | 0d |  |  |  |  |  |  |
| 984 | 3.12.2.5.15 | Vibrations tests |  | 4d | 2016-02-23 | 2016-02-26 | 983 |  |  |  |  |  | 0d |  |  |  |  |  |  |
| 985 | 3.12.2.5.16 | FFT MEB |  | 3d | 2016-02-29 | 2016-03-02 | 984 |  |  |  |  |  | 0d |  |  |  |  |  |  |
| 986 | 3.12.2.5.17 | **MEB delivery to CNES** |  | 9d | 2016-03-03 | 2016-03-15 |  |  |  |  |  |  | 0d |  |  | Cnes_MEB_AIT | 757 |  |  |
| 987 | 3.12.2.5.17.1 | Datapack preparation |  | 5d | 2016-03-03 | 2016-03-09 | 985 |  |  |  |  |  | 0d |  |  | Cnes_MEB_AIT | 758 |  |  |
| 988 | 3.12.2.5.17.2 | TRB/DRB |  | 1d | 2016-03-10 | 2016-03-10 | 987 |  |  |  |  |  | 0d |  |  | Cnes_MEB_AIT | 759 |  |  |
| 989 | 3.12.2.5.17.3 | Packing and shipment |  | 2d | 2016-03-11 | 2016-03-14 | 988 |  |  |  |  |  | 0d |  |  | Cnes_MEB_AIT | 760 |  |  |
| 990 | 3.12.2.5.17.4 | MEB PFM delivery to CNES |  | 1d | 2016-03-15 | 2016-03-15 | 989 |  |  |  |  |  | 0d |  |  | Cnes_MEB_AIT | 761 |  |  |
| 991 | 4 | **SCM** |  | 619d | 2013-06-14 A | 2015-11-27 |  |  | 616.58d | 2012-05-11 | 2014-08-04 | 559d | 75d |  |  |  | 179 | 139 | 148 |
| 992 | 4.1 | Components procurement ( FM) |  | 420d | 2013-06-14 | 2015-02-12 |  |  |  | 2013-01-11 | 2013-08-16 | 150d | 0d |  | start no earlier than 2013-06-14 |  | 216 | 172 | 183 |
| 993 | 4.2 | 3D PA prototype validated | milestone | 0d | 2014-10-31 | 2014-10-31 |  |  |  |  |  |  | 82d |  | start no earlier than 2014-10-31 |  |  |  |  |
| 994 | 4.3 | SCM mech elements materials procurement | milestone | 0d | 2013-07-10 A | 2013-07-10 A |  | 100% |  | 2013-07-26 | 2013-09-06 | 30d |  |  | start no earlier than 2013-07-10 |  | 234 | 187 | 200 |

Notes:
- 969: ECHEANCE: NC Unitary performance tests (resp. Cnes) / FIN+NOM: 04/12/15 Unitary performance tests (resp. Cnes)
- 970: ECHEANCE: NC Performance tests without TNR/HFR / FIN+NOM: 04/12/15 Performance tests without TNR/HFR
- 971: ECHEANCE: NC MEB Assembly / FIN+NOM: 25/11/15 MEB Assembly
- 972: ECHEANCE: NC Electrical coupling all units / FIN+NOM: 07/12/15 Electrical coupling all units
- 973: ECHEANCE: NC TRR (LESIA) / FIN+NOM: 14/12/15 TRR (LESIA)
- 974: ECHEANCE: NC TRR datapack preparation / FIN+NOM: 11/12/15 TRR datapack preparation
- 975: ECHEANCE: NC TRR / FIN+NOM: 14/12/15 TRR
- 976: ECHEANCE: NC Coupling with SIIS / FIN+NOM: 14/12/15 Coupling with SIIS
- 977: ECHEANCE: NC Redundancy swapping / FIN+NOM: 17/12/15 Redundancy swapping
- 978: ECHEANCE: NC FFT MEB / FIN+NOM: 22/12/15 FFT MEB
- 979: ECHEANCE: NC FDIR tests / FIN+NOM: 07/01/16 FDIR tests
- 980: ECHEANCE: NC Thermal vaccum tests (responsability LESIA) / FIN+NOM: 20/01/16 Thermal vaccum tests (responsability LESIA)
- 981: ECHEANCE: NC Thermal calibration / noise flow & dynamique (responsability Cnes) / FIN+NOM: 17/02/16 Thermal calibration / noise flow & dynamique (responsability Cnes)
- 982: ECHEANCE: NC Transportation to Mechano-ID / FIN+NOM: 19/02/16 Transportation to Mechano-ID
- 983: ECHEANCE: NC Shock tests / FIN+NOM: 22/02/16 Shock tests
- 984: ECHEANCE: NC Vibrations tests / FIN+NOM: 26/02/16 Vibrations tests
- 985: ECHEANCE: NC FFT MEB / FIN+NOM: 02/03/16 FFT MEB
- 986: FIN+NOM: 15/03/16 MEB delivery to CNES
- 987: ECHEANCE: NC Datapack preparation / FIN+NOM: 09/03/16 Datapack preparation
- 988: ECHEANCE: NC TRB/DRB / FIN+NOM: 10/03/16 TRB/DRB
- 989: ECHEANCE: NC Packing and shipment / FIN+NOM: 14/03/16 Packing and shipment
- 990: ECHEANCE: NC MEB PFM delivery to CNES / FIN+NOM: 15/03/16 MEB PFM delivery to CNES
- 991: FIN+NOM: 27/11/15 SCM
- 992: ECHEANCE: NC Components procurement ( FM) / FIN+NOM: 12/02/15 Components procurement ( FM)
- 993: ECHEANCE: NC 3D PA prototype validated / FIN+NOM: 31/10/14 3D PA prototype validated
- 994: prédecesseur? / ECHEANCE: NC SCM mech elements materials procurement / FIN+NOM: 10/07/13 SCM mech elements materials procurement

| ID | WBS | Task | Type | Duration | Start | Finish | Predecessors | Complete | Remaining | Baseline start | Baseline finish | Baseline duration | Total slack | Free slack | Constraint | ECHEANCE | FIN+NOM | OldLg | Texte17 | Ancien Num |
| --- | --- | --- | --- | --- | --- | --- | --- | --- | --- | --- | --- | --- | --- | --- | --- | --- | --- | --- | --- | --- |
| 995 | 4.4 | **SCM PFM** |  | 357d | 2014-07-01 A | 2015-11-27 |  | 1% | 354.93d |  |  |  | 75d |  |  | NC SCM PFM | 27/11/15 SCM PFM |  |  |  |
| 996 | 4.4.1 | **SCM PFM fabrication** |  | 288.5d | 2014-07-01 A | 2015-08-24 |  | 1% | 286.46d |  |  |  | 10.5d |  |  | NC SCM PFM fabrication | 24/08/15 SCM PFM fabrication |  |  |  |
| 997 | 4.4.1.1 | **SCM ANT PFM** |  | 196d | 2014-07-01 | 2015-04-08 |  |  |  | 2013-09-03 | 2013-09-23 | 15d | 71d |  |  |  | 08/04/15 SCM ANT PFM | 158 | 200 | 169 |
| 998 | 4.4.1.1.1 | Ferrite cores procurement ( FM) |  | 40d | 2014-07-01 | 2014-08-27 |  |  |  | 2013-03-11 | 2013-06-07 | 60d | 137d | 66d | start no earlier than 2014-07-01 | NC Ferrite cores procurement ( FM) | 27/08/14 Ferrite cores procurement ( FM) | 154 | 196 | 165 |
| 999 | 4.4.1.1.2 | Epoxy flanges manufacturing |  | 15d | 2014-12-01 | 2014-12-19 | 998 |  |  |  |  |  | 71d | 0d | start no earlier than 2014-12-01 | NC Epoxy flanges manufacturing | 19/12/14 Epoxy flanges manufacturing |  |  |  |
| 1000 | 4.4.1.1.3 | Antennas coiling (FM ) |  | 50d | 2014-12-22 | 2015-03-03 | 999, 998 |  |  | 2013-06-10 | 2013-09-02 | 60d | 71d | 0d |  | NC Antennas coiling (FM ) | 03/03/15 Antennas coiling (FM ) | 155 | 197 | 166 |
| 1001 | 4.4.1.1.4 | Antennas burn-in |  | 15d | 2015-03-04 | 2015-03-24 | 1000 |  |  |  |  |  | 71d | 0d |  | NC Antennas burn-in | 24/03/15 Antennas burn-in |  |  |  |
| 1002 | 4.4.1.1.5 | Antennas FM cabling |  | 10d | 2015-03-25 | 2015-04-08 | 1001 |  |  | 2013-09-03 | 2013-09-23 | 15d | 71d | 0d |  | NC Antennas FM cabling | 08/04/15 Antennas FM cabling | 159 | 201 | 170 |
| 1003 | 4.4.1.1.6 | SCM ANT ready for FM AIT | milestone | 0d | 2015-04-08 | 2015-04-08 | 1002 |  |  | 2013-09-23 | 2013-09-23 | 0d | 71d |  |  | NC SCM ANT ready for FM AIT | 08/04/15 SCM ANT ready for FM AIT | 160 | 202 | 171 |
| 1004 | 4.4.1.2 | **SCM PA PFM** |  | 130d | 2015-02-13 | 2015-08-21 |  |  |  | 2013-01-11 | 2013-12-24 | 240d | 0d |  |  |  | 21/08/15 SCM PA PFM | 171 | 215 | 182 |
| 1005 | 4.4.1.2.1 | 3D PA JFET transistor adjustment |  | 10d | 2015-02-13 | 2015-02-26 | 992 |  |  |  |  |  | 0d |  |  | NC 3D PA JFET transistor adjustment | 26/02/15 3D PA JFET transistor adjustment |  |  |  |
| 1006 | 4.4.1.2.2 | MRR | milestone | 1d | 2015-02-27 | 2015-02-27 | 1005 |  |  |  |  |  | 0d |  |  | NC MRR | 27/02/15 MRR |  |  |  |
| 1007 | 4.4.1.2.3 | 3D PA Manufacturing FM |  | 80d | 2015-02-27 | 2015-06-25 | 1005, 993 |  |  | 2013-08-19 | 2013-12-10 | 80d | 0d |  |  | NC 3D PA Manufacturing FM | 25/06/15 3D PA Manufacturing FM | 173 | 217 | 184 |
| 1008 | 4.4.1.2.4 | MIP | milestone | 1d | 2015-06-04 | 2015-06-04 | 1007FF-15d |  |  |  |  |  | 0d |  |  | NC MIP | 04/06/15 MIP |  |  |  |
| 1009 | 4.4.1.2.5 | 3D PA FM LAT |  | 40d | 2015-06-26 | 2015-08-21 | 1007 |  |  | 2013-12-11 | 2014-02-06 | 40d | 11d |  |  | NC 3D PA FM LAT | 21/08/15 3D PA FM LAT | 177 | 222 | 189 |
| 1010 | 4.4.1.2.6 | 3D PA Acceptance |  | 10d | 2015-06-26 | 2015-07-09 | 1007 |  |  | 2014-02-07 | 2014-02-28 | 16d | 24d | 0d |  | NC 3D PA Acceptance | 09/07/15 3D PA Acceptance | 178 | 223 | 190 |
| 1011 | 4.4.1.2.7 | SCM PA FM ready for SENSOR FM AIT | milestone | 0d | 2015-07-09 | 2015-07-09 | 1010 |  |  | 2014-02-28 | 2014-02-28 | 0d | 24d |  |  | NC SCM PA FM ready for SENSOR FM AIT | 09/07/15 SCM PA FM ready for SENSOR FM AIT | 179 | 224 | 191 |
| 1012 | 4.4.1.3 | **SCM mechanical element FM** |  | 30d | 2015-06-11 | 2015-07-23 |  |  |  | 2013-07-26 | 2013-10-18 | 60d | 0d |  |  |  | 23/07/15 SCM mechanical element FM | 186 | 233 | 199 |
| 1013 | 4.4.1.3.1 | Mechanical elements manufacturing |  | 30d | 2015-06-11 | 2015-07-23 | 994, 1038 |  |  | 2013-09-09 | 2013-10-18 | 30d | 0d |  |  | NC Mechanical elements manufacturing | 23/07/15 Mechanical elements manufacturing | 188 | 235 | 201 |
| 1014 | 4.4.1.3.2 | SCM mechanical elements ready for FM AIT | milestone | 0d | 2015-07-23 | 2015-07-23 | 1013 |  |  | 2013-10-18 | 2013-10-18 | 0d | 0d |  |  | NC SCM mechanical elements ready for FM AIT | 23/07/15 SCM mechanical elements ready for FM AIT | 189 | 236 | 202 |
| 1015 | 4.4.1.4 | **SCM Thermal I/F FM** |  | 235d | 2014-09-08 | 2015-08-13 |  |  |  | 2013-09-23 | 2013-12-17 | 60d | 0d |  |  |  | 13/08/15 SCM Thermal I/F FM | 198 | 249 | 213 |
| 1016 | 4.4.1.4.1 | SCM TCS PFM Design updated |  | 15d | 2015-03-10 | 2015-03-30 | 550, 549 |  |  | 2013-09-23 | 2013-12-17 | 60d | 0d |  |  | NC SCM TCS PFM Design updated | 30/03/15 SCM TCS PFM Design updated | 199 | 250 | 214 |
| 1017 | 4.4.1.4.2 | Iteration with ESA/ASTRIUM on MLI interface |  | 100d | 2014-09-08 | 2015-01-28 | 1033 |  |  |  |  |  | 0d |  |  | NC Iteration with ESA/ASTRIUM on MLI interface | 28/01/15 Iteration with ESA/ASTRIUM on MLI interface |  |  |  |
| 1018 | 4.4.1.4.3 | SCM MLI design update |  | 40d | 2015-01-29 | 2015-03-25 | 1017 |  |  |  |  |  | 0d |  |  | NC SCM MLI design update | 25/03/15 SCM MLI design update |  |  |  |

| ID | WBS | Task | Type | Duration | Start | Finish | Predecessors | Complete | Baseline start | Baseline finish | Baseline duration | Total slack | Free slack | Constraint | OldLg | Texte17 | Ancien Num |
| --- | --- | --- | --- | --- | --- | --- | --- | --- | --- | --- | --- | --- | --- | --- | --- | --- | --- |
| 1019 | 4.4.1.4.4 | **Caracterisation interface thermal coupling (fastenning torque)** |  | 30d | 2015-01-13 | 2015-02-23 |  |  |  |  |  | 57d |  |  |  |  |  |
| 1020 | 4.4.1.4.4.1 | Design and manufacturing thermal mock-up of base plate |  | 15d | 2015-01-13 | 2015-02-02 | 1036 |  |  |  |  | 57d | 0d |  |  |  |  |
| 1021 | 4.4.1.4.4.2 | Mock-up thermal tests + Tests report |  | 15d | 2015-02-03 | 2015-02-23 | 1020 |  |  |  |  | 57d | 0d |  |  |  |  |
| 1022 | 4.4.1.4.5 | SCM EM MLI manufacturing |  | 30d | 2015-03-26 | 2015-05-11 | 1018 |  |  |  |  | 0d |  |  |  |  |  |
| 1023 | 4.4.1.4.6 | SCM FM MLI design update + manufacturing |  | 45d | 2015-06-11 | 2015-08-13 | 1038, 1022 |  |  |  |  | 0d |  |  |  |  |  |
| 1024 | 4.4.1.4.7 | SCM heater design update (following thermal analisis) |  | 10d | 2015-02-24 | 2015-03-09 | 1021 |  |  |  |  | 57d | 0d |  |  |  |  |
| 1025 | 4.4.1.4.8 | SCM FM heater manufacturing |  | 50d | 2015-03-10 | 2015-05-22 | 1024 |  |  |  |  | 57d |  |  |  |  |  |
| 1026 | 4.4.1.5 | **SCM Harness (Pigtail)** |  | 186.5d | 2014-11-25 | 2015-08-24 |  |  | 2013-01-18 | 2014-07-04 | 365d | 0d |  |  | 202 | 253 | 217 |
| 1027 | 4.4.1.5.1 | Design update |  | 15d | 2014-11-25 | 2014-12-15 |  |  |  |  |  | 105.5d |  | start no earlier than 2014-11-25 |  |  |  |
| 1028 | 4.4.1.5.2 | Manufacturing |  | 66d | 2015-05-20 | 2015-08-24 | 1065, 1027 |  | 2014-07-04 | 2014-07-04 | 0d | 0d |  |  | 208 | 259 | 223 |
| 1029 | 4.4.1.6 | **Finalization design and CDR documentation** |  | 5d | 2014-10-24 A | 2014-10-30 A |  | 100% | 2013-09-23 | 2013-10-25 | 25d |  |  |  | 209 | 260 | 224 |
| 1030 | 4.4.1.6.1 | Final documentation SCM for ICDR |  | 5d | 2014-10-24 A | 2014-10-30 A |  | 100% | 2013-10-14 | 2013-10-25 | 10d |  |  | start no earlier than 2014-10-24 | 210 | 261 | 225 |
| 1031 | 4.4.2 | **AIT SCM** |  | 320d | 2014-08-25 | 2015-11-27 |  |  | 2012-11-15 | 2015-02-23 | 571d | 0d |  |  | 424 | 465 | 441 |
| 1032 | 4.4.2.1 | **SCM EM integration** |  | 201d | 2014-08-25 | 2015-06-11 |  |  | 2013-06-14 | 2013-09-20 | 70d | 0d |  |  | 481 | 515 | 505 |
| 1033 | 4.4.2.1.1 | Thermal balance tests |  | 10d | 2014-08-25 | 2014-09-05 |  |  | 2013-08-09 | 2013-09-06 | 20d | 0d |  | start no earlier than 2014-08-25 | 487 | 522 | 511 |
| 1034 | 4.4.2.1.2 | **SCM EM activies** |  | 103d | 2015-01-13 | 2015-06-11 |  |  | 2013-04-02 | 2013-12-05 | 171d | 0d |  |  | 472 | 509 | 495 |
| 1035 | 4.4.2.1.2.1 | Iboom I/F consolidation (ESA & Cnes) | milestone | 0d | 2015-01-28 | 2015-01-28 | 1017, 1036 |  |  |  |  | 0d |  |  |  |  |  |
| 1036 | 4.4.2.1.2.2 | M5 screws ECR accepted | milestone | 0d | 2015-01-13 | 2015-01-13 |  |  |  |  |  | 12d | 0d | start no earlier than 2015-01-13 |  |  |  |
| 1037 | 4.4.2.1.2.3 | Bedplate manufacturing |  | 10d | 2015-01-13 | 2015-01-26 | 1036 |  |  |  |  | 72d |  |  |  |  |  |
| 1038 | 4.4.2.1.2.4 | Mechanical environment qualification tests EM (vibration & Chock) |  | 20d | 2015-05-12 | 2015-06-10 | 1037, 1022 |  |  |  |  | 0d |  |  |  |  |  |
| 1039 | 4.4.2.1.2.5 | SCM EM with EM MLI aivalable for potential Iboom TB tests |  | 1d | 2015-06-11 | 2015-06-11 | 1038 |  |  |  |  | 0d |  |  |  |  |  |
| 1040 | 4.4.2.2 | **PFM SCM AIT** |  | 110d | 2015-06-25 | 2015-11-27 |  |  | 2014-05-19 | 2015-02-23 | 194d | 0d |  |  | 599 | 669 | 625 |
| 1041 | 4.4.2.2.1 | **SCM PFM integration** |  | 110d | 2015-06-25 | 2015-11-27 |  |  | 2014-05-28 | 2014-11-25 | 125d | 0d |  |  | 608 | 670 | 634 |
| 1042 | 4.4.2.2.1.1 | Potting resin procurement |  | 20d | 2015-06-25 | 2015-07-24 | 1043SF |  |  |  |  | 0d |  |  |  |  |  |
| 1043 | 4.4.2.2.1.2 | Antennas assembly and potting |  | 15d | 2015-07-24 | 2015-08-13 | 1003, 1014 |  | 2014-05-28 | 2014-07-03 | 25d | 0d |  |  | 609 | 671 | 635 |
| 1044 | 4.4.2.2.1.3 | PA and heater Cabling and assembly |  | 15d | 2015-08-14 | 2015-09-03 | 1043, 1011, 1025 |  | 2014-07-04 | 2014-07-18 | 10d | 0d |  |  | 610 | 672 | 636 |
| 1045 | 4.4.2.2.1.4 | Unit test |  | 2d | 2015-09-04 | 2015-09-07 | 1044 |  | 2014-07-21 | 2014-07-25 | 5d | 0d |  |  | 611 | 673 | 637 |
| 1046 | 4.4.2.2.1.5 | Preamplifier potting |  | 5d | 2015-09-08 | 2015-09-14 | 1045, 1009 |  | 2014-07-28 | 2014-08-01 | 5d | 0d |  |  | 612 | 674 | 638 |
| 1047 | 4.4.2.2.1.6 | TRR | milestone | 1d | 2015-09-15 | 2015-09-15 | 1046 |  |  |  |  | 0d |  |  |  |  |  |
| 1048 | 4.4.2.2.1.7 | Functional tests (perfo, EMC) |  | 5d | 2015-09-15 | 2015-09-21 | 1046 |  | 2014-08-11 | 2014-08-25 | 10d | 75d | 0d |  | 614 | 676 | 640 |
| 1049 | 4.4.2.2.1.8 | Mechanical tests (PFM level) Incl Transportation |  | 5d | 2015-09-22 | 2015-09-28 | 1048 |  | 2014-08-26 | 2014-11-18 | 60d | 75d | 0d |  | 615 | 677 | 641 |
| 1050 | 4.4.2.2.1.9 | Thermal tests (PFM level) Incl Transportation |  | 25d | 2015-09-29 | 2015-11-02 | 1049 |  | 2014-08-26 | 2014-11-18 | 60d | 75d | 0d |  | 615 | 677 | 641 |
| 1051 | 4.4.2.2.1.10 | Final functionnal tests, perf. verification |  | 5d | 2015-11-03 | 2015-11-09 | 1050 |  | 2014-11-19 | 2014-11-25 | 5d | 75d | 0d |  | 616 | 678 | 642 |
| 1052 | 4.4.2.2.1.11 | EIDP Delivery |  | 5d | 2015-11-10 | 2015-11-17 | 1051 |  |  |  |  | 75d | 0d |  |  |  |  |
| 1053 | 4.4.2.2.1.12 | TRB/DRB |  | 5d | 2015-11-18 | 2015-11-24 | 1052 |  |  |  |  | 75d | 0d |  |  |  |  |
| 1054 | 4.4.2.2.1.13 | Packing and shipment |  | 2d | 2015-11-25 | 2015-11-26 | 1053 |  |  |  |  | 75d | 0d |  |  |  |  |
| 1055 | 4.4.2.2.1.14 | SCM PFM delivery to CNES | milestone | 1d | 2015-11-27 | 2015-11-27 | 1054 |  |  |  |  | 75d |  |  |  |  |  |
| 1056 | 4.4.2.2.1.15 | SCM PFM for RPW AIT | milestone | 1d | 2015-11-27 | 2015-11-27 | 1054 |  |  |  |  | 75d |  |  |  |  |  |

Notes:
- 1019: ECHEANCE: NC Caracterisation interface thermal coupling (fastenning torque) / FIN+NOM: 23/02/15 Caracterisation interface thermal coupling (fastenning torque)
- 1020: ECHEANCE: NC Design and manufacturing thermal mock-up of base plate / FIN+NOM: 02/02/15 Design and manufacturing thermal mock-up of base plate
- 1021: ECHEANCE: NC Mock-up thermal tests + Tests report / FIN+NOM: 23/02/15 Mock-up thermal tests + Tests report
- 1022: ECHEANCE: NC SCM EM MLI manufacturing / FIN+NOM: 11/05/15 SCM EM MLI manufacturing
- 1023: ECHEANCE: NC SCM FM MLI design update + manufacturing / FIN+NOM: 13/08/15 SCM FM MLI design update + manufacturing
- 1024: ECHEANCE: NC SCM heater design update (following thermal analisis) / FIN+NOM: 09/03/15 SCM heater design update (following thermal analisis)
- 1025: ECHEANCE: NC SCM FM heater manufacturing / FIN+NOM: 22/05/15 SCM FM heater manufacturing
- 1026: FIN+NOM: 24/08/15 SCM Harness (Pigtail)
- 1027: ECHEANCE: NC Design update / FIN+NOM: 15/12/14 Design update
- 1028: ECHEANCE: NC Manufacturing / FIN+NOM: 24/08/15 Manufacturing
- 1029: FIN+NOM: 30/10/14 Finalization design and CDR documentation
- 1030: ECHEANCE: NC Final documentation SCM for ICDR / FIN+NOM: 30/10/14 Final documentation SCM for ICDR
- 1031: FIN+NOM: 27/11/15 AIT SCM
- 1032: ECHEANCE: NC SCM EM integration / FIN+NOM: 11/06/15 SCM EM integration
- 1033: ECHEANCE: NC Thermal balance tests / FIN+NOM: 05/09/14 Thermal balance tests
- 1034: ECHEANCE: NC EM SCM complementary tests / FIN+NOM: 11/06/15 SCM EM activies
- 1035: ECHEANCE: NC Iboom I/F consolidation (ESA & Cnes) / FIN+NOM: 28/01/15 Iboom I/F consolidation (ESA & Cnes)
- 1036: ECHEANCE: NC M5 screws ECR accepted / FIN+NOM: 13/01/15 M5 screws ECR accepted
- 1037: ECHEANCE: NC Bedplate manufacturing / FIN+NOM: 26/01/15 Bedplate manufacturing
- 1038: ECHEANCE: NC Mechanical environment qualification tests EM (vibration & Chock) / FIN+NOM: 10/06/15 Mechanical environment qualification tests EM (vibration & Chock)
- 1039: ECHEANCE: NC SCM EM with EM MLI aivalable for potential Iboom TB tests / FIN+NOM: 11/06/15 SCM EM with EM MLI aivalable for potential Iboom TB tests
- 1040: FIN+NOM: 27/11/15 PFM SCM AIT
- 1041: FIN+NOM: 27/11/15 SCM PFM integration
- 1042: ECHEANCE: NC Potting resin procurement / FIN+NOM: 24/07/15 Potting resin procurement
- 1043: ECHEANCE: NC Antennas assembly and potting / FIN+NOM: 13/08/15 Antennas assembly and potting
- 1044: ECHEANCE: NC PA and heater Cabling and assembly / FIN+NOM: 03/09/15 PA and heater Cabling and assembly
- 1045: ECHEANCE: NC Unit test / FIN+NOM: 07/09/15 Unit test
- 1046: ECHEANCE: NC Preamplifier potting / FIN+NOM: 14/09/15 Preamplifier potting
- 1047: ECHEANCE: NC TRR / FIN+NOM: 15/09/15 TRR
- 1048: ECHEANCE: NC Functional tests (perfo, EMC) / FIN+NOM: 21/09/15 Functional tests (perfo, EMC)
- 1049: ECHEANCE: NC Mechanical tests (PFM level) Incl Transportation / FIN+NOM: 28/09/15 Mechanical tests (PFM level) Incl Transportation
- 1050: ECHEANCE: NC Thermal tests (PFM level) Incl Transportation / FIN+NOM: 02/11/15 Thermal tests (PFM level) Incl Transportation
- 1051: ECHEANCE: NC Final functionnal tests, perf. verification / FIN+NOM: 09/11/15 Final functionnal tests, perf. verification
- 1052: ECHEANCE: NC EIDP Delivery / FIN+NOM: 17/11/15 EIDP Delivery
- 1053: ECHEANCE: NC TRB/DRB / FIN+NOM: 24/11/15 TRB/DRB
- 1054: ECHEANCE: NC Packing and shipment / FIN+NOM: 26/11/15 Packing and shipment
- 1055: ECHEANCE: NC SCM PFM delivery to CNES / FIN+NOM: 27/11/15 SCM PFM delivery to CNES
- 1056: ECHEANCE: NC SCM PFM for RPW AIT / FIN+NOM: 27/11/15 SCM PFM for RPW AIT

| ID | WBS | Task | Type | Duration | Start | Finish | Predecessors | Baseline start | Baseline finish | Baseline duration | Total slack | Calendar | Texte17 | OldLg | Ancien Num |
| --- | --- | --- | --- | --- | --- | --- | --- | --- | --- | --- | --- | --- | --- | --- | --- |
| 1057 | 5 | **RPW EM2 AIT (without ANT)** |  | 159.5d | 2015-04-02 | 2015-11-20 |  |  |  |  | 0d |  |  |  |  |
| 1058 | 5.1 | **Tests RPW EM2 ( MEB EM2, SCM EM, PA EQM)** |  | 34d | 2015-04-02 | 2015-05-20 |  |  |  |  | 0d | Cnes_MEB_AIT |  |  |  |
| 1059 | 5.1.1 | Assembling electrical coupling, SFT |  | 1d | 2015-04-02 | 2015-04-03 | 911, 832 |  |  |  | 0d |  |  |  |  |
| 1060 | 5.1.2 | LFR unitary performance tests |  | 2d | 2015-04-03 | 2015-04-08 | 1059 |  |  |  | 0d |  |  |  |  |
| 1061 | 5.1.3 | FFT RPW |  | 1d | 2015-04-08 | 2015-04-09 | 1060 |  |  |  | 0d |  |  |  |  |
| 1062 | 5.1.4 | FFPT RPW (phase shift, cal. SCM, synchro., robust.) |  | 4d | 2015-04-09 | 2015-04-15 | 1061 |  |  |  | 0d |  |  |  |  |
| 1063 | 5.1.5 | EMC RPW testing with PA at Intespace (+SCM EM) conduiting & radiating + Transportation (1J) |  | 20d | 2015-04-15 | 2015-05-13 | 1062 |  |  |  | 0d | Cnes_MEB_AIT |  |  |  |
| 1064 | 5.1.6 | Finalisation and waiting tests reports |  | 5d | 2015-05-13 | 2015-05-20 | 1063 |  |  |  | 0d | Cnes_MEB_AIT |  |  |  |
| 1065 | 5.1.7 | Go for PFM units | milestone | 0d | 2015-05-20 | 2015-05-20 | 1064 |  |  |  | 0d | Cnes_MEB_AIT |  |  |  |
| 1066 | 5.2 | **RPW EM2 complementary tests & PFM AIT preparation** |  | 100d | 2015-07-02 | 2015-11-20 |  |  |  |  | 0d |  |  |  |  |
| 1067 | 5.2.1 | FDIR Tests (Cnes, LESIA) |  | 10d | 2015-07-02 | 2015-07-15 | 924 |  |  |  | 0d | Cnes_MEB_AIT | 730 |  |  |
| 1068 | 5.2.2 | PFM RPW procedure preparartion |  | 100d | 2015-07-02 | 2015-11-20 | 924 |  |  |  | 0d |  |  |  |  |
| 1069 | 6 | **RPW FM AIT (without ANT)** |  | 71.5d | 2016-03-16 | 2016-06-28 |  | 2014-12-08 | 2015-02-23 | 54d | 0d |  | 834 | 637 | 663 |
| 1070 | 6.1 | Electrical integration SCM |  | 1d | 2016-03-16 | 2016-03-16 | 990, 1056, 1055 | 2014-12-08 | 2014-12-12 | 5d | 0d |  | 835 | 638 | 664 |
| 1071 | 6.2 | Electrical integration PA ANT (1, 2 & 3) |  | 1.5d | 2016-03-17 | 2016-03-18 | 189, 1070, 175 | 2014-12-15 | 2014-12-17 | 3d | 0d |  | 836 | 639 | 665 |
| 1072 | 6.3 | Performance (FFT) |  | 2d | 2016-03-18 | 2016-03-22 | 1071 |  |  |  | 0d |  | 840 |  |  |
| 1073 | 6.4 | Calibration in phase |  | 22d | 2016-03-22 | 2016-04-22 | 1072 |  |  |  | 0d |  |  |  |  |
| 1074 | 6.5 | EMC tests (with PA) / including TRR, TRB & transportation |  | 10d | 2016-04-22 | 2016-05-09 | 1072, 1073 | 2015-01-13 | 2015-01-26 | 10d | 0d |  | 841 | 643 | 669 |
| 1075 | 6.6 | FFT |  | 2d | 2016-05-09 | 2016-05-11 | 1074 | 2015-01-27 | 2015-02-09 | 10d | 0d |  | 842 | 644 | 670 |
| 1076 | 6.7 | Bake-out SCM and MEB |  | 10d | 2016-05-11 | 2016-05-26 | 1075 | 2015-02-10 | 2015-02-23 | 10d | 0d |  | 843 | 645 | 671 |
| 1077 | 6.8 | SCM and MEB ready for ESA delivery | milestone | 0d | 2016-05-26 | 2016-05-26 | 1076 |  |  |  | 0d |  | 845 |  |  |
| 1078 | 6.9 | **DRB preparation (SCM + MEB)** |  | 20d | 2016-05-26 | 2016-06-23 |  |  |  |  | 0d |  |  |  |  |
| 1079 | 6.9.1 | EIDP preparation and delivery |  | 5d | 2016-05-26 | 2016-06-02 | 1077 |  |  |  | 0d |  |  |  |  |
| 1080 | 6.9.2 | Questions / answers RIDs |  | 15d | 2016-06-02 | 2016-06-23 | 1079 |  |  |  | 0d |  |  |  |  |
| 1081 | 6.10 | Qualification review |  | 2d | 2016-06-23 | 2016-06-27 | 1080 |  |  |  | 0d |  |  |  |  |
| 1082 | 6.11 | MEB & SCM delivery to ESA | milestone | 1d | 2016-06-27 | 2016-06-28 | 1081 |  |  |  | 0d |  |  |  |  |

Notes:
- 1057: ECHEANCE: NC RPW EM2 AIT (without ANT) / FIN+NOM: 20/11/15 RPW EM2 AIT (without ANT)
- 1058: ECHEANCE: NC Integration LFR / FIN+NOM: 20/05/15 Tests RPW EM2 ( MEB EM2, SCM EM, PA EQM)
- 1059: ECHEANCE: NC Assembling electrical coupling, SFT / FIN+NOM: 03/04/15 Assembling electrical coupling, SFT
- 1060: ECHEANCE: NC LFR unitary performance tests / FIN+NOM: 08/04/15 LFR unitary performance tests
- 1061: ECHEANCE: NC FFT RPW / FIN+NOM: 09/04/15 FFT RPW
- 1062: ECHEANCE: NC FFPT RPW (phase shift, cal. SCM, synchro., robust.) / FIN+NOM: 15/04/15 FFPT RPW (phase shift, cal. SCM, synchro., robust.)
- 1063: ECHEANCE: NC EMC RPW testing with PA at Intespace (+SCM EM) conduiting & radiating + Transportation (1J) / FIN+NOM: 13/05/15 EMC RPW testing with PA at Intespace (+SCM EM) conduiting & radiating + Transportation (1J)
- 1064: ECHEANCE: NC Finalisation and waiting tests reports / FIN+NOM: 20/05/15 Finalisation and waiting tests reports
- 1065: ECHEANCE: NC Go for PFM units / FIN+NOM: 20/05/15 Go for PFM units
- 1066: ECHEANCE: NC RPW com^plementary tests & PFM AIT preparation / FIN+NOM: 20/11/15 RPW EM2 complementary tests & PFM AIT preparation
- 1067: ECHEANCE: NC FDIR Tests (Cnes, LESIA) / FIN+NOM: 15/07/15 FDIR Tests (Cnes, LESIA)
- 1068: ECHEANCE: NC PFM RPW procedure preparartion / FIN+NOM: 20/11/15 PFM RPW procedure preparartion
- 1069: FIN+NOM: 28/06/16 RPW FM AIT (without ANT)
- 1070: ECHEANCE: NC Electrical integration SCM / FIN+NOM: 16/03/16 Electrical integration SCM
- 1071: ECHEANCE: NC Electrical integration PA ANT (1, 2 & 3) / FIN+NOM: 18/03/16 Electrical integration PA ANT (1, 2 & 3)
- 1072: ECHEANCE: NC Performance (FFT) / FIN+NOM: 22/03/16 Performance (FFT)
- 1073: ECHEANCE: NC Calibration in phase / FIN+NOM: 22/04/16 Calibration in phase
- 1074: ECHEANCE: NC EMC tests (with PA) / including TRR, TRB & transportation / FIN+NOM: 09/05/16 EMC tests (with PA) / including TRR, TRB & transportation
- 1075: ECHEANCE: NC FFT / FIN+NOM: 11/05/16 FFT
- 1076: ECHEANCE: NC Bake-out SCM and MEB / FIN+NOM: 26/05/16 Bake-out SCM and MEB
- 1077: ECHEANCE: NC SCM and MEB ready for ESA delivery / FIN+NOM: 26/05/16 SCM and MEB ready for ESA delivery
- 1078: ECHEANCE: NC DRB preparation / FIN+NOM: 23/06/16 DRB preparation (SCM + MEB)
- 1079: ECHEANCE: NC EIDP preparation and delivery / FIN+NOM: 02/06/16 EIDP preparation and delivery
- 1080: ECHEANCE: NC Questions / answers RIDs / FIN+NOM: 23/06/16 Questions / answers RIDs
- 1081: ECHEANCE: NC Qualification review / FIN+NOM: 27/06/16 Qualification review
- 1082: ECHEANCE: NC MEB & SCM delivery to ESA / FIN+NOM: 28/06/16 MEB & SCM delivery to ESA

| ID | WBS | Task | Type | Duration | Start | Finish | Predecessors | Total slack | ECHEANCE | FIN+NOM |
| --- | --- | --- | --- | --- | --- | --- | --- | --- | --- | --- |
| 1083 | 7 | **ANT DRB prep** |  | 26d | 2016-08-18 | 2016-09-22 |  | 0d | NC DRB preparation (Antenna) | 22/09/16 ANT DRB prep |
| 1084 | 7.1 | EIDP preparation and delivery |  | 10d | 2016-08-18 | 2016-08-31 | 106FS-5d | 0d | NC EIDP preparation and delivery | 31/08/16 EIDP preparation and delivery |
| 1085 | 7.2 | Questions / answers RIDs |  | 15d | 2016-09-01 | 2016-09-21 | 1084 | 0d | NC Questions / answers RIDs | 21/09/16 Questions / answers RIDs |
| 1086 | 7.3 | ANT delivery to ESA | milestone | 1d | 2016-09-22 | 2016-09-22 | 1085 | 0d | NC ANT delivery to ESA | 22/09/16 ANT delivery to ESA |
